# GNSO_Council_Program_Management_Tool_20200723

How a schedule from MS Project changed from version to version. A marks actual dates.

## Version 1 (saved 2020-07-18, file GNSO_Council_Program_Management_Tool_20200723.mpp)

| ID | WBS | Task | Duration | Start | Finish | Predecessors | Complete | Total float | Constraint |
| --- | --- | --- | --- | --- | --- | --- | --- | --- | --- |
| 1 | 1 | **GNSO Program Management Planning** | 1713d | 2020-07-01 A | 2027-01-22 |  |  | 0d |  |
| 2 | 1.1 | **RDS - Program Track** | 1103d | 2020-07-01 A | 2024-09-20 |  | 1% | 610d |  |
| 3 | 1.1.1 | **EPDP: Temporary Specification on gTLD Registration Data - Phase 2** | 633d | 2020-07-01 | 2022-12-02 |  |  | 1065d |  |
| 4 |  | Engage EPDP: Temporary Specification on gTLD Registration Data - Phase 2 | 23d | 2020-07-01 | 2020-07-31 |  |  | 1065d |  |
| 5 |  | Council to deliberate and adopt working group consensus recommendations | 40d | 2020-08-03 | 2020-09-25 | 4 |  | 1065d |  |
| 6 |  | Board to deliberate and adopt consensus recommendations | 50d | 2020-09-28 | 2020-12-04 | 5 |  | 1080d |  |
| 7 |  | Engage IRT: Temporary Specification on gTLD Registration Data - Phase 2 | 520d | 2020-12-07 | 2022-12-02 | 6 |  | 1080d |  |
| 8 | 1.1.2 | **Remaining EPDP-P2 Topics (Legal vs. Natural, Unique Contacts, + Accuracy )** | 625d | 2020-08-03 | 2022-12-23 |  |  | 1065d |  |
| 9 | 1.1.2.1 | **Remaining EPDP-P2 Topics Track 1 (Legal vs. Natural + Feasability of Unique Contacts)** | 339d | 2020-08-03 | 2021-11-18 |  |  | 1351d |  |
| 10 |  | Reset EPDP-P2 and elect new Chair | 23d | 2020-08-03 | 2020-09-02 | 4 |  | 1351d |  |
| 11 |  | Engage EPDP-P2 to address remaining topics | 46d | 2020-09-03 | 2020-11-05 | 10 |  | 1351d |  |
| 12 |  | Council to deliberate and adopt working group consensus recommendations | 40d | 2020-11-06 | 2020-12-31 | 11 |  | 1351d |  |
| 13 |  | Board to deliberate and adopt consensus recommendations | 50d | 2021-01-01 | 2021-03-11 | 12 |  | 1351d |  |
| 14 |  | Engage IRT | 180d | 2021-03-12 | 2021-11-18 | 13 |  | 1351d |  |
| 15 | 1.1.2.2 | **Remaining EPDP-P2 Topics Track 2 (Accuracy)** | 585d | 2020-09-28 | 2022-12-23 |  |  | 1065d |  |
| 16 |  | Deliberate scope and decide to request Issues Report | 45d | 2020-09-28 | 2020-11-27 | 5 |  | 1065d | start no earlier than 2020-07-01 |
| 17 |  | Issues Report | 60d | 2020-11-30 | 2021-02-19 | 16 |  | 1065d |  |
| 18 |  | Council to approve PDP launch | 20d | 2021-02-22 | 2021-03-19 | 17 |  | 1065d |  |
| 19 |  | Council to approve scope and charter | 40d | 2021-03-22 | 2021-05-14 | 18 |  | 1065d |  |
| 20 |  | Engage RDS Accuracy PDP | 150d | 2021-05-17 | 2021-12-10 | 19 |  | 1065d |  |
| 21 |  | Council to deliberate and adopt working group consensus recommendations | 40d | 2021-12-13 | 2022-02-04 | 20 |  | 1065d |  |
| 22 |  | Board to deliberate and adopt consensus recommendations | 50d | 2022-02-07 | 2022-04-15 | 21 |  | 1065d |  |
| 23 |  | Engage IRT | 180d | 2022-04-18 | 2022-12-23 | 22 |  | 1065d |  |
| 24 | 1.1.3 | **RDS2 Review Items** | 403d | 2020-07-23 A | 2022-02-07 |  | 94% | 1294d |  |
| 25 | 1.1.3.1 | **RDS2 Review - Recommendation CC.1 (suspension of domain due to incorrect RDS)** | 403d | 2020-07-23 A | 2022-02-07 |  | 83% | 1294d |  |
| 26 |  | Reply to Board on proposed action | 10d | 2020-07-23 A | 2020-08-05 A |  | 100% |  |  |
| 27 |  | Determine if CC.1 can be coupled with Remaining EPDP-P2 Topics (Accuracy) | 1d | 2020-11-30 | 2020-11-30 | 16, 26 |  | 1604d |  |
| 28 |  | CC.1 Implemented | 1d | 2022-02-07 | 2022-02-07 | 21 |  | 1294d |  |
| 29 | 1.1.3.2 | **RDS2 Review - Recommendation CC.4 (measure, audit, etc. of RDS Policies)** | 10d | 2020-07-23 A | 2020-08-05 A |  | 100% |  |  |
| 30 |  | Reply to Board on proposed action | 10d | 2020-07-23 A | 2020-08-05 A |  | 100% |  |  |
| 31 |  | Council will take no action as operating procedures already allow for this | 10d | 2020-07-23 A | 2020-08-05 A |  | 100% |  | start no earlier than 2020-07-23 |
| 32 | 1.1.4 | **IRT: Temporary Specification on gTLD Registration Data - Phase 1** | 545d | 2020-07-01 | 2022-08-02 |  |  | 1168d |  |
| 33 |  | Engage IRT: Temporary Specification on gTLD Registration Data - Phase 1 | 545d | 2020-07-01 | 2022-08-02 |  |  | 1168d |  |
| 34 | 1.1.5 | **EPDP-P1 Rec27 Wave 1 Other Policy Impacts** | 1103d | 2020-07-01 A | 2024-09-20 |  |  | 610d |  |
| 35 | 1.1.5.1 | **Add Grace Period (AGP) Limits Policy [LOW]** | 1d | 2020-07-01 A | 2020-07-01 A |  | 100% |  |  |
| 36 |  | No impacts as a result of Registration Data Services Policy implementation | 1d | 2020-07-01 A | 2020-07-01 A |  | 100% |  |  |
| 37 | 1.1.5.2 | **Additional Whois Information Policy (AWIP) [LOW]** | 90d | 2020-08-03 | 2020-12-04 |  |  | 0d |  |
| 38 |  | Produce redlines of consensus policy provisions (assumes step 2 accomplished here) | 45d | 2020-08-03 | 2020-10-02 |  |  |  |  |
| 39 |  | Review and confirm redlines for final changes | 10d | 2020-10-05 | 2020-10-16 | 38 |  | 1600d |  |
| 40 |  | Conduct public comment of changes | 30d | 2020-10-19 | 2020-11-27 | 39 |  | 1600d |  |
| 41 |  | Post updated consensus policy | 5d | 2020-11-30 | 2020-12-04 | 40 |  | 1600d |  |
| 42 | 1.1.5.3 | **Expired Domain Deletion Policy (EDDP) [MEDIUM]** | 1d | 2021-11-25 | 2021-11-25 |  |  | 0d |  |
| 43 |  | Migrated to Expiration Program | 1d | 2021-11-25 | 2021-11-25 | 158 |  |  |  |
| 44 | 1.1.5.4 | **Expired Registration Recovery Policy (ERRP) [LOW]** | 1d | 2021-11-25 | 2021-11-25 |  |  | 0d |  |
| 45 |  | Migrated to Expiration Program | 1d | 2021-11-25 | 2021-11-25 | 158 |  |  |  |
| 46 | 1.1.5.5 | **Protection of IGO / INGO Identifiers in All gTLDs Policy [LOW]** | 1d | 2020-07-01 A | 2020-07-01 A |  | 100% |  |  |
| 47 |  | No impacts as a result of Registration Data Services Policy implementation | 1d | 2020-07-01 A | 2020-07-01 A |  | 100% |  |  |
| 48 | 1.1.5.6 | **Registry Registration Data Directory Services Consistent Labeling and Display Policy (CL&D) [HIGH]** | 60d | 2020-08-03 | 2020-10-23 |  |  | 0d |  |
| 49 |  | Council to determine next steps based on EPDP-P1-IRT + Rec27 findings | 60d | 2020-08-03 | 2020-10-23 |  |  |  |  |
| 50 | 1.1.5.7 | **Registry Services Evaluation Policy [LOW]** | 1d | 2020-07-01 A | 2020-07-01 A |  | 100% |  |  |
| 51 |  | No impacts as a result of Registration Data Services Policy implementation | 1d | 2020-07-01 A | 2020-07-01 A |  | 100% |  |  |
| 52 | 1.1.5.8 | **Restored Names Accuracy Policy (RNAP) [LOW]** | 146d | 2020-08-03 | 2021-02-22 |  |  | 0d |  |
| 53 | 1.1.5.8.1 | **Track 1 - Item 1** | 90d | 2020-08-03 | 2020-12-04 |  |  | 0d |  |
| 54 |  | Produce redlines of consensus policy provisions | 45d | 2020-08-03 | 2020-10-02 |  |  |  |  |
| 55 |  | Review and confirm redlines for final changes | 10d | 2020-10-05 | 2020-10-16 | 54 |  | 1600d |  |
| 56 |  | Conduct public comment of changes | 30d | 2020-10-19 | 2020-11-27 | 55 |  | 1600d |  |
| 57 |  | Post updated consensus policy | 5d | 2020-11-30 | 2020-12-04 | 56 |  | 1600d |  |
| 58 | 1.1.5.8.2 | **Track 2 - Item 2** | 1d | 2021-02-22 | 2021-02-22 |  |  | 0d |  |
| 59 |  | Migrated to Remaining EPDP-P2 Topics Track 2 (Accuracy) | 1d | 2021-02-22 | 2021-02-22 | 17 |  |  |  |
| 60 | 1.1.5.9 | **Revised ICANN Procedure for Handling Whois Conflicts with Privacy Law [LOW]** | 90d | 2020-08-03 | 2020-12-04 |  |  | 0d |  |
| 61 | 1.1.5.9.1 | **Track 1 - Items 1 to 3** | 45d | 2020-08-03 | 2020-10-02 |  |  | 0d |  |
| 62 |  | Request Whois IAG to consider terminology updates and if policy changes are required | 45d | 2020-08-03 | 2020-10-02 |  |  |  |  |
| 63 | 1.1.5.9.2 | **Track 2** | 45d | 2020-08-03 | 2020-10-02 |  |  | 0d |  |
| 64 |  | Staff to review procedure based on experience and develop report | 45d | 2020-08-03 | 2020-10-02 |  |  |  |  |
| 65 |  | Council to deliberate findings and determine appropriate path | 45d | 2020-10-05 | 2020-12-04 | 62, 64 |  | 1600d |  |
| 66 | 1.1.5.10 | **Thick Whois Transition Policy for .COM, .NET, .JOBS [HIGH]** | 60d | 2020-08-03 | 2020-10-23 |  |  | 0d |  |
| 67 |  | Council to determine next steps based on EPDP-P1-IRT + Rec27 findings | 60d | 2020-08-03 | 2020-10-23 |  |  |  | start no earlier than 2020-08-03 |
| 68 | 1.1.5.11 | **Transfer Policy [HIGH]** | 1d | 2021-02-04 | 2021-02-04 |  |  | 0d |  |
| 69 |  | Migrated to Transfer Program | 1d | 2021-02-04 | 2021-02-04 | 191, 193 |  |  |  |
| 70 | 1.1.5.12 | **Transfer Dispute Resolution Policy (TDRP) [HIGH]** | 1d | 2021-02-04 | 2021-02-04 |  |  | 0d |  |

| ID | WBS | Task | Duration | Start | Finish | Predecessors | Total float | Constraint |
| --- | --- | --- | --- | --- | --- | --- | --- | --- |
| 71 |  | Migrated to Transfer Program | 1d | 2021-02-04 | 2021-02-04 | 199, 201 |  |  |
| 72 | 1.1.5.13 | **Rules for Uniform Domain Name Dispute Resolution Policy (UDRP Rules) [HIGH]** | 1d | 2024-09-20 | 2024-09-20 |  | 0d |  |
| 73 |  | Migrated to RPM Program | 1d | 2024-09-20 | 2024-09-20 | 124, 132 |  |  |
| 74 | 1.1.5.14 | **Uniform Rapid Suspension System Procedure (URS) [HIGH]** | 1d | 2022-03-18 | 2022-03-18 |  | 0d |  |
| 75 |  | Migrated to RPM Program | 1d | 2022-03-18 | 2022-03-18 | 103, 114, 108 |  |  |
| 76 | 1.1.5.15 | **Uniform Rapid Suspension System Rules (URS Rules) [HIGH]** | 1d | 2022-03-18 | 2022-03-18 |  | 0d |  |
| 77 |  | Migrated to RPM Program | 1d | 2022-03-18 | 2022-03-18 | 105, 119, 108 |  |  |
| 78 | 1.1.5.16 | **Whois Data Reminder Policy (WDRP) [MEDIUM]** | 343d | 2020-08-03 | 2021-11-24 |  | 0d |  |
| 79 | 1.1.5.16.1 | **Track 1 - Item 1** | 90d | 2020-08-03 | 2020-12-04 |  | 0d |  |
| 80 |  | Produce redlines of consensus policy provisions | 45d | 2020-08-03 | 2020-10-02 |  |  |  |
| 81 |  | Review and confirm redlines for final changes | 10d | 2020-10-05 | 2020-10-16 | 80 | 1600d |  |
| 82 |  | Conduct public comment of changes | 30d | 2020-10-19 | 2020-11-27 | 81 | 1600d |  |
| 83 |  | Post updated consensus policy | 5d | 2020-11-30 | 2020-12-04 | 82 | 1600d |  |
| 84 | 1.1.5.16.2 | **Track 2 - Items 2 through 6** | 343d | 2020-08-03 | 2021-11-24 |  | 0d |  |
| 85 |  | Council to determine if this issue can be coupled with Accuracy or intruct to Develop Policy Status Report | 60d | 2020-08-03 | 2020-10-23 |  |  |  |
| 86 |  | Council to deliberate findings and determine appropriate path | 45d | 2021-09-23 | 2021-11-24 | 85 |  |  |
| 87 | 1.1.5.17 | **Whois Marketing Restriction Policy [LOW]** | 90d | 2020-08-03 | 2020-12-04 |  | 0d |  |
| 88 |  | Produce redlines of consensus policy provisions | 45d | 2020-08-03 | 2020-10-02 |  |  |  |
| 89 |  | Review and confirm redlines for final changes | 10d | 2020-10-05 | 2020-10-16 | 88 | 1600d |  |
| 90 |  | Conduct public comment of changes | 30d | 2020-10-19 | 2020-11-27 | 89 | 1600d |  |
| 91 |  | Post updated consensus policy | 5d | 2020-11-30 | 2020-12-04 | 90 | 1600d |  |
| 92 | 1.1.6 | **EPDP-P1 Rec27 Wave 1.5 & Wave 2 Other Policy Impacts (pending delivery)** | 90d | 2020-08-03 | 2020-12-04 |  | 0d |  |
| 93 |  | Council to consider Wave 1.5 and Wave 2 reports and determine next steps | 90d | 2020-08-03 | 2020-12-04 |  |  |  |
| 94 | 1.1.7 | **IRT: Privacy & Proxy Services Accreditation Issues (on-hold pending EPDP)** | 270d | 2020-09-28 | 2021-10-08 |  | 1380d |  |
| 95 |  | Engage IRT: Privacy & Proxy Services Accreditation Issues | 270d | 2020-09-28 | 2021-10-08 | 5 | 1380d |  |
| 96 | 1.1.8 | **IRT: Translation/Transliteration of gTLD Registration Data (on-hold pending EPDP + RDAP)** | 270d | 2020-09-28 | 2021-10-08 |  | 1380d |  |
| 97 |  | Engage IRT: Translation/Transliteration of gTLD Registration Data | 270d | 2020-09-28 | 2021-10-08 | 5 | 1380d |  |
| 98 | 1.2 | **RPM - Program Track** | 1102d | 2020-07-01 | 2024-09-19 |  | 610d |  |
| 99 | 1.2.1 | **PDP: Review of All Rights Protection Mechanisms in All gTLDs - Phase 1 (URS, TMCH, Sunrise, Claims)** | 447d | 2020-07-01 | 2022-03-17 |  | 610d |  |
| 100 |  | Engage Phase 1 working group (started 4 Mar 2016) | 77d | 2020-07-01 | 2020-10-15 |  | 610d |  |
| 101 | 1.2.1.2 | **EPDP-P1 Rec27 Wave 1 Other Policy Impacts** | 77d | 2020-07-01 | 2020-10-15 |  | 610d |  |
| 102 | 1.2.1.2.1 | **Track 2 - URS - Items 3 through 7** | 77d | 2020-07-01 | 2020-10-15 |  | 610d |  |
| 103 |  | Determine if or easily can be addressed, else report back to Council | 77d | 2020-07-01 | 2020-10-15 |  | 610d |  |
| 104 | 1.2.1.2.2 | **Track 2 - URS Rules - Items 2, 4 through 8** | 77d | 2020-07-01 | 2020-10-15 |  | 610d |  |
| 105 |  | Determine if or easily can be addressed, else report back to Council | 77d | 2020-07-01 | 2020-10-15 |  | 610d |  |
| 106 |  | Council to deliberate and adopt working group consensus recommendations | 40d | 2020-10-16 | 2020-12-10 | 100, 103, 105 | 610d |  |
| 107 |  | Board to deliberate and adopt consensus recommendations | 60d | 2020-12-11 | 2021-03-04 | 106 | 1265d |  |
| 108 |  | Engage IRT | 270d | 2021-03-05 | 2022-03-17 | 107 | 1265d |  |
| 109 | 1.2.2 | **EPDP-P1 Rec27 Wave 1 Other Policy Impacts** | 267d | 2020-07-01 | 2021-07-08 |  | 1445d |  |
| 110 | 1.2.2.1 | **Track 1 - URS - Item 1 & 2 & 8** | 90d | 2021-03-05 | 2021-07-08 |  | 1445d |  |
| 111 |  | Produce redlines of consensus policy provisions | 45d | 2021-03-05 | 2021-05-06 | 107 | 1445d | start no earlier than 2020-11-02 |
| 112 |  | Review and confirm redlines for final changes | 10d | 2021-05-07 | 2021-05-20 | 111 | 1445d |  |
| 113 |  | Conduct public comment of changes | 30d | 2021-05-21 | 2021-07-01 | 112 | 1445d |  |
| 114 |  | Post updated consensus policy | 5d | 2021-07-02 | 2021-07-08 | 113 | 1445d |  |
| 115 | 1.2.2.2 | **Track 1 - URS Rules - Items 1 & 3** | 90d | 2021-03-05 | 2021-07-08 |  | 1445d |  |
| 116 |  | Produce redlines of consensus policy provisions | 45d | 2021-03-05 | 2021-05-06 | 107 | 1445d | start no earlier than 2020-11-02 |
| 117 |  | Review and confirm redlines for final changes | 10d | 2021-05-07 | 2021-05-20 | 116 | 1445d |  |
| 118 |  | Conduct public comment of changes | 30d | 2021-05-21 | 2021-07-01 | 117 | 1445d |  |
| 119 |  | Post updated consensus policy | 5d | 2021-07-02 | 2021-07-08 | 118 | 1445d |  |
| 120 | 1.2.2.3 | **Track 1 - UDRP - Item 1** | 90d | 2020-07-01 | 2020-11-03 |  | 1622d |  |
| 121 |  | Produce redlines of consensus policy provisions | 45d | 2020-07-01 | 2020-09-01 |  | 1622d | start no earlier than 2020-07-01 |
| 122 |  | Review and confirm redlines for final changes | 10d | 2020-09-02 | 2020-09-15 | 121 | 1622d |  |
| 123 |  | Conduct public comment of changes | 30d | 2020-09-16 | 2020-10-27 | 122 | 1622d |  |
| 124 |  | Post updated consensus policy | 5d | 2020-10-28 | 2020-11-03 | 123 | 1622d |  |
| 125 | 1.2.3 | **PDP: Review of All Rights Protection Mechanisms in All gTLDs - Phase 2 (UDRP)** | 985d | 2020-12-11 | 2024-09-19 |  | 610d |  |
| 126 |  | Drafting Team to draft new charter | 90d | 2020-12-11 | 2021-04-15 | 106 | 610d |  |
| 127 |  | Engage Phase 2 working group | 525d | 2021-04-16 | 2023-04-20 | 126 | 610d |  |
| 128 | 1.2.3.3 | **EPDP-P1 Rec27 Wave 1 Other Policy Impacts** | 525d | 2021-04-16 | 2023-04-20 |  | 981d |  |
| 129 |  | Track 2 - UDRP - Items 2 through 11 | 525d | 2021-04-16 | 2023-04-20 | 126 | 981d |  |
| 130 |  | Council to deliberate and adopt working group consensus recommendations | 40d | 2023-04-21 | 2023-06-15 | 127 | 610d |  |
| 131 |  | Board to deliberate and adopt consensus recommendations | 60d | 2023-06-16 | 2023-09-07 | 130 | 610d |  |
| 132 |  | Engage IRT | 270d | 2023-09-08 | 2024-09-19 | 131 | 610d |  |
| 133 | 1.3 | **gTLD - Program Track** | 814d | 2020-07-01 | 2023-08-14 |  | 0d |  |
| 134 | 1.3.1 | **CCWG: New gTLD Auction Proceeds Drafting Team (completed 31 May 2020)** | 360d | 2020-07-01 | 2021-11-16 |  | 0d |  |
| 135 |  | Council to deliberate and adopt CCWG recommendations | 20d | 2020-07-01 | 2020-07-28 |  |  |  |
| 136 |  | Board to deliberate and adopt consensus recommendations | 90d | 2020-07-29 | 2020-12-01 | 135 | 1353d |  |
| 137 |  | Implement program | 250d | 2020-12-02 | 2021-11-16 | 136 | 1353d |  |
| 138 | 1.3.2 | **PDP: New gTLD Subsequent Procedures PDP** | 814d | 2020-07-01 | 2023-08-14 |  | 899d |  |
| 139 |  | Execute New gTLD Subsequent Procedures PDP (started 21 Jan 2016) | 124d | 2020-07-01 | 2020-12-21 |  | 899d |  |
| 140 |  | Council to deliberate and adopt working group recommendations | 60d | 2020-12-22 | 2021-03-15 | 139 | 899d |  |

| ID | WBS | Task | Duration | Start | Finish | Predecessors | Complete | Total float |
| --- | --- | --- | --- | --- | --- | --- | --- | --- |
| 141 |  | Board to deliberate and adopt consensus recommendations | 90d | 2021-03-16 | 2021-07-19 | 140 |  | 899d |
| 142 |  | Execute IRT | 540d | 2021-07-20 | 2023-08-14 | 141 |  | 899d |
| 143 | 1.3.3 | **Internationalized Domain Names** | 716d | 2020-07-01 | 2023-03-29 |  |  | 23d |
| 144 | 1.3.3.1 | **IDN Operational Track 1 Working Group** | 120d | 2020-08-03 | 2021-01-15 |  |  | 0d |
| 145 |  | Determine scope of Track 1 working group | 30d | 2020-08-03 | 2020-09-11 |  |  |  |
| 146 |  | Engage Operational Track 1 expert group | 90d | 2020-09-14 | 2021-01-15 | 145 |  | 1570d |
| 147 | 1.3.3.2 | **IDN Policy Track 2 EPDP Working Group** | 660d | 2020-09-17 | 2023-03-29 |  |  | 0d |
| 148 |  | Drafting Team to draft charter | 60d | 2020-09-17 | 2020-12-09 |  |  |  |
| 149 |  | Engage Track 2 EPDP working group | 250d | 2020-12-10 | 2021-11-24 | 145, 148 |  | 997d |
| 150 |  | Council to deliberate and adopt working group consensus recommendations | 40d | 2021-11-25 | 2022-01-19 | 149 |  | 997d |
| 151 |  | Board to deliberate and adopt consensus recommendations | 60d | 2022-01-20 | 2022-04-13 | 150 |  | 997d |
| 152 |  | Engage IRT | 250d | 2022-04-14 | 2023-03-29 | 151 |  | 997d |
| 153 | 1.3.3.3 | **IDN Track 3 Council Coordination** | 375d | 2020-07-01 | 2021-12-07 |  |  | 1338d |
| 154 |  | GNSO Council to coordinate with the CCNSO regarding IDN policy developments | 375d | 2020-07-01 | 2021-12-07 |  |  | 1338d |
| 155 | 1.4 | **Expiration - Program Track** | 193d | 2021-03-01 | 2021-11-24 |  |  | 0d |
| 156 | 1.4.1 | **Expired Domain Deletion Policy (EDDP) / Expired Registration Recovery Policy (ERRP) Review** | 105d | 2021-07-01 | 2021-11-24 |  |  | 0d |
| 157 |  | Develop Policy Status Report | 60d | 2021-07-01 | 2021-09-22 |  |  |  |
| 158 |  | Council to deliberate findings | 45d | 2021-09-23 | 2021-11-24 | 157 |  | 1346d |
| 159 | 1.4.2 | **EPDP-P1 Rec27 Wave 1 Other Policy Impacts (Expiration Policies) [MEDIUM, LOW]** | 149d | 2021-03-01 | 2021-09-23 |  |  | 0d |
| 160 | 1.4.2.1 | **Expired Domain Deletion Policy (EDDP) [MEDIUM]** | 149d | 2021-03-01 | 2021-09-23 |  |  | 0d |
| 161 | 1.4.2.1.1 | **Track 1 - Item 1** | 90d | 2021-03-01 | 2021-07-02 |  |  | 0d |
| 162 |  | Produce redlines of consensus policy provisions | 45d | 2021-03-01 | 2021-04-30 |  |  |  |
| 163 |  | Review and confirm redlines for final changes | 10d | 2021-05-03 | 2021-05-14 | 162 |  | 1450d |
| 164 |  | Conduct public comment of changes | 30d | 2021-05-17 | 2021-06-25 | 163 |  | 1450d |
| 165 |  | Post updated consensus policy | 5d | 2021-06-28 | 2021-07-02 | 164 |  | 1450d |
| 166 | 1.4.2.1.2 | **Track 2 - Item 2** | 1d | 2021-09-23 | 2021-09-23 |  |  | 0d |
| 167 |  | Staff to include as part of Expiration Policy Status Report | 1d | 2021-09-23 | 2021-09-23 | 157 |  |  |
| 168 | 1.4.2.2 | **Expired Registration Recovery Policy (ERRP) [LOW]** | 149d | 2021-03-01 | 2021-09-23 |  |  | 0d |
| 169 | 1.4.2.2.1 | **Track 1 - Item 1 & 2** | 90d | 2021-03-01 | 2021-07-02 |  |  | 0d |
| 170 |  | Produce redlines of consensus policy provisions | 45d | 2021-03-01 | 2021-04-30 |  |  |  |
| 171 |  | Review and confirm redlines for final changes | 10d | 2021-05-03 | 2021-05-14 | 170 |  | 1450d |
| 172 |  | Conduct public comment of changes | 30d | 2021-05-17 | 2021-06-25 | 171 |  | 1450d |
| 173 |  | Post updated consensus policy | 5d | 2021-06-28 | 2021-07-02 | 172 |  | 1450d |
| 174 | 1.4.2.2.2 | **Track 2 - Item 3** | 1d | 2021-09-23 | 2021-09-23 |  |  | 1391d |
| 175 |  | Staff to include as part of Expiration Policy Status Report | 1d | 2021-09-23 | 2021-09-23 | 157 |  | 1391d |
| 176 | 1.5 | **Transfers - Program Track** | 995d | 2020-07-01 | 2024-04-23 |  |  | 66d |
| 177 | 1.5.1 | **Transfer Policy Review** | 995d | 2020-07-01 | 2024-04-23 |  |  | 718d |
| 178 |  | Issues Report | 35d | 2020-07-01 | 2020-08-18 |  |  | 718d |
| 179 |  | Council to approve PDP launch | 20d | 2020-09-02 | 2020-09-29 | 178, 193 |  | 718d |
| 180 |  | Council to approve scope and charter | 20d | 2020-09-30 | 2020-10-27 | 179 |  | 718d |
| 181 |  | Engage Transfer Policy Review PDP | 540d | 2020-10-28 | 2022-11-22 | 180 |  | 718d |
| 182 |  | Council to deliberate and adopt working group consensus recommendations | 40d | 2022-11-23 | 2023-01-17 | 181 |  | 718d |
| 183 |  | Board to deliberate and adopt consensus recommendations | 60d | 2023-01-18 | 2023-04-11 | 182 |  | 718d |
| 184 |  | Engage IRT | 270d | 2023-04-12 | 2024-04-23 | 183 |  | 718d |
| 185 | 1.5.2 | **EPDP-P1 Rec27 Wave 1 Other Policy Impacts (Transfer & TDRP Policies) [HIGH]** | 121d | 2020-08-19 | 2021-02-03 |  |  | 31d |
| 186 | 1.5.2.1 | **Transfer Policy [HIGH]** | 121d | 2020-08-19 | 2021-02-03 |  |  | 31d |
| 187 | 1.5.2.1.1 | **Track 1 - Items 1, 2, 3, & 6** | 90d | 2020-10-01 | 2021-02-03 |  |  | 0d |
| 188 |  | Produce redlines of consensus policy provisions | 45d | 2020-10-01 | 2020-12-02 |  |  |  |
| 189 |  | Review and confirm redlines for final changes | 10d | 2020-12-03 | 2020-12-16 | 188 |  | 1556d |
| 190 |  | Conduct public comment of changes | 30d | 2020-12-17 | 2021-01-27 | 189 |  | 1556d |
| 191 |  | Post updated consensus policy | 5d | 2021-01-28 | 2021-02-03 | 190 |  | 1556d |
| 192 | 1.5.2.1.2 | **Track 2 - Items 4 & 5** | 10d | 2020-08-19 | 2020-09-01 |  |  | 718d |
| 193 |  | Staff to include as part of Transfer Review Issue Report and subseqent scoping of effort | 10d | 2020-08-19 | 2020-09-01 | 178 |  | 718d |
| 194 | 1.5.2.2 | **Transfer Dispute Resolution Policy (TDRP) [HIGH]** | 121d | 2020-08-19 | 2021-02-03 |  |  | 31d |
| 195 | 1.5.2.2.1 | **Track 1 - Item 1** | 90d | 2020-10-01 | 2021-02-03 |  |  | 0d |
| 196 |  | Produce redlines of consensus policy provisions | 45d | 2020-10-01 | 2020-12-02 |  |  |  |
| 197 |  | Review and confirm redlines for final changes | 10d | 2020-12-03 | 2020-12-16 | 196 |  | 1556d |
| 198 |  | Conduct public comment of changes | 30d | 2020-12-17 | 2021-01-27 | 197 |  | 1556d |
| 199 |  | Post updated consensus policy | 5d | 2021-01-28 | 2021-02-03 | 198 |  | 1556d |
| 200 | 1.5.2.2.2 | **Track 2 - Items 2, 3, & 4** | 10d | 2020-08-19 | 2020-09-01 |  |  | 1667d |
| 201 |  | Staff to include as part of Transfer Review Issue Report and subseqent scoping of effort | 10d | 2020-08-19 | 2020-09-01 | 178 |  | 1667d |
| 202 | 1.6 | **IGO - Program Track** | 748d | 2020-07-01 A | 2023-05-12 |  |  | 965d |
| 203 | 1.6.1 | **PDP: RPM - IGO Curative Rights Work Track** | 748d | 2020-07-01 A | 2023-05-12 |  |  | 965d |
| 204 |  | Council to approve PDP launch | 0d | 2020-07-01 A | 2020-07-01 A |  | 100% |  |
| 205 |  | Council to approve scope and charter | 0d | 2020-07-01 A | 2020-07-01 A | 204 | 100% |  |
| 206 |  | Engage IGO-CRPM Work Track Policy Review PDP | 270d | 2020-11-30 | 2021-12-10 | 205 |  |  |
| 207 |  | Council to deliberate and adopt working group consensus recommendations | 40d | 2021-12-13 | 2022-02-04 | 206 |  | 965d |
| 208 |  | Board to deliberate and adopt consensus recommendations | 60d | 2022-02-07 | 2022-04-29 | 207 |  | 965d |
| 209 |  | Engage IRT | 270d | 2022-05-02 | 2023-05-12 | 208 |  | 965d |
| 210 | 1.6.2 | **PDP: Curative Rights Protections for IGO/INGOs** | 330d | 2022-02-07 | 2023-05-12 |  |  | 965d |

| ID | WBS | Task | Duration | Start | Finish | Predecessors | Complete | Total float | Constraint |
| --- | --- | --- | --- | --- | --- | --- | --- | --- | --- |
| 211 |  | Board to deliberate and adopt consensus recommendations | 60d | 2022-02-07 | 2022-04-29 | 207 |  | 965d |  |
| 212 |  | Engage IRT | 270d | 2022-05-02 | 2023-05-12 | 211 |  | 965d |  |
| 213 | 1.6.3 | **PDP: Protection of International Organization Names in All gTLDs** | 270d | 2022-05-02 | 2023-05-12 |  |  | 965d |  |
| 214 |  | Engage IRT | 270d | 2022-05-02 | 2023-05-12 | 211 |  | 965d |  |
| 215 | 1.7 | **Accountability - Program Track** | 380d | 2020-07-01 | 2021-12-14 |  |  | 0d |  |
| 216 | 1.7.1 | **Independent Review Process - Implementation Oversight Team** | 250d | 2020-07-01 | 2021-06-15 |  |  | 1463d |  |
| 217 |  | Engage IoT Oversight Team | 250d | 2020-07-01 | 2021-06-15 |  |  | 1463d |  |
| 218 | 1.7.2 | **Cross Community Working Group on Enhancing ICANN Accountability - WS2** | 245d | 2020-07-01 | 2021-06-08 |  |  | 0d |  |
| 219 |  | Council small team to revew WS2 | 45d | 2020-07-01 | 2020-09-01 |  |  |  |  |
| 220 |  | Council to determine what is required of the GNSO | 200d | 2020-09-02 | 2021-06-08 | 219 |  | 1468d |  |
| 221 | 1.7.3 | **Multistakeholder Model Evolution** | 380d | 2020-07-01 | 2021-12-14 |  |  | 1333d |  |
| 222 |  | Council to determine what is required of the GNSO | 380d | 2020-07-01 | 2021-12-14 |  |  | 1333d |  |
| 223 | 1.7.4 | **Geo Regions Review** | 380d | 2020-07-01 | 2021-12-14 |  |  | 1333d |  |
| 224 |  | Council to determine what is required of the GNSO | 380d | 2020-07-01 | 2021-12-14 |  |  | 1333d |  |
| 225 | 1.8 | **Reviews - Program Track** | 1713d | 2020-07-01 A | 2027-01-22 |  |  | 0d |  |
| 226 | 1.8.1 | **IANA Naming Function Review** | 150d | 2020-07-01 A | 2021-01-26 |  |  | 1563d |  |
| 227 |  | Council SSC to select GNSO representatives on Review Team | 0d | 2020-07-01 A | 2020-07-01 A |  | 100% |  |  |
| 228 |  | GNSO participation on IFRT2 | 150d | 2020-07-01 | 2021-01-26 | 227 |  | 1563d |  |
| 229 | 1.8.2 | **GNSO Review RT3** | 670d | 2021-06-01 | 2023-12-25 |  |  | 0d |  |
| 230 |  | Council SSC to select GNSO representatives on Review Team | 30d | 2021-06-01 | 2021-07-12 |  |  |  |  |
| 231 |  | GNSO participation on GNSO3-RT | 270d | 2021-07-13 | 2022-07-25 | 230 |  | 804d |  |
| 232 |  | Council to deliberate and adopt review team consensus recommendations | 40d | 2022-07-26 | 2022-09-19 | 231 |  | 804d |  |
| 233 |  | Board to deliberate and adopt consensus recommendations | 60d | 2022-09-20 | 2022-12-12 | 232 |  | 804d |  |
| 234 |  | Implement GNSO3 Review recommendations | 270d | 2022-12-13 | 2023-12-25 | 233 |  | 804d |  |
| 235 | 1.8.3 | **Customer Standing Committee Effectiveness Review** | 180d | 2022-03-01 | 2022-11-07 |  |  | 0d |  |
| 236 |  | Council SSC to select GNSO representatives on Review Team | 30d | 2022-03-01 | 2022-04-11 |  |  |  |  |
| 237 |  | GNSO participation on CSC2-ER | 150d | 2022-04-12 | 2022-11-07 | 236 |  | 1099d |  |
| 238 | 1.8.4 | **Registration Directory Service Review RT3** | 300d | 2024-09-02 | 2025-10-24 |  |  | 0d |  |
| 239 |  | Council SSC to select GNSO representatives on Review Team | 30d | 2024-09-02 | 2024-10-11 |  |  |  |  |
| 240 |  | GNSO participation on RDS3-RT | 270d | 2024-10-14 | 2025-10-24 | 239 |  | 325d |  |
| 241 | 1.8.5 | **Competition, Consumer Trust and Consumer Choice RT2** | 300d | 2023-01-03 | 2024-02-26 |  |  | 0d |  |
| 242 |  | Council SSC to select GNSO representatives on Review Team | 30d | 2023-01-03 | 2023-02-13 |  |  |  |  |
| 243 |  | GNSO participation on CCT-RT2 | 270d | 2023-02-14 | 2024-02-26 | 242 |  | 759d |  |
| 244 | 1.8.6 | **Accountability and Transparency Review 3** | 260d | 2020-07-01 | 2021-06-29 |  |  | 1453d |  |
| 245 |  | Council to form a small team to draft a public comment response to the ATRT3 | 22d | 2020-07-01 | 2020-07-30 |  |  | 1691d |  |
| 246 |  | Council to monitor for ATRT3 implementation assignments should the Board adopt ATRT3 recommendations | 260d | 2020-07-01 | 2021-06-29 |  |  | 1453d | start no earlier than 2020-07-01 |
| 247 | 1.8.7 | **Accountability and Transparency Review 4** | 300d | 2025-06-02 | 2026-07-24 |  |  | 0d |  |
| 248 |  | Council SSC to select GNSO representatives on Review Team | 30d | 2025-06-02 | 2025-07-11 |  |  |  |  |
| 249 |  | GNSO participation on ATRT4 | 270d | 2025-07-14 | 2026-07-24 | 248 |  | 130d |  |
| 250 | 1.8.8 | **Security, Stability and Resiliency of the DNS #2** | 170d | 2020-07-01 | 2021-02-23 |  |  | 1543d |  |
| 251 |  | GNSO participation on SSR#2 | 125d | 2020-07-01 | 2020-12-22 |  |  | 1543d |  |
| 252 |  | Council to consider SSR#2 Results | 45d | 2020-12-23 | 2021-02-23 | 251 |  | 1543d |  |
| 253 | 1.8.9 | **Security, Stability and Resiliency of the DNS #3** | 300d | 2025-12-01 | 2027-01-22 |  |  | 0d |  |
| 254 |  | Council SSC to select GNSO representatives on Review Team | 30d | 2025-12-01 | 2026-01-09 |  |  |  |  |
| 255 |  | GNSO participation on SSR3 | 270d | 2026-01-12 | 2027-01-22 | 254 |  | 0d |  |
| 256 | 1.9 | **Operations - Program Track** | 543d | 2020-07-01 | 2022-07-29 |  |  | 0d |  |
| 257 | 1.9.1 | **Policy & Implementation - Recommendations Review** | 475d | 2020-10-05 | 2022-07-29 |  |  | 0d |  |
| 258 |  | Council to decide to extend review beyond 5 years from Final Report | 20d | 2020-10-05 | 2020-10-30 |  |  |  |  |
| 259 |  | Survey community (EPDP) on P&I features | 60d | 2022-01-03 | 2022-03-25 | 258 |  |  |  |
| 260 |  | Review IRT principles and CPIF | 90d | 2022-01-03 | 2022-05-06 | 258 |  |  |  |
| 261 |  | Determine if additional review is required | 60d | 2022-05-09 | 2022-07-29 | 259, 260 |  | 1170d |  |
| 262 | 1.9.2 | **Participant of Empowered Community** | 386d | 2020-07-01 | 2021-12-22 |  |  | 0d |  |
| 263 |  | Perform role | 81d | 2020-07-01 | 2020-10-21 |  |  |  |  |
| 264 |  | Elect new participant | 15d | 2020-10-22 | 2020-11-11 | 263 |  | 1327d |  |
| 265 |  | New participant perform role | 290d | 2020-11-12 | 2021-12-22 | 264 |  | 1327d |  |
| 266 | 1.9.3 | **GNSO Council** | 386d | 2020-07-01 | 2021-12-22 |  |  | 0d |  |
| 267 | 1.9.3.1 | **GNSO Council - Monthly Meetings** | 366d | 2020-07-23 | 2021-12-16 |  |  | 0d |  |
| 268 |  | GNSO Council Meeting 1 | 1d | 2020-07-23 | 2020-07-23 |  |  |  | start no earlier than 2020-07-23 |
| 269 |  | GNSO Council Meeting 2 | 1d | 2020-08-20 | 2020-08-20 |  |  |  | start no earlier than 2020-08-20 |
| 270 |  | GNSO Council Meeting 3 | 1d | 2020-09-24 | 2020-09-24 |  |  |  | start no earlier than 2020-09-24 |
| 271 |  | GNSO Council Meeting 4 | 1d | 2020-10-21 | 2020-10-21 |  |  |  | start no earlier than 2020-10-21 |
| 272 |  | GNSO Council Meeting 5 | 1d | 2020-11-19 | 2020-11-19 |  |  |  | start no earlier than 2020-11-19 |
| 273 |  | GNSO Council Meeting 6 | 1d | 2020-12-17 | 2020-12-17 |  |  |  | start no earlier than 2020-12-17 |
| 274 |  | GNSO Council Meeting 7 | 1d | 2021-01-21 | 2021-01-21 |  |  |  | start no earlier than 2021-01-21 |
| 275 |  | GNSO Council Meeting 8 | 1d | 2021-02-18 | 2021-02-18 |  |  |  | start no earlier than 2021-02-18 |
| 276 |  | GNSO Council Meeting 9 | 1d | 2021-03-18 | 2021-03-18 |  |  |  | start no earlier than 2021-03-18 |
| 277 |  | GNSO Council Meeting 10 | 1d | 2021-04-15 | 2021-04-15 |  |  |  | start no earlier than 2021-04-15 |
| 278 |  | GNSO Council Meeting 11 | 1d | 2021-05-20 | 2021-05-20 |  |  |  | start no earlier than 2021-05-20 |
| 279 |  | GNSO Council Meeting 12 | 1d | 2021-06-17 | 2021-06-17 |  |  |  | start no earlier than 2021-06-17 |
| 280 |  | GNSO Council Meeting 13 | 1d | 2021-07-15 | 2021-07-15 |  |  |  | start no earlier than 2021-07-15 |

| ID | WBS | Task | Duration | Start | Finish | Predecessors | Total float | Constraint |
| --- | --- | --- | --- | --- | --- | --- | --- | --- |
| 281 |  | GNSO Council Meeting 14 | 1d | 2021-08-19 | 2021-08-19 |  |  | start no earlier than 2021-08-19 |
| 282 |  | GNSO Council Meeting 15 | 1d | 2021-09-16 | 2021-09-16 |  |  | start no earlier than 2021-09-16 |
| 283 |  | GNSO Council Meeting 16 | 1d | 2021-10-21 | 2021-10-21 |  |  | start no earlier than 2021-10-21 |
| 284 |  | GNSO Council Meeting 17 | 1d | 2021-11-18 | 2021-11-18 |  |  | start no earlier than 2021-11-18 |
| 285 |  | GNSO Council Meeting 18 | 1d | 2021-12-16 | 2021-12-16 |  |  | start no earlier than 2021-12-16 |
| 286 | 1.9.3.2 | **GNSO Council - Leadership Meetings** | 372d | 2020-07-13 | 2021-12-14 |  | 0d |  |
| 287 |  | GNSO Council - Leadership Meetings 1 | 2d | 2020-07-13 | 2020-07-14 |  |  | start no earlier than 2020-07-13 |
| 288 |  | GNSO Council - Leadership Meetings 2 | 2d | 2020-08-10 | 2020-08-11 |  |  | start no earlier than 2020-08-10 |
| 289 |  | GNSO Council - Leadership Meetings 3 | 2d | 2020-09-14 | 2020-09-15 |  |  | start no earlier than 2020-09-14 |
| 290 |  | GNSO Council - Leadership Meetings 4 | 2d | 2020-10-12 | 2020-10-13 |  |  | start no earlier than 2020-10-12 |
| 291 |  | GNSO Council - Leadership Meetings 5 | 2d | 2020-11-09 | 2020-11-10 |  |  | start no earlier than 2020-11-09 |
| 292 |  | GNSO Council - Leadership Meetings 6 | 2d | 2020-12-14 | 2020-12-15 |  |  | start no earlier than 2020-12-14 |
| 293 |  | GNSO Council - Leadership Meetings 7 | 2d | 2021-01-11 | 2021-01-12 |  |  | start no earlier than 2021-01-11 |
| 294 |  | GNSO Council - Leadership Meetings 8 | 2d | 2021-02-08 | 2021-02-09 |  |  | start no earlier than 2021-02-08 |
| 295 |  | GNSO Council - Leadership Meetings 9 | 2d | 2021-03-08 | 2021-03-09 |  |  | start no earlier than 2021-03-08 |
| 296 |  | GNSO Council - Leadership Meetings 10 | 2d | 2021-04-12 | 2021-04-13 |  |  | start no earlier than 2021-04-12 |
| 297 |  | GNSO Council - Leadership Meetings 11 | 2d | 2021-05-10 | 2021-05-11 |  |  | start no earlier than 2021-05-10 |
| 298 |  | GNSO Council - Leadership Meetings 12 | 2d | 2021-06-14 | 2021-06-15 |  |  | start no earlier than 2021-06-14 |
| 299 |  | GNSO Council - Leadership Meetings 13 | 2d | 2021-07-12 | 2021-07-13 |  |  | start no earlier than 2021-07-12 |
| 300 |  | GNSO Council - Leadership Meetings 14 | 2d | 2021-08-09 | 2021-08-10 |  |  | start no earlier than 2021-08-09 |
| 301 |  | GNSO Council - Leadership Meetings 15 | 2d | 2021-09-13 | 2021-09-14 |  |  | start no earlier than 2021-09-13 |
| 302 |  | GNSO Council - Leadership Meetings 16 | 2d | 2021-10-11 | 2021-10-12 |  |  | start no earlier than 2021-10-11 |
| 303 |  | GNSO Council - Leadership Meetings 17 | 2d | 2021-11-08 | 2021-11-09 |  |  | start no earlier than 2021-11-08 |
| 304 |  | GNSO Council - Leadership Meetings 18 | 2d | 2021-12-13 | 2021-12-14 |  |  | start no earlier than 2021-12-13 |
| 305 | 1.9.3.3 | **GNSO Council - Action Items** | 371d | 2020-07-13 | 2021-12-13 |  | 0d |  |
| 306 |  | GNSO Council - Action Items 1 | 1d | 2020-07-13 | 2020-07-13 |  |  | start no earlier than 2020-07-13 |
| 307 |  | GNSO Council - Action Items 2 | 1d | 2020-08-10 | 2020-08-10 |  |  | start no earlier than 2020-08-10 |
| 308 |  | GNSO Council - Action Items 3 | 1d | 2020-09-14 | 2020-09-14 |  |  | start no earlier than 2020-09-14 |
| 309 |  | GNSO Council - Action Items 4 | 1d | 2020-10-12 | 2020-10-12 |  |  | start no earlier than 2020-10-12 |
| 310 |  | GNSO Council - Action Items 5 | 1d | 2020-11-09 | 2020-11-09 |  |  | start no earlier than 2020-11-09 |
| 311 |  | GNSO Council - Action Items 6 | 1d | 2020-12-14 | 2020-12-14 |  |  | start no earlier than 2020-12-14 |
| 312 |  | GNSO Council - Action Items 7 | 1d | 2021-01-11 | 2021-01-11 |  |  | start no earlier than 2021-01-11 |
| 313 |  | GNSO Council - Action Items 8 | 1d | 2021-02-08 | 2021-02-08 |  |  | start no earlier than 2021-02-08 |
| 314 |  | GNSO Council - Action Items 9 | 1d | 2021-03-08 | 2021-03-08 |  |  | start no earlier than 2021-03-08 |
| 315 |  | GNSO Council - Action Items 10 | 1d | 2021-04-12 | 2021-04-12 |  |  | start no earlier than 2021-04-12 |
| 316 |  | GNSO Council - Action Items 11 | 1d | 2021-05-10 | 2021-05-10 |  |  | start no earlier than 2021-05-10 |
| 317 |  | GNSO Council - Action Items 12 | 1d | 2021-06-14 | 2021-06-14 |  |  | start no earlier than 2021-06-14 |
| 318 |  | GNSO Council - Action Items 13 | 1d | 2021-07-12 | 2021-07-12 |  |  | start no earlier than 2021-07-12 |
| 319 |  | GNSO Council - Action Items 14 | 1d | 2021-08-09 | 2021-08-09 |  |  | start no earlier than 2021-08-09 |
| 320 |  | GNSO Council - Action Items 15 | 1d | 2021-09-13 | 2021-09-13 |  |  | start no earlier than 2021-09-13 |
| 321 |  | GNSO Council - Action Items 16 | 1d | 2021-10-11 | 2021-10-11 |  |  | start no earlier than 2021-10-11 |
| 322 |  | GNSO Council - Action Items 17 | 1d | 2021-11-08 | 2021-11-08 |  |  | start no earlier than 2021-11-08 |
| 323 |  | GNSO Council - Action Items 18 | 1d | 2021-12-13 | 2021-12-13 |  |  | start no earlier than 2021-12-13 |
| 324 | 1.9.3.4 | **GNSO Standing Committee on Budget and Operations** | 105d | 2020-11-02 | 2021-03-26 |  | 0d |  |
| 325 |  | Refresh roster and confirm Chair | 15d | 2020-11-02 | 2020-11-20 |  |  |  |
| 326 |  | Evaluate fiscal year budget and planning documents | 75d | 2020-11-23 | 2021-03-05 | 325 | 1520d |  |
| 327 |  | Complete draft of comments for Council consideration and submit | 15d | 2021-03-08 | 2021-03-26 | 326 | 1520d |  |
| 328 | 1.9.3.5 | **GNSO Standing Selection Committee** | 386d | 2020-07-01 | 2021-12-22 |  | 0d |  |
| 329 |  | SSC fill positions as assigned | 386d | 2020-07-01 | 2021-12-22 |  |  |  |
| 330 | 1.9.3.6 | **Strategic Planning Session** | 99d | 2020-10-01 | 2021-02-16 |  | 0d |  |
| 331 |  | Establish and manage travel arrangements | 75d | 2020-10-01 | 2021-01-13 |  |  |  |
| 332 |  | Develop plan, topics, and materials for deliberation | 65d | 2020-10-21 | 2021-01-19 |  |  |  |
| 333 |  | Conduct planning session | 5d | 2021-01-20 | 2021-01-26 | 332 | 1548d |  |
| 334 |  | Develop post planning session report | 15d | 2021-01-27 | 2021-02-16 | 333 | 1548d |  |

## Version 2 (saved 2020-08-08, file GNSO_Council_Program_Management_Tool_20200820.mpp)

Last finish stays 2027-01-22. Complete tasks 9 → 17.

Added:

| ID | Task | Duration | Start | Finish | Predecessors | Resources |
| --- | --- | --- | --- | --- | --- | --- |
| 50 | Produce redlines of consensus policy provisions | 45d | 2020-08-03 | 2020-10-02 |  | GDD Staff |
| 51 | Review and confirm redlines for final changes | 10d | 2020-10-05 | 2020-10-16 | 50 | GDD Staff; IRT; Policy Staff |
| 52 | Conduct public comment of changes | 30d | 2020-10-19 | 2020-11-27 | 51 | GDD Staff; IRT |
| 53 | Post updated consensus policy | 5d | 2020-11-30 | 2020-12-04 | 52 | GDD Staff |
| 72 | Produce redlines of consensus policy provisions | 45d | 2020-08-03 | 2020-10-02 |  | GDD Staff |
| 73 | Review and confirm redlines for final changes | 10d | 2020-10-05 | 2020-10-16 | 72 | GDD Staff; IRT; Policy Staff |
| 74 | Conduct public comment of changes | 30d | 2020-10-19 | 2020-11-27 | 73 | GDD Staff; IRT |
| 75 | Post updated consensus policy | 5d | 2020-11-30 | 2020-12-04 | 74 | GDD Staff |
| 274 | Elect new participant | 15d | 2021-10-28 | 2021-11-17 | 273 | Council; Policy Staff; EC Admin |
| 275 | Perform role 2022 | 250d | 2021-11-18 | 2022-11-02 | 274 | EC Admin; EC Rep |
| 276 | Elect new participant | 15d | 2022-11-03 | 2022-11-23 | 275 | Council; Policy Staff; EC Admin |
| 277 | Perform role 2023 | 250d | 2022-11-24 | 2023-11-08 | 276 | EC Admin; EC Rep |
| 278 | Elect new participant | 15d | 2023-11-09 | 2023-11-29 | 277 | Council; Policy Staff; EC Admin |
| 279 | Perform role 2024 | 250d | 2023-11-30 | 2024-11-13 | 278 | EC Admin; EC Rep |
| 280 | Elect new participant | 15d | 2024-11-14 | 2024-12-04 | 279 | Council; Policy Staff; EC Admin |
| 281 | Perform role 2025 | 250d | 2024-12-05 | 2025-11-19 | 280 | EC Admin; EC Rep |

Changed:

| ID | Task | Start | Finish | Duration | Complete | Total float | Predecessors | Other |
| --- | --- | --- | --- | --- | --- | --- | --- | --- |
| 1 | **GNSO Program Management Planning** |  |  |  | 0% → 2% |  |  |  |
| 2 | **RDS - Program Track** |  |  |  | 1% → 2% |  |  |  |
| 3 | **EPDP: Temporary Specification on gTLD Registration Data - Phase 2** | 2020-07-01 A |  |  | 0% → 4% | 1065d → 1080d |  |  |
| 4 | Engage EPDP: Temporary Specification on gTLD Registration Data - Phase 2 | 2020-07-01 A | 2020-07-31 A |  | 0% → 100% | 1065d → none |  |  |
| 8 | **Remaining EPDP-P2 Topics (Legal vs. Natural, Unique Contacts, + Accuracy )** | 2020-08-03 → 2020-09-28 (+56d) |  | 625d → 585d |  |  |  |  |
| 9 | **Remaining EPDP-P2 Topics Track 1 (Legal vs. Natural + Feasability of Unique Contacts)** | 2020-08-03 → 2020-09-28 (+56d) | 2021-11-18 → 2022-01-13 (+56d) |  |  | 1351d → 1311d |  |  |
| 10 | Reset EPDP-P2 and elect new Chair | 2020-08-03 → 2020-09-28 (+56d) | 2020-09-02 → 2020-10-28 (+56d) |  |  | 1351d → 1311d | 4 → 5 |  |
| 11 | Engage EPDP-P2 to address remaining topics | 2020-09-03 → 2020-10-29 (+56d) | 2020-11-05 → 2020-12-31 (+56d) |  |  | 1351d → 1311d |  |  |
| 12 | Council to deliberate and adopt working group consensus recommendations | 2020-11-06 → 2021-01-01 (+56d) | 2020-12-31 → 2021-02-25 (+56d) |  |  | 1351d → 1311d |  |  |
| 13 | Board to deliberate and adopt consensus recommendations | 2021-01-01 → 2021-02-26 (+56d) | 2021-03-11 → 2021-05-06 (+56d) |  |  | 1351d → 1311d |  |  |
| 14 | Engage IRT | 2021-03-12 → 2021-05-07 (+56d) | 2021-11-18 → 2022-01-13 (+56d) |  |  | 1351d → 1311d |  |  |
| 48 | **Registry Registration Data Directory Services Consistent Labeling and Display Policy (CL&D) [HIGH]** |  | 2020-10-23 → 2020-12-04 (+42d) | 60d → 90d |  |  |  |  |
| 70 | **Thick Whois Transition Policy for .COM, .NET, .JOBS [HIGH]** |  | 2020-10-23 → 2020-12-04 (+42d) | 60d → 90d |  |  |  |  |
| 100 | **EPDP-P1 Rec27 Wave 1.5 & Wave 2 Other Policy Impacts (pending delivery)** | 2020-08-03 → 2020-08-21 (+18d) | 2020-12-04 → 2020-12-24 (+20d) |  |  |  |  |  |
| 101 | Council to consider Wave 1.5 and Wave 2 reports and determine next steps | 2020-08-03 → 2020-08-21 (+18d) | 2020-12-04 → 2020-12-24 (+20d) |  |  |  |  |  |
| 106 | **RPM - Program Track** | 2020-07-01 A |  |  | 0% → 2% | 610d → 611d |  |  |
| 107 | **PDP: Review of All Rights Protection Mechanisms in All gTLDs - Phase 1 (URS, TMCH, Sunrise, Claims)** | 2020-07-01 A |  |  | 0% → 6% | 610d → 1265d |  |  |
| 109 | **EPDP-P1 Rec27 Wave 1 Other Policy Impacts** | 2020-07-01 A |  |  | 0% → 25% |  |  |  |
| 110 | **Track 2 - URS - Items 3 through 7** | 2020-07-01 A |  |  | 0% → 25% |  |  |  |
| 111 | Determine if or easily can be addressed, else report back to Council | 2020-07-01 A |  |  | 0% → 25% |  |  |  |
| 112 | **Track 2 - URS Rules - Items 2, 4 through 8** | 2020-07-01 A |  |  | 0% → 25% |  |  |  |
| 113 | Determine if or easily can be addressed, else report back to Council | 2020-07-01 A |  |  | 0% → 25% |  |  |  |
| 117 | **EPDP-P1 Rec27 Wave 1 Other Policy Impacts** | 2020-07-01 → 2020-08-03 (+33d) |  | 267d → 244d |  |  |  |  |
| 128 | **Track 1 - UDRP - Item 1** | 2020-07-01 → 2020-08-03 (+33d) | 2020-11-03 → 2020-12-04 (+31d) |  |  | 1622d → 1599d |  |  |
| 129 | Produce redlines of consensus policy provisions | 2020-07-01 → 2020-08-03 (+33d) | 2020-09-01 → 2020-10-02 (+31d) |  |  | 1622d → 1599d |  | constraint start no earlier than 2020-07-01 → start no earlier than 2020-08-03 |
| 130 | Review and confirm redlines for final changes | 2020-09-02 → 2020-10-05 (+33d) | 2020-09-15 → 2020-10-16 (+31d) |  |  | 1622d → 1599d |  |  |
| 131 | Conduct public comment of changes | 2020-09-16 → 2020-10-19 (+33d) | 2020-10-27 → 2020-11-27 (+31d) |  |  | 1622d → 1599d |  |  |
| 132 | Post updated consensus policy | 2020-10-28 → 2020-11-30 (+33d) | 2020-11-03 → 2020-12-04 (+31d) |  |  | 1622d → 1599d |  |  |
| 163 | **Expiration - Program Track** | 2021-03-01 → 2020-08-03 (-210d) |  | 193d → 343d |  |  |  |  |
| 167 | **EPDP-P1 Rec27 Wave 1 Other Policy Impacts (Expiration Policies) [MEDIUM, LOW]** | 2021-03-01 → 2020-08-03 (-210d) |  | 149d → 299d |  |  |  |  |
| 168 | **Expired Domain Deletion Policy (EDDP) [MEDIUM]** | 2021-03-01 → 2020-08-03 (-210d) |  | 149d → 299d |  |  |  |  |
| 169 | **Track 1 - Item 1** | 2021-03-01 → 2020-08-03 (-210d) | 2021-07-02 → 2020-12-04 (-210d) |  |  |  |  |  |
| 170 | Produce redlines of consensus policy provisions | 2021-03-01 → 2020-08-03 (-210d) | 2021-04-30 → 2020-10-02 (-210d) |  |  |  |  |  |
| 171 | Review and confirm redlines for final changes | 2021-05-03 → 2020-10-05 (-210d) | 2021-05-14 → 2020-10-16 (-210d) |  |  | 1450d → 1600d |  |  |
| 172 | Conduct public comment of changes | 2021-05-17 → 2020-10-19 (-210d) | 2021-06-25 → 2020-11-27 (-210d) |  |  | 1450d → 1600d |  |  |
| 173 | Post updated consensus policy | 2021-06-28 → 2020-11-30 (-210d) | 2021-07-02 → 2020-12-04 (-210d) |  |  | 1450d → 1600d |  |  |
| 176 | **Expired Registration Recovery Policy (ERRP) [LOW]** | 2021-03-01 → 2020-08-03 (-210d) |  | 149d → 299d |  |  |  |  |
| 177 | **Track 1 - Item 1 & 2** | 2021-03-01 → 2020-08-03 (-210d) | 2021-07-02 → 2020-12-04 (-210d) |  |  |  |  |  |
| 178 | Produce redlines of consensus policy provisions | 2021-03-01 → 2020-08-03 (-210d) | 2021-04-30 → 2020-10-02 (-210d) |  |  |  |  |  |
| 179 | Review and confirm redlines for final changes | 2021-05-03 → 2020-10-05 (-210d) | 2021-05-14 → 2020-10-16 (-210d) |  |  | 1450d → 1600d |  |  |
| 180 | Conduct public comment of changes | 2021-05-17 → 2020-10-19 (-210d) | 2021-06-25 → 2020-11-27 (-210d) |  |  | 1450d → 1600d |  |  |
| 181 | Post updated consensus policy | 2021-06-28 → 2020-11-30 (-210d) | 2021-07-02 → 2020-12-04 (-210d) |  |  | 1450d → 1600d |  |  |
| 184 | **Transfers - Program Track** | 2020-07-01 A | 2024-04-23 → 2024-08-06 (+105d) | 995d → 1070d | 0% → 3% | 66d → 643d |  |  |
| 185 | **Transfer Policy Review** | 2020-07-01 A | 2024-04-23 → 2024-08-06 (+105d) | 995d → 1070d | 0% → 3% | 718d → 643d |  |  |
| 186 | Issues Report | 2020-07-01 A | 2020-08-18 → 2020-11-24 (+98d) | 35d → 105d | 0% → 30% | 718d → 643d |  |  |
| 187 | Council to approve PDP launch | 2020-09-02 → 2020-12-09 (+98d) | 2020-09-29 → 2020-12-22 (+84d) | 20d → 10d |  | 718d → 643d |  |  |
| 188 | Council to approve scope and charter | 2020-09-30 → 2020-12-23 (+84d) | 2020-10-27 → 2021-02-09 (+105d) | 20d → 35d |  | 718d → 643d |  |  |
| 189 | Engage Transfer Policy Review PDP | 2020-10-28 → 2021-02-10 (+105d) | 2022-11-22 → 2023-03-07 (+105d) |  |  | 718d → 643d |  |  |
| 190 | Council to deliberate and adopt working group consensus recommendations | 2022-11-23 → 2023-03-08 (+105d) | 2023-01-17 → 2023-05-02 (+105d) |  |  | 718d → 643d |  |  |
| 191 | Board to deliberate and adopt consensus recommendations | 2023-01-18 → 2023-05-03 (+105d) | 2023-04-11 → 2023-07-25 (+105d) |  |  | 718d → 643d |  |  |
| 192 | Engage IRT | 2023-04-12 → 2023-07-26 (+105d) | 2024-04-23 → 2024-08-06 (+105d) |  |  | 718d → 643d |  |  |
| 193 | **EPDP-P1 Rec27 Wave 1 Other Policy Impacts (Transfer & TDRP Policies) [HIGH]** | 2020-08-19 → 2020-08-03 (-16d) | 2021-02-03 → 2020-12-08 (-57d) | 121d → 92d |  | 31d → 0d |  |  |
| 194 | **Transfer Policy [HIGH]** | 2020-08-19 → 2020-08-03 (-16d) | 2021-02-03 → 2020-12-08 (-57d) | 121d → 92d |  | 31d → 0d |  |  |
| 195 | **Track 1 - Items 1, 2, 3, & 6** | 2020-10-01 → 2020-08-03 (-59d) | 2021-02-03 → 2020-12-04 (-61d) |  |  |  |  |  |
| 196 | Produce redlines of consensus policy provisions | 2020-10-01 → 2020-08-03 (-59d) | 2020-12-02 → 2020-10-02 (-61d) |  |  |  |  |  |
| 197 | Review and confirm redlines for final changes | 2020-12-03 → 2020-10-05 (-59d) | 2020-12-16 → 2020-10-16 (-61d) |  |  | 1556d → 1599d |  |  |
| 198 | Conduct public comment of changes | 2020-12-17 → 2020-10-19 (-59d) | 2021-01-27 → 2020-11-27 (-61d) |  |  | 1556d → 1599d |  |  |
| 199 | Post updated consensus policy | 2021-01-28 → 2020-11-30 (-59d) | 2021-02-03 → 2020-12-04 (-61d) |  |  | 1556d → 1599d |  |  |
| 200 | **Track 2 - Items 4 & 5** | 2020-08-19 → 2020-11-25 (+98d) | 2020-09-01 → 2020-12-08 (+98d) |  |  | 718d → 643d |  |  |
| 201 | Staff to include as part of Transfer Review Issue Report and subseqent scoping of effort | 2020-08-19 → 2020-11-25 (+98d) | 2020-09-01 → 2020-12-08 (+98d) |  |  | 718d → 643d |  |  |
| 202 | **Transfer Dispute Resolution Policy (TDRP) [HIGH]** | 2020-08-19 → 2020-08-03 (-16d) | 2021-02-03 → 2020-12-08 (-57d) | 121d → 92d |  | 31d → 0d |  |  |
| 203 | **Track 1 - Item 1** | 2020-10-01 → 2020-08-03 (-59d) | 2021-02-03 → 2020-12-04 (-61d) |  |  |  |  |  |
| 204 | Produce redlines of consensus policy provisions | 2020-10-01 → 2020-08-03 (-59d) | 2020-12-02 → 2020-10-02 (-61d) |  |  |  |  |  |
| 205 | Review and confirm redlines for final changes | 2020-12-03 → 2020-10-05 (-59d) | 2020-12-16 → 2020-10-16 (-61d) |  |  | 1556d → 1599d |  |  |
| 206 | Conduct public comment of changes | 2020-12-17 → 2020-10-19 (-59d) | 2021-01-27 → 2020-11-27 (-61d) |  |  | 1556d → 1599d |  |  |
| 207 | Post updated consensus policy | 2021-01-28 → 2020-11-30 (-59d) | 2021-02-03 → 2020-12-04 (-61d) |  |  | 1556d → 1599d |  |  |
| 208 | **Track 2 - Items 2, 3, & 4** | 2020-08-19 → 2020-11-25 (+98d) | 2020-09-01 → 2020-12-08 (+98d) |  |  | 1667d → 1597d |  |  |
| 209 | Staff to include as part of Transfer Review Issue Report and subseqent scoping of effort | 2020-08-19 → 2020-11-25 (+98d) | 2020-09-01 → 2020-12-08 (+98d) |  |  | 1667d → 1597d |  |  |
| 223 | **Accountability - Program Track** | 2020-07-01 A |  |  | 0% → 4% | 0d → 1333d |  |  |
| 224 | **Independent Review Process - Implementation Oversight Team** | 2020-07-01 A |  |  | 0% → 5% |  |  |  |

| ID | Task | Start | Finish | Duration | Complete | Total float | Other |
| --- | --- | --- | --- | --- | --- | --- | --- |
| 225 | Engage IoT Oversight Team | 2020-07-01 A |  |  | 0% → 5% |  |  |
| 226 | **Cross Community Working Group on Enhancing ICANN Accountability - WS2** | 2020-07-01 A |  |  | 0% → 1% | 0d → 1468d |  |
| 227 | Council small team to revew WS2 | 2020-07-01 A |  |  | 0% → 5% |  |  |
| 229 | **Multistakeholder Model Evolution** | 2020-07-01 A |  |  | 0% → 5% |  |  |
| 230 | Council to determine what is required of the GNSO | 2020-07-01 A |  |  | 0% → 5% |  |  |
| 231 | **Geo Regions Review** | 2020-07-01 A |  |  | 0% → 5% |  |  |
| 232 | Council to determine what is required of the GNSO | 2020-07-01 A |  |  | 0% → 5% |  |  |
| 233 | **Reviews - Program Track** |  |  |  | 0% → 3% |  |  |
| 234 | **IANA Naming Function Review** |  |  |  | 0% → 5% |  |  |
| 236 | GNSO participation on IFRT2 | 2020-07-01 A |  |  | 0% → 5% |  |  |
| 252 | **Accountability and Transparency Review 3** | 2020-07-01 A |  |  | 0% → 8% |  |  |
| 253 | Council to form a small team to draft a public comment response to the ATRT3 | 2020-07-01 A | 2020-07-30 A |  | 0% → 100% | 1691d → none |  |
| 258 | **Security, Stability and Resiliency of the DNS #2** | 2020-07-01 A |  |  | 0% → 22% |  |  |
| 259 | GNSO participation on SSR#2 | 2020-07-01 A |  |  | 0% → 30% |  |  |
| 264 | **Operations - Program Track** | 2020-07-01 A | 2022-07-29 → 2025-11-19 (+1209d) | 543d → 1406d | 0% → 2% | 0d → 307d |  |
| 270 | **Participant of Empowered Community** | 2020-07-01 A | 2021-12-22 → 2025-11-19 (+1428d) | 386d → 1406d | 0% → 2% | 0d → 307d |  |
| 271 | Perform role 2020 | 2020-07-01 A |  |  | 0% → 33% |  | was named Perform role |
| 273 | Perform role 2021 |  | 2021-12-22 → 2021-10-27 (-56d) | 290d → 250d |  | 1327d → 307d | was named New participant perform role |
| 282 | **GNSO Council** | 2020-07-01 A |  |  | 0% → 4% | 0d → 1327d |  |
| 283 | **GNSO Council - Monthly Meetings** | 2020-07-23 A |  |  | 0% → 11% |  |  |
| 284 | GNSO Council Meeting 1 | 2020-07-23 A | 2020-07-23 A |  | 0% → 100% |  |  |
| 285 | GNSO Council Meeting 2 | 2020-08-20 A | 2020-08-20 A |  | 0% → 100% |  |  |
| 302 | **GNSO Council - Leadership Meetings** | 2020-07-13 A |  |  | 0% → 11% |  |  |
| 303 | GNSO Council - Leadership Meetings 1 | 2020-07-13 A | 2020-07-14 A |  | 0% → 100% |  |  |
| 304 | GNSO Council - Leadership Meetings 2 | 2020-08-10 A | 2020-08-11 A |  | 0% → 100% |  |  |
| 321 | **GNSO Council - Action Items** | 2020-07-13 A |  |  | 0% → 11% |  |  |
| 322 | GNSO Council - Action Items 1 | 2020-07-13 A | 2020-07-13 A |  | 0% → 100% |  |  |
| 323 | GNSO Council - Action Items 2 | 2020-08-10 A | 2020-08-10 A |  | 0% → 100% |  |  |
| 344 | **GNSO Standing Selection Committee** | 2020-07-01 A |  |  | 0% → 5% |  |  |
| 345 | SSC fill positions as assigned | 2020-07-01 A |  |  | 0% → 5% |  |  |

## Version 3 (saved 2020-09-11, file GNSO_Council_Program_Management_Tool_20200924.mpp)

Last finish stays 2027-01-22. Complete tasks 17 → 25.

Changed:

| ID | Task | Start | Finish | Duration | Complete | Total float | Other |
| --- | --- | --- | --- | --- | --- | --- | --- |
| 1 | **GNSO Program Management Planning** |  |  |  | 2% → 8% |  |  |
| 2 | **RDS - Program Track** |  | 2024-09-20 → 2024-11-20 (+61d) | 1103d → 1146d | 2% → 9% | 610d → 567d |  |
| 3 | **EPDP: Temporary Specification on gTLD Registration Data - Phase 2** |  |  |  | 4% → 6% |  |  |
| 5 | Council to deliberate and adopt working group consensus recommendations | 2020-08-03 A |  |  | 0% → 40% |  |  |
| 32 | **IRT: Temporary Specification on gTLD Registration Data - Phase 1** | 2020-07-01 A |  |  | 0% → 30% |  |  |
| 33 | Engage IRT: Temporary Specification on gTLD Registration Data - Phase 1 | 2020-07-01 A |  |  | 0% → 30% |  |  |
| 34 | **EPDP-P1 Rec27 Wave 1 Other Policy Impacts** |  | 2024-09-20 → 2024-11-20 (+61d) | 1103d → 1146d | 0% → 10% | 610d → 567d |  |
| 37 | **Additional Whois Information Policy (AWIP) [LOW]** | 2020-08-03 → 2020-09-04 A (+32d) | 2020-12-04 → 2021-01-07 (+34d) |  | 0% → 25% | 0d → 1576d |  |
| 38 | Produce redlines of consensus policy provisions (assumes step 2 accomplished here) | 2020-08-03 → 2020-09-04 A (+32d) | 2020-10-02 → 2020-11-05 (+34d) |  | 0% → 50% |  |  |
| 39 | Review and confirm redlines for final changes | 2020-10-05 → 2020-11-06 (+32d) | 2020-10-16 → 2020-11-19 (+34d) |  |  | 1600d → 1576d |  |
| 40 | Conduct public comment of changes | 2020-10-19 → 2020-11-20 (+32d) | 2020-11-27 → 2020-12-31 (+34d) |  |  | 1600d → 1576d |  |
| 41 | Post updated consensus policy | 2020-11-30 → 2021-01-01 (+32d) | 2020-12-04 → 2021-01-07 (+34d) |  |  | 1600d → 1576d |  |
| 49 | Council to determine next steps based on EPDP-P1-IRT + Rec27 findings | 2020-08-03 → 2020-09-04 (+32d) | 2020-10-23 → 2020-11-26 (+34d) |  |  |  |  |
| 56 | **Restored Names Accuracy Policy (RNAP) [LOW]** | 2020-08-03 → 2020-09-04 A (+32d) |  | 146d → 122d | 0% → 25% | 0d → 1544d |  |
| 57 | **Track 1 - Item 1** | 2020-08-03 → 2020-09-04 A (+32d) | 2020-12-04 → 2021-01-07 (+34d) |  | 0% → 25% | 0d → 1576d |  |
| 58 | Produce redlines of consensus policy provisions | 2020-08-03 → 2020-09-04 A (+32d) | 2020-10-02 → 2020-11-05 (+34d) |  | 0% → 50% |  |  |
| 59 | Review and confirm redlines for final changes | 2020-10-05 → 2020-11-06 (+32d) | 2020-10-16 → 2020-11-19 (+34d) |  |  | 1600d → 1576d |  |
| 60 | Conduct public comment of changes | 2020-10-19 → 2020-11-20 (+32d) | 2020-11-27 → 2020-12-31 (+34d) |  |  | 1600d → 1576d |  |
| 61 | Post updated consensus policy | 2020-11-30 → 2021-01-01 (+32d) | 2020-12-04 → 2021-01-07 (+34d) |  |  | 1600d → 1576d |  |
| 64 | **Revised ICANN Procedure for Handling Whois Conflicts with Privacy Law [LOW]** | 2020-08-03 → 2020-09-04 (+32d) | 2020-12-04 → 2021-02-24 (+82d) | 90d → 124d |  |  |  |
| 65 | **Track 1 - Items 1 to 3** | 2020-08-03 → 2020-09-04 (+32d) | 2020-10-02 → 2020-11-05 (+34d) |  |  |  |  |
| 66 | Request Whois IAG to consider terminology updates and if policy changes are required | 2020-08-03 → 2020-09-04 (+32d) | 2020-10-02 → 2020-11-05 (+34d) |  |  |  |  |
| 67 | **Track 2** | 2020-08-03 → 2020-10-01 (+59d) | 2020-10-02 → 2020-12-23 (+82d) | 45d → 60d |  |  |  |
| 68 | Staff to review procedure based on experience and develop report | 2020-08-03 → 2020-10-01 (+59d) | 2020-10-02 → 2020-12-23 (+82d) | 45d → 60d |  |  |  |
| 69 | Council to deliberate findings and determine appropriate path | 2020-10-05 → 2020-12-24 (+80d) | 2020-12-04 → 2021-02-24 (+82d) |  |  | 1600d → 1542d |  |
| 70 | **Thick Whois Transition Policy for .COM, .NET, .JOBS [HIGH]** | 2020-08-03 → 2020-09-04 (+32d) | 2020-12-04 → 2021-01-07 (+34d) |  |  |  |  |
| 71 | Council to determine next steps based on EPDP-P1-IRT + Rec27 findings | 2020-08-03 → 2020-09-04 (+32d) | 2020-10-23 → 2020-11-26 (+34d) |  |  |  | constraint start no earlier than 2020-08-03 → start no earlier than 2020-09-04 |
| 72 | Produce redlines of consensus policy provisions | 2020-08-03 → 2020-09-04 (+32d) | 2020-10-02 → 2020-11-05 (+34d) |  |  |  |  |
| 73 | Review and confirm redlines for final changes | 2020-10-05 → 2020-11-06 (+32d) | 2020-10-16 → 2020-11-19 (+34d) |  |  | 1600d → 1576d |  |
| 74 | Conduct public comment of changes | 2020-10-19 → 2020-11-20 (+32d) | 2020-11-27 → 2020-12-31 (+34d) |  |  | 1600d → 1576d |  |
| 75 | Post updated consensus policy | 2020-11-30 → 2021-01-01 (+32d) | 2020-12-04 → 2021-01-07 (+34d) |  |  | 1600d → 1576d |  |
| 80 | **Rules for Uniform Domain Name Dispute Resolution Policy (UDRP Rules) [HIGH]** | 2024-09-20 → 2024-11-20 (+61d) | 2024-09-20 → 2024-11-20 (+61d) |  |  |  |  |
| 81 | Migrated to RPM Program | 2024-09-20 → 2024-11-20 (+61d) | 2024-09-20 → 2024-11-20 (+61d) |  |  |  |  |
| 82 | **Uniform Rapid Suspension System Procedure (URS) [HIGH]** | 2022-03-18 → 2022-05-18 (+61d) | 2022-03-18 → 2022-05-18 (+61d) |  |  |  |  |
| 83 | Migrated to RPM Program | 2022-03-18 → 2022-05-18 (+61d) | 2022-03-18 → 2022-05-18 (+61d) |  |  |  |  |
| 84 | **Uniform Rapid Suspension System Rules (URS Rules) [HIGH]** | 2022-03-18 → 2022-05-18 (+61d) | 2022-03-18 → 2022-05-18 (+61d) |  |  |  |  |
| 85 | Migrated to RPM Program | 2022-03-18 → 2022-05-18 (+61d) | 2022-03-18 → 2022-05-18 (+61d) |  |  |  |  |
| 86 | **Whois Data Reminder Policy (WDRP) [MEDIUM]** | 2020-08-03 A |  |  | 0% → 12% | 0d → 1347d |  |
| 87 | **Track 1 - Item 1** | 2020-08-03 → 2020-09-04 A (+32d) | 2020-12-04 → 2021-01-07 (+34d) |  | 0% → 25% | 0d → 1576d |  |
| 88 | Produce redlines of consensus policy provisions | 2020-08-03 → 2020-09-04 A (+32d) | 2020-10-02 → 2020-11-05 (+34d) |  | 0% → 50% |  |  |
| 89 | Review and confirm redlines for final changes | 2020-10-05 → 2020-11-06 (+32d) | 2020-10-16 → 2020-11-19 (+34d) |  |  | 1600d → 1576d |  |
| 90 | Conduct public comment of changes | 2020-10-19 → 2020-11-20 (+32d) | 2020-11-27 → 2020-12-31 (+34d) |  |  | 1600d → 1576d |  |
| 91 | Post updated consensus policy | 2020-11-30 → 2021-01-01 (+32d) | 2020-12-04 → 2021-01-07 (+34d) |  |  | 1600d → 1576d |  |
| 95 | **Whois Marketing Restriction Policy [LOW]** | 2020-08-03 → 2020-09-04 A (+32d) | 2020-12-04 → 2021-01-07 (+34d) |  | 0% → 25% | 0d → 1576d |  |
| 96 | Produce redlines of consensus policy provisions | 2020-08-03 → 2020-09-04 A (+32d) | 2020-10-02 → 2020-11-05 (+34d) |  | 0% → 50% |  |  |
| 97 | Review and confirm redlines for final changes | 2020-10-05 → 2020-11-06 (+32d) | 2020-10-16 → 2020-11-19 (+34d) |  |  | 1600d → 1576d |  |
| 98 | Conduct public comment of changes | 2020-10-19 → 2020-11-20 (+32d) | 2020-11-27 → 2020-12-31 (+34d) |  |  | 1600d → 1576d |  |
| 99 | Post updated consensus policy | 2020-11-30 → 2021-01-01 (+32d) | 2020-12-04 → 2021-01-07 (+34d) |  |  | 1600d → 1576d |  |
| 100 | **EPDP-P1 Rec27 Wave 1.5 & Wave 2 Other Policy Impacts (pending delivery)** | 2020-08-21 → 2020-09-30 (+40d) | 2020-12-24 → 2021-02-02 (+40d) |  |  |  |  |
| 101 | Council to consider Wave 1.5 and Wave 2 reports and determine next steps | 2020-08-21 → 2020-09-30 (+40d) | 2020-12-24 → 2021-02-02 (+40d) |  |  |  |  |
| 106 | **RPM - Program Track** |  | 2024-09-19 → 2024-11-19 (+61d) | 1102d → 1145d | 2% → 8% | 611d → 568d |  |
| 107 | **PDP: Review of All Rights Protection Mechanisms in All gTLDs - Phase 1 (URS, TMCH, Sunrise, Claims)** |  | 2022-03-17 → 2022-05-17 (+61d) | 447d → 490d | 6% → 31% | 1265d → 1222d |  |
| 108 | Engage Phase 1 working group (started 4 Mar 2016) | 2020-07-01 A | 2020-10-15 → 2020-12-15 (+61d) | 77d → 120d | 0% → 40% | 610d → 567d |  |
| 109 | **EPDP-P1 Rec27 Wave 1 Other Policy Impacts** |  | 2020-10-15 A |  | 25% → 100% | 610d → none |  |
| 110 | **Track 2 - URS - Items 3 through 7** |  | 2020-10-15 A |  | 25% → 100% | 610d → none |  |
| 111 | Determine if or easily can be addressed, else report back to Council |  | 2020-10-15 A |  | 25% → 100% | 610d → none |  |
| 112 | **Track 2 - URS Rules - Items 2, 4 through 8** |  | 2020-10-15 A |  | 25% → 100% | 610d → none |  |
| 113 | Determine if or easily can be addressed, else report back to Council |  | 2020-10-15 A |  | 25% → 100% | 610d → none |  |
| 114 | Council to deliberate and adopt working group consensus recommendations | 2020-10-16 → 2020-12-16 (+61d) | 2020-12-10 → 2021-02-09 (+61d) |  |  | 610d → 567d |  |
| 115 | Board to deliberate and adopt consensus recommendations | 2020-12-11 → 2021-02-10 (+61d) | 2021-03-04 → 2021-05-04 (+61d) |  |  | 1265d → 1222d |  |
| 116 | Engage IRT | 2021-03-05 → 2021-05-05 (+61d) | 2022-03-17 → 2022-05-17 (+61d) |  |  | 1265d → 1222d |  |
| 117 | **EPDP-P1 Rec27 Wave 1 Other Policy Impacts** |  | 2021-07-08 → 2021-09-07 (+61d) | 244d → 287d |  | 1445d → 1402d |  |
| 118 | **Track 1 - URS - Item 1 & 2 & 8** | 2021-03-05 → 2021-05-05 (+61d) | 2021-07-08 → 2021-09-07 (+61d) |  |  | 1445d → 1402d |  |
| 119 | Produce redlines of consensus policy provisions | 2021-03-05 → 2021-05-05 (+61d) | 2021-05-06 → 2021-07-06 (+61d) |  |  | 1445d → 1402d |  |
| 120 | Review and confirm redlines for final changes | 2021-05-07 → 2021-07-07 (+61d) | 2021-05-20 → 2021-07-20 (+61d) |  |  | 1445d → 1402d |  |
| 121 | Conduct public comment of changes | 2021-05-21 → 2021-07-21 (+61d) | 2021-07-01 → 2021-08-31 (+61d) |  |  | 1445d → 1402d |  |
| 122 | Post updated consensus policy | 2021-07-02 → 2021-09-01 (+61d) | 2021-07-08 → 2021-09-07 (+61d) |  |  | 1445d → 1402d |  |
| 123 | **Track 1 - URS Rules - Items 1 & 3** | 2021-03-05 → 2021-05-05 (+61d) | 2021-07-08 → 2021-09-07 (+61d) |  |  | 1445d → 1402d |  |
| 124 | Produce redlines of consensus policy provisions | 2021-03-05 → 2021-05-05 (+61d) | 2021-05-06 → 2021-07-06 (+61d) |  |  | 1445d → 1402d |  |
| 125 | Review and confirm redlines for final changes | 2021-05-07 → 2021-07-07 (+61d) | 2021-05-20 → 2021-07-20 (+61d) |  |  | 1445d → 1402d |  |

| ID | Task | Start | Finish | Duration | Complete | Total float | Other |
| --- | --- | --- | --- | --- | --- | --- | --- |
| 126 | Conduct public comment of changes | 2021-05-21 → 2021-07-21 (+61d) | 2021-07-01 → 2021-08-31 (+61d) |  |  | 1445d → 1402d |  |
| 127 | Post updated consensus policy | 2021-07-02 → 2021-09-01 (+61d) | 2021-07-08 → 2021-09-07 (+61d) |  |  | 1445d → 1402d |  |
| 133 | **PDP: Review of All Rights Protection Mechanisms in All gTLDs - Phase 2 (UDRP)** | 2020-12-11 → 2021-02-10 (+61d) | 2024-09-19 → 2024-11-19 (+61d) |  |  | 610d → 567d |  |
| 134 | Drafting Team to draft new charter | 2020-12-11 → 2021-02-10 (+61d) | 2021-04-15 → 2021-06-15 (+61d) |  |  | 610d → 567d |  |
| 135 | Engage Phase 2 working group | 2021-04-16 → 2021-06-16 (+61d) | 2023-04-20 → 2023-06-20 (+61d) |  |  | 610d → 567d |  |
| 136 | **EPDP-P1 Rec27 Wave 1 Other Policy Impacts** | 2021-04-16 → 2021-06-16 (+61d) | 2023-04-20 → 2023-06-20 (+61d) |  |  | 981d → 938d |  |
| 137 | Track 2 - UDRP - Items 2 through 11 | 2021-04-16 → 2021-06-16 (+61d) | 2023-04-20 → 2023-06-20 (+61d) |  |  | 981d → 938d |  |
| 138 | Council to deliberate and adopt working group consensus recommendations | 2023-04-21 → 2023-06-21 (+61d) | 2023-06-15 → 2023-08-15 (+61d) |  |  | 610d → 567d |  |
| 139 | Board to deliberate and adopt consensus recommendations | 2023-06-16 → 2023-08-16 (+61d) | 2023-09-07 → 2023-11-07 (+61d) |  |  | 610d → 567d |  |
| 140 | Engage IRT | 2023-09-08 → 2023-11-08 (+61d) | 2024-09-19 → 2024-11-19 (+61d) |  |  | 610d → 567d |  |
| 141 | **gTLD - Program Track** | 2020-07-01 A |  |  | 0% → 8% | 0d → 899d |  |
| 142 | **CCWG: New gTLD Auction Proceeds Drafting Team (group completed 31 May 2020)** | 2020-07-01 → 2020-08-03 A (+33d) | 2021-11-16 → 2021-12-17 (+31d) |  | 0% → 6% | 0d → 1330d | was named CCWG: New gTLD Auction Proceeds Drafting Team (completed 31 May 2020) |
| 143 | Council to deliberate and adopt CCWG recommendations | 2020-07-01 → 2020-08-03 A (+33d) | 2020-07-28 → 2020-08-28 A (+31d) |  | 0% → 100% |  |  |
| 144 | Board to deliberate and adopt consensus recommendations | 2020-07-29 → 2020-08-31 (+33d) | 2020-12-01 → 2021-01-01 (+31d) |  |  | 1353d → 1330d |  |
| 145 | Implement program | 2020-12-02 → 2021-01-04 (+33d) | 2021-11-16 → 2021-12-17 (+31d) |  |  | 1353d → 1330d |  |
| 146 | **PDP: New gTLD Subsequent Procedures PDP** | 2020-07-01 A |  |  | 0% → 11% |  |  |
| 147 | Execute New gTLD Subsequent Procedures PDP (started 21 Jan 2016) | 2020-07-01 A |  |  | 0% → 70% |  |  |
| 151 | **Internationalized Domain Names** | 2020-07-01 A | 2023-03-29 → 2023-04-14 (+16d) | 716d → 728d | 0% → 7% | 23d → 985d |  |
| 152 | **IDN Operational Track 1 Working Group** | 2020-08-03 A |  |  | 0% → 33% | 0d → 1570d |  |
| 153 | Determine scope of Track 1 working group | 2020-08-03 A | 2020-09-11 A |  | 0% → 100% |  |  |
| 154 | Engage Operational Track 1 expert group | 2020-09-14 A |  |  | 0% → 10% |  |  |
| 155 | **IDN Policy Track 2 EPDP Working Group** | 2020-09-17 → 2020-10-05 (+18d) | 2023-03-29 → 2023-04-14 (+16d) |  |  |  |  |
| 156 | Drafting Team to draft charter | 2020-09-17 → 2020-10-05 (+18d) | 2020-12-09 → 2020-12-25 (+16d) |  |  |  |  |
| 157 | Engage Track 2 EPDP working group | 2020-12-10 → 2020-12-28 (+18d) | 2021-11-24 → 2021-12-10 (+16d) |  |  | 997d → 985d |  |
| 158 | Council to deliberate and adopt working group consensus recommendations | 2021-11-25 → 2021-12-13 (+18d) | 2022-01-19 → 2022-02-04 (+16d) |  |  | 997d → 985d |  |
| 159 | Board to deliberate and adopt consensus recommendations | 2022-01-20 → 2022-02-07 (+18d) | 2022-04-13 → 2022-04-29 (+16d) |  |  | 997d → 985d |  |
| 160 | Engage IRT | 2022-04-14 → 2022-05-02 (+18d) | 2023-03-29 → 2023-04-14 (+16d) |  |  | 997d → 985d |  |
| 161 | **IDN Track 3 Council Coordination** | 2020-07-01 A |  |  | 0% → 10% |  |  |
| 162 | GNSO Council to coordinate with the CCNSO regarding IDN policy developments | 2020-07-01 A |  |  | 0% → 10% |  |  |
| 163 | **Expiration - Program Track** | 2020-08-03 → 2020-09-04 A (+32d) |  | 343d → 319d | 0% → 16% | 0d → 1347d |  |
| 167 | **EPDP-P1 Rec27 Wave 1 Other Policy Impacts (Expiration Policies) [MEDIUM, LOW]** | 2020-08-03 → 2020-09-04 A (+32d) |  | 299d → 275d | 0% → 25% | 0d → 1391d |  |
| 168 | **Expired Domain Deletion Policy (EDDP) [MEDIUM]** | 2020-08-03 → 2020-09-04 A (+32d) |  | 299d → 275d | 0% → 25% | 0d → 1391d |  |
| 169 | **Track 1 - Item 1** | 2020-08-03 → 2020-09-04 A (+32d) | 2020-12-04 → 2021-01-07 (+34d) |  | 0% → 25% | 0d → 1576d |  |
| 170 | Produce redlines of consensus policy provisions | 2020-08-03 → 2020-09-04 A (+32d) | 2020-10-02 → 2020-11-05 (+34d) |  | 0% → 50% |  |  |
| 171 | Review and confirm redlines for final changes | 2020-10-05 → 2020-11-06 (+32d) | 2020-10-16 → 2020-11-19 (+34d) |  |  | 1600d → 1576d |  |
| 172 | Conduct public comment of changes | 2020-10-19 → 2020-11-20 (+32d) | 2020-11-27 → 2020-12-31 (+34d) |  |  | 1600d → 1576d |  |
| 173 | Post updated consensus policy | 2020-11-30 → 2021-01-01 (+32d) | 2020-12-04 → 2021-01-07 (+34d) |  |  | 1600d → 1576d |  |
| 176 | **Expired Registration Recovery Policy (ERRP) [LOW]** | 2020-08-03 → 2020-09-04 A (+32d) |  | 299d → 275d | 0% → 25% | 0d → 1391d |  |
| 177 | **Track 1 - Item 1 & 2** | 2020-08-03 → 2020-09-04 A (+32d) | 2020-12-04 → 2021-01-07 (+34d) |  | 0% → 25% | 0d → 1576d |  |
| 178 | Produce redlines of consensus policy provisions | 2020-08-03 → 2020-09-04 A (+32d) | 2020-10-02 → 2020-11-05 (+34d) |  | 0% → 50% |  |  |
| 179 | Review and confirm redlines for final changes | 2020-10-05 → 2020-11-06 (+32d) | 2020-10-16 → 2020-11-19 (+34d) |  |  | 1600d → 1576d |  |
| 180 | Conduct public comment of changes | 2020-10-19 → 2020-11-20 (+32d) | 2020-11-27 → 2020-12-31 (+34d) |  |  | 1600d → 1576d |  |
| 181 | Post updated consensus policy | 2020-11-30 → 2021-01-01 (+32d) | 2020-12-04 → 2021-01-07 (+34d) |  |  | 1600d → 1576d |  |
| 184 | **Transfers - Program Track** |  | 2024-08-06 → 2024-09-24 (+49d) | 1070d → 1105d | 3% → 10% | 643d → 608d |  |
| 185 | **Transfer Policy Review** |  | 2024-08-06 → 2024-09-24 (+49d) | 1070d → 1105d | 3% → 8% | 643d → 608d |  |
| 186 | Issues Report |  | 2020-11-24 → 2021-01-12 (+49d) | 105d → 140d | 30% → 60% | 643d → 608d |  |
| 187 | Council to approve PDP launch | 2020-12-09 → 2021-01-27 (+49d) | 2020-12-22 → 2021-02-09 (+49d) |  |  | 643d → 608d |  |
| 188 | Council to approve scope and charter | 2020-12-23 → 2021-02-10 (+49d) | 2021-02-09 → 2021-03-30 (+49d) |  |  | 643d → 608d |  |
| 189 | Engage Transfer Policy Review PDP | 2021-02-10 → 2021-03-31 (+49d) | 2023-03-07 → 2023-04-25 (+49d) |  |  | 643d → 608d |  |
| 190 | Council to deliberate and adopt working group consensus recommendations | 2023-03-08 → 2023-04-26 (+49d) | 2023-05-02 → 2023-06-20 (+49d) |  |  | 643d → 608d |  |
| 191 | Board to deliberate and adopt consensus recommendations | 2023-05-03 → 2023-06-21 (+49d) | 2023-07-25 → 2023-09-12 (+49d) |  |  | 643d → 608d |  |
| 192 | Engage IRT | 2023-07-26 → 2023-09-13 (+49d) | 2024-08-06 → 2024-09-24 (+49d) |  |  | 643d → 608d |  |
| 193 | **EPDP-P1 Rec27 Wave 1 Other Policy Impacts (Transfer & TDRP Policies) [HIGH]** | 2020-08-03 → 2020-09-04 A (+32d) | 2020-12-08 → 2021-01-26 (+49d) | 92d → 103d | 0% → 23% | 0d → 1562d |  |
| 194 | **Transfer Policy [HIGH]** | 2020-08-03 → 2020-09-04 A (+32d) | 2020-12-08 → 2021-01-26 (+49d) | 92d → 103d | 0% → 23% | 0d → 1562d |  |
| 195 | **Track 1 - Items 1, 2, 3, & 6** | 2020-08-03 → 2020-09-04 A (+32d) | 2020-12-04 → 2021-01-07 (+34d) |  | 0% → 25% | 0d → 1575d |  |
| 196 | Produce redlines of consensus policy provisions | 2020-08-03 → 2020-09-04 A (+32d) | 2020-10-02 → 2020-11-05 (+34d) |  | 0% → 50% |  |  |
| 197 | Review and confirm redlines for final changes | 2020-10-05 → 2020-11-06 (+32d) | 2020-10-16 → 2020-11-19 (+34d) |  |  | 1599d → 1575d |  |
| 198 | Conduct public comment of changes | 2020-10-19 → 2020-11-20 (+32d) | 2020-11-27 → 2020-12-31 (+34d) |  |  | 1599d → 1575d |  |
| 199 | Post updated consensus policy | 2020-11-30 → 2021-01-01 (+32d) | 2020-12-04 → 2021-01-07 (+34d) |  |  | 1599d → 1575d |  |
| 200 | **Track 2 - Items 4 & 5** | 2020-11-25 → 2021-01-13 (+49d) | 2020-12-08 → 2021-01-26 (+49d) |  |  | 643d → 608d |  |
| 201 | Staff to include as part of Transfer Review Issue Report and subseqent scoping of effort | 2020-11-25 → 2021-01-13 (+49d) | 2020-12-08 → 2021-01-26 (+49d) |  |  | 643d → 608d |  |
| 202 | **Transfer Dispute Resolution Policy (TDRP) [HIGH]** | 2020-08-03 → 2020-09-04 A (+32d) | 2020-12-08 → 2021-01-26 (+49d) | 92d → 103d | 0% → 23% | 0d → 1562d |  |
| 203 | **Track 1 - Item 1** | 2020-08-03 → 2020-09-04 A (+32d) | 2020-12-04 → 2021-01-07 (+34d) |  | 0% → 25% | 0d → 1575d |  |
| 204 | Produce redlines of consensus policy provisions | 2020-08-03 → 2020-09-04 A (+32d) | 2020-10-02 → 2020-11-05 (+34d) |  | 0% → 50% |  |  |
| 205 | Review and confirm redlines for final changes | 2020-10-05 → 2020-11-06 (+32d) | 2020-10-16 → 2020-11-19 (+34d) |  |  | 1599d → 1575d |  |
| 206 | Conduct public comment of changes | 2020-10-19 → 2020-11-20 (+32d) | 2020-11-27 → 2020-12-31 (+34d) |  |  | 1599d → 1575d |  |
| 207 | Post updated consensus policy | 2020-11-30 → 2021-01-01 (+32d) | 2020-12-04 → 2021-01-07 (+34d) |  |  | 1599d → 1575d |  |
| 208 | **Track 2 - Items 2, 3, & 4** | 2020-11-25 → 2021-01-13 (+49d) | 2020-12-08 → 2021-01-26 (+49d) |  |  | 1597d → 1562d |  |
| 209 | Staff to include as part of Transfer Review Issue Report and subseqent scoping of effort | 2020-11-25 → 2021-01-13 (+49d) | 2020-12-08 → 2021-01-26 (+49d) |  |  | 1597d → 1562d |  |
| 223 | **Accountability - Program Track** |  |  |  | 4% → 9% |  |  |

| ID | Task | Start | Finish | Duration | Complete | Total float |
| --- | --- | --- | --- | --- | --- | --- |
| 224 | **Independent Review Process - Implementation Oversight Team** |  |  |  | 5% → 20% |  |
| 225 | Engage IoT Oversight Team |  |  |  | 5% → 20% |  |
| 226 | **Cross Community Working Group on Enhancing ICANN Accountability - WS2** |  | 2021-06-08 → 2021-07-20 (+42d) | 245d → 275d | 1% → 3% | 1468d → 1438d |
| 227 | Council small team to revew WS2 |  | 2020-09-01 → 2020-10-13 (+42d) | 45d → 75d | 5% → 10% |  |
| 228 | Council to determine what is required of the GNSO | 2020-09-02 → 2020-10-14 (+42d) | 2021-06-08 → 2021-07-20 (+42d) |  |  | 1468d → 1438d |
| 229 | **Multistakeholder Model Evolution** |  |  |  | 5% → 10% |  |
| 230 | Council to determine what is required of the GNSO |  |  |  | 5% → 10% |  |
| 233 | **Reviews - Program Track** |  |  |  | 3% → 5% |  |
| 234 | **IANA Naming Function Review** |  |  |  | 5% → 20% |  |
| 236 | GNSO participation on IFRT2 |  |  |  | 5% → 20% |  |
| 252 | **Accountability and Transparency Review 3** |  |  |  | 8% → 22% |  |
| 254 | Council to monitor for ATRT3 implementation assignments should the Board adopt ATRT3 recommendations | 2020-07-01 A |  |  | 0% → 15% |  |
| 264 | **Operations - Program Track** |  |  |  | 2% → 14% |  |
| 270 | **Participant of Empowered Community** |  |  |  | 2% → 4% |  |
| 271 | Perform role 2020 |  |  |  | 33% → 70% |  |
| 282 | **GNSO Council** |  |  |  | 4% → 39% |  |
| 283 | **GNSO Council - Monthly Meetings** |  |  |  | 11% → 17% |  |
| 286 | GNSO Council Meeting 3 | 2020-09-24 A | 2020-09-24 A |  | 0% → 100% |  |
| 302 | **GNSO Council - Leadership Meetings** |  |  |  | 11% → 17% |  |
| 305 | GNSO Council - Leadership Meetings 3 | 2020-09-14 A | 2020-09-15 A |  | 0% → 100% |  |
| 321 | **GNSO Council - Action Items** |  |  |  | 11% → 17% |  |
| 324 | GNSO Council - Action Items 3 | 2020-09-14 A | 2020-09-14 A |  | 0% → 100% |  |
| 344 | **GNSO Standing Selection Committee** |  |  |  | 5% → 50% |  |
| 345 | SSC fill positions as assigned |  |  |  | 5% → 50% |  |
| 346 | **Strategic Planning Session** | 2020-10-01 A |  |  | 0% → 47% | 0d → 1548d |
| 347 | Establish and manage travel arrangements | 2020-10-01 A | 2021-01-13 A |  | 0% → 100% |  |

## Version 4 (saved 2020-10-10, file GNSO_Council_Program_Management_Tool_20201021.mpp)

Last finish stays 2027-01-22. Complete tasks 25 → 31.

Added:

| ID | Task | Duration | Start | Finish | Predecessors | Constraint | Resources |
| --- | --- | --- | --- | --- | --- | --- | --- |
| 83 | Produce redlines of consensus policy provisions (Items 1,2,3 & 6) | 45d | 2020-09-04 A | 2020-11-05 |  |  | GDS Staff |
| 93 | Produce redlines of consensus policy provisions (Item 1) | 45d | 2020-08-03 A | 2020-10-02 |  | start no earlier than 2020-08-03 | GDS Staff |
| 98 | Produce redlines of consensus policy provisions (Items 1,2 & 8) | 45d | 2021-05-05 A | 2021-07-06 | 148 | start no earlier than 2020-11-02 | GDS Staff |
| 103 | Produce redlines of consensus policy provisions (Items 1&3) | 45d | 2021-05-05 A | 2021-07-06 | 148 | start no earlier than 2020-11-02 | GDS Staff |
| 104 | Review and confirm redlines for final changes | 10d | 2021-07-07 | 2021-07-20 | 103 |  | GDS Staff; IRT; Policy Staff |
| 105 | Conduct public comment of changes | 30d | 2021-07-21 | 2021-08-31 | 104 |  | GDS Staff; IRT |
| 106 | Post updated consensus policy | 5d | 2021-09-01 | 2021-09-07 | 105 |  | GDS Staff |
| 120 | **Revised ICANN Procedure for Handling Whois Conflicts with Privacy Law** | 575d | 2020-07-31 A | 2022-10-13 |  |  |  |
| 121 | Council small scoping team to determine next steps and Council consideration | 60d | 2020-07-31 A | 2020-10-22 |  |  | Council; Policy Staff |
| 122 | Request ICANN org to develop revised proposal for invoking Procedure | 60d | 2020-10-23 | 2021-01-14 | 121 |  | GDS Staff; Policy Staff; Legal Staff |
| 124 | IF required, review WPIAG Charter to determine if it's fit for purpose | 30d | 2021-03-19 | 2021-04-29 | 123 |  | Council; Policy Staff |
| 125 | **IF required, Council to approve charter and launch WPIAG** | 105d | 2021-04-30 | 2021-09-23 |  |  |  |
| 126 | Engage WPIAG | 60d | 2021-04-30 | 2021-07-22 | 124 |  | Policy Staff; Working Group |
| 128 | **IF required, Council to approve launch of EPDP** | 275d | 2021-09-24 | 2022-10-13 |  |  |  |
| 129 | Engage EPDP: Temporary Specification on gTLD Registration Data - Phase 2 | 90d | 2021-09-24 | 2022-01-27 | 127 |  | Policy Staff; Working Group |
| 130 | Council to deliberate and adopt working group consensus recommendations | 45d | 2022-01-28 | 2022-03-31 | 129 |  | Council; Policy Staff |
| 131 | Board to deliberate and adopt consensus recommendations | 50d | 2022-04-01 | 2022-06-09 | 130 |  | Board |
| 132 | Engage IRT: Temporary Specification on gTLD Registration Data - Phase 2 | 90d | 2022-06-10 | 2022-10-13 | 131 |  | GDS Staff; Policy Staff |
| 180 | Council to extend PSR for 18 months or when bandwidth becomes available | 375d | 2020-10-21 | 2022-03-29 |  |  | Council; Policy Staff |
| 185 | **Transfer Issue Report** | 141d | 2020-07-01 A | 2021-01-13 |  |  |  |
| 187 | Staff to include as part of Transfer Review Issue Report (IRTP Items 4&5, TDRP Items 2-4) | 1d | 2021-01-13 A | 2021-01-13 A | 186 |  | Policy Staff |

Removed: 43 Migrated to Expiration Program; 45 Migrated to Expiration Program; 66 Request Whois IAG to consider terminology updates and if policy changes are required; 67 Track 2; 68 Staff to review procedure based on experience and develop report; 77 Migrated to Transfer Program; 79 Migrated to Transfer Program; 81 Migrated to RPM Program; 83 Migrated to RPM Program; 85 Migrated to RPM Program; 117 EPDP-P1 Rec27 Wave 1 Other Policy Impacts; 118 Track 1 - URS - Item 1 & 2 & 8; 123 Track 1 - URS Rules - Items 1 & 3; 128 Track 1 - UDRP - Item 1; 136 EPDP-P1 Rec27 Wave 1 Other Policy Impacts; 137 Track 2 - UDRP - Items 2 through 11; 167 EPDP-P1 Rec27 Wave 1 Other Policy Impacts (Expiration Policies) [MEDIUM, LOW]; 168 Expired Domain Deletion Policy (EDDP) [MEDIUM]; 169 Track 1 - Item 1; 174 Track 2 - Item 2; 175 Staff to include as part of Expiration Policy Status Report; 176 Expired Registration Recovery Policy (ERRP) [LOW]; 177 Track 1 - Item 1 & 2; 178 Produce redlines of consensus policy provisions; 182 Track 2 - Item 3; 183 Staff to include as part of Expiration Policy Status Report; 193 EPDP-P1 Rec27 Wave 1 Other Policy Impacts (Transfer & TDRP Policies) [HIGH]; 194 Transfer Policy [HIGH]; 195 Track 1 - Items 1, 2, 3, & 6; 196 Produce redlines of consensus policy provisions; 200 Track 2 - Items 4 & 5; 201 Staff to include as part of Transfer Review Issue Report and subseqent scoping of effort; 202 Transfer Dispute Resolution Policy (TDRP) [HIGH]; 203 Track 1 - Item 1; 204 Produce redlines of consensus policy provisions; 208 Track 2 - Items 2, 3, & 4; 209 Staff to include as part of Transfer Review Issue Report and subseqent scoping of effort

Changed:

| ID | Task | Start | Finish | Duration | Complete | Total float | Predecessors | Other |
| --- | --- | --- | --- | --- | --- | --- | --- | --- |
| 1 | **GNSO Program Management Planning** |  |  |  | 8% → 12% |  |  |  |
| 2 | **RDDS - Program Track** |  | 2024-11-20 → 2022-12-23 (-698d) | 1146d → 648d | 9% → 16% | 567d → 1065d |  | was named RDS - Program Track |
| 3 | **EPDP: Temporary Specification on gTLD Registration Data - Phase 2** |  |  |  | 6% → 10% |  |  |  |
| 5 | Council to deliberate and adopt working group consensus recommendations |  | 2020-09-25 A |  | 40% → 100% | 1065d → none |  |  |
| 7 | Engage IRT: Temporary Specification on gTLD Registration Data - Phase 2 |  |  |  |  |  |  | resources GDD Staff; IRT; Policy Staff → GDS Staff; IRT; Policy Staff |
| 9 | **Remaining EPDP-P2 Topics Track 1 (Legal vs. Natural + Feasability of Unique Contacts)** |  | 2022-01-13 → 2022-03-04 (+50d) | 339d → 375d |  | 1311d → 1275d |  |  |
| 10 | Reset EPDP-P2 and elect new Chair |  | 2020-10-28 → 2020-11-13 (+16d) | 23d → 35d |  | 1311d → 1275d |  |  |
| 11 | Engage EPDP-P2 to address remaining topics | 2020-10-29 → 2020-11-16 (+18d) | 2020-12-31 → 2021-02-19 (+50d) | 46d → 70d |  | 1311d → 1275d |  |  |
| 12 | Council to deliberate and adopt working group consensus recommendations | 2021-01-01 → 2021-02-22 (+52d) | 2021-02-25 → 2021-04-16 (+50d) |  |  | 1311d → 1275d |  |  |
| 13 | Board to deliberate and adopt consensus recommendations | 2021-02-26 → 2021-04-19 (+52d) | 2021-05-06 → 2021-06-25 (+50d) |  |  | 1311d → 1275d |  |  |
| 14 | Engage IRT | 2021-05-07 → 2021-06-28 (+52d) | 2022-01-13 → 2022-03-04 (+50d) |  |  | 1311d → 1275d |  | resources GDD Staff; IRT; Policy Staff → GDS Staff; IRT; Policy Staff |
| 23 | Engage IRT |  |  |  |  |  |  | resources GDD Staff; IRT; Policy Staff → GDS Staff; IRT; Policy Staff |
| 27 | Determine if CC.1 can be coupled with Remaining EPDP-P2 Topics (Accuracy) | 2020-11-30 → 2021-02-22 (+84d) | 2020-11-30 → 2021-02-22 (+84d) |  |  | 1604d → 1544d | 16, 26 → 16, 26, 17 |  |
| 32 | **IRT: Temporary Specification on gTLD Registration Data - Phase 1** |  |  |  | 30% → 32% |  |  |  |
| 33 | Engage IRT: Temporary Specification on gTLD Registration Data - Phase 1 |  |  |  | 30% → 40% |  |  | resources GDD Staff; IRT; Policy Staff → GDS Staff; IRT; Policy Staff |
| 34 | **EPDP-P1 Rec27 Wave 1 Other Policy Impacts** |  | 2024-11-20 → 2021-09-07 (-1170d) | 1146d → 310d | 10% → 29% | 567d → 1403d |  |  |
| 36 | No impacts as a result of Registration Data Services Policy implementation |  |  |  |  |  |  | resources GDD Staff → GDS Staff |
| 37 | **Additional Whois Information Policy (AWIP) [LOW]** |  |  |  | 25% → 38% |  |  |  |
| 38 | Produce redlines of consensus policy provisions (assumes step 2 accomplished here) |  |  |  | 50% → 75% |  |  | resources GDD Staff → GDS Staff |
| 39 | Review and confirm redlines for final changes |  |  |  |  |  |  | resources GDD Staff; IRT; Policy Staff → GDS Staff; IRT; Policy Staff |
| 40 | Conduct public comment of changes |  |  |  |  |  |  | resources GDD Staff; IRT → GDS Staff; IRT |
| 41 | Post updated consensus policy |  |  |  |  |  |  | resources GDD Staff → GDS Staff |
| 42 | **Expired Domain Deletion Policy (EDDP) [MEDIUM]** | 2021-11-25 → 2020-09-04 A (-447d) | 2021-11-25 → 2021-01-07 (-322d) | 1d → 90d | 0% → 38% | 0d → 1576d |  |  |
| 43 | Produce redlines of consensus policy provisions | 2021-05-05 → 2020-09-04 A (-243d) | 2021-07-06 → 2020-11-05 (-243d) |  | 0% → 75% | 1402d → none | 148 → none | constraint start no earlier than 2020-11-02 → none; resources GDD Staff → GDS Staff |
| 44 | Review and confirm redlines for final changes | 2021-07-07 → 2020-11-06 (-243d) | 2021-07-20 → 2020-11-19 (-243d) |  |  | 1402d → 1576d |  | resources GDD Staff; IRT; Policy Staff → GDS Staff; IRT; Policy Staff |
| 45 | Conduct public comment of changes | 2021-07-21 → 2020-11-20 (-243d) | 2021-08-31 → 2020-12-31 (-243d) |  |  | 1402d → 1576d |  | resources GDD Staff; IRT → GDS Staff; IRT |
| 46 | Post updated consensus policy | 2021-09-01 → 2021-01-01 (-243d) | 2021-09-07 → 2021-01-07 (-243d) |  |  | 1402d → 1576d |  | resources GDD Staff → GDS Staff |
| 47 | **Expired Registration Recovery Policy (ERRP) [LOW]** | 2021-11-25 → 2020-09-04 A (-447d) | 2021-11-25 → 2021-01-07 (-322d) | 1d → 90d | 0% → 38% | 0d → 1576d |  |  |
| 48 | Produce redlines of consensus policy provisions | 2021-05-05 → 2020-09-04 A (-243d) | 2021-07-06 → 2020-11-05 (-243d) |  | 0% → 75% | 1402d → none | 148 → none | constraint start no earlier than 2020-11-02 → none; resources GDD Staff → GDS Staff |
| 49 | Review and confirm redlines for final changes | 2021-07-07 → 2020-11-06 (-243d) | 2021-07-20 → 2020-11-19 (-243d) |  |  | 1402d → 1576d |  | resources GDD Staff; IRT; Policy Staff → GDS Staff; IRT; Policy Staff |
| 50 | Conduct public comment of changes | 2021-07-21 → 2020-11-20 (-243d) | 2021-08-31 → 2020-12-31 (-243d) |  |  | 1402d → 1576d |  | resources GDD Staff; IRT → GDS Staff; IRT |
| 51 | Post updated consensus policy | 2021-09-01 → 2021-01-01 (-243d) | 2021-09-07 → 2021-01-07 (-243d) |  |  | 1402d → 1576d |  | resources GDD Staff → GDS Staff |
| 53 | No impacts as a result of Registration Data Services Policy implementation |  |  |  |  |  |  | resources GDD Staff → GDS Staff |
| 56 | Produce redlines of consensus policy provisions |  |  |  |  |  |  | resources GDD Staff → GDS Staff |
| 57 | Review and confirm redlines for final changes |  |  |  |  |  |  | resources GDD Staff; IRT; Policy Staff → GDS Staff; IRT; Policy Staff |
| 58 | Conduct public comment of changes |  |  |  |  |  |  | resources GDD Staff; IRT → GDS Staff; IRT |
| 59 | Post updated consensus policy |  |  |  |  |  |  | resources GDD Staff → GDS Staff |
| 61 | No impacts as a result of Registration Data Services Policy implementation |  |  |  |  |  |  | resources GDD Staff → GDS Staff |
| 62 | **Restored Names Accuracy Policy (RNAP) [LOW]** |  |  |  | 25% → 37% |  |  |  |
| 63 | **Track 1 - Item 1** |  |  |  | 25% → 38% |  |  |  |
| 64 | Produce redlines of consensus policy provisions |  |  |  | 50% → 75% |  |  | resources GDD Staff → GDS Staff |
| 65 | Review and confirm redlines for final changes |  |  |  |  |  |  | resources GDD Staff; IRT; Policy Staff → GDS Staff; IRT; Policy Staff |
| 66 | Conduct public comment of changes |  |  |  |  |  |  | resources GDD Staff; IRT → GDS Staff; IRT |
| 67 | Post updated consensus policy |  |  |  |  |  |  | resources GDD Staff → GDS Staff |
| 70 | **Revised ICANN Procedure for Handling Whois Conflicts with Privacy Law [LOW]** | 2020-09-04 A | 2021-02-24 → 2021-01-07 (-48d) | 124d → 90d | 0% → 38% | 0d → 1576d |  |  |
| 71 | **Track 1 - Items 1 to 3** | 2020-09-04 A | 2020-11-05 → 2021-01-07 (+63d) | 45d → 90d | 0% → 38% | 0d → 1576d |  |  |
| 72 | Produce redlines of consensus policy provisions | 2020-08-03 → 2020-09-04 A (+32d) | 2020-10-02 → 2020-11-05 (+34d) |  | 0% → 75% | 1599d → none |  | constraint start no earlier than 2020-08-03 → none; resources GDD Staff → GDS Staff |
| 73 | Review and confirm redlines for final changes | 2020-10-05 → 2020-11-06 (+32d) | 2020-10-16 → 2020-11-19 (+34d) |  |  | 1599d → 1576d |  | resources GDD Staff; IRT; Policy Staff → GDS Staff; IRT; Policy Staff |
| 74 | Conduct public comment of changes | 2020-10-19 → 2020-11-20 (+32d) | 2020-11-27 → 2020-12-31 (+34d) |  |  | 1599d → 1576d |  | resources GDD Staff; IRT → GDS Staff; IRT |
| 75 | Post updated consensus policy | 2020-11-30 → 2021-01-01 (+32d) | 2020-12-04 → 2021-01-07 (+34d) |  |  | 1599d → 1576d |  | resources GDD Staff → GDS Staff |
| 78 | Produce redlines of consensus policy provisions |  |  |  |  |  |  | resources GDD Staff → GDS Staff |
| 79 | Review and confirm redlines for final changes |  |  |  |  |  |  | resources GDD Staff; IRT; Policy Staff → GDS Staff; IRT; Policy Staff |
| 80 | Conduct public comment of changes |  |  |  |  |  |  | resources GDD Staff; IRT → GDS Staff; IRT |
| 81 | Post updated consensus policy |  |  |  |  |  |  | resources GDD Staff → GDS Staff |
| 82 | **Transfer Policy [HIGH]** | 2021-02-04 → 2020-09-04 A (-153d) | 2021-02-04 → 2021-01-07 (-28d) | 1d → 90d | 0% → 38% | 0d → 1576d |  |  |
| 84 | Review and confirm redlines for final changes |  |  |  |  |  | 88 → 83 | resources GDD Staff; IRT; Policy Staff → GDS Staff; IRT; Policy Staff |
| 85 | Conduct public comment of changes |  |  |  |  |  |  | resources GDD Staff; IRT → GDS Staff; IRT |
| 86 | Post updated consensus policy |  |  |  |  |  |  | resources GDD Staff → GDS Staff |
| 87 | **Transfer Dispute Resolution Policy (TDRP) [HIGH]** | 2021-02-04 → 2020-09-04 A (-153d) | 2021-02-04 → 2021-01-07 (-28d) | 1d → 90d | 0% → 38% | 0d → 1576d |  |  |
| 88 | Produce redlines of consensus policy provisions |  |  |  | 50% → 75% |  |  | resources GDD Staff → GDS Staff |
| 89 | Review and confirm redlines for final changes |  |  |  |  |  | Produce redlines of consensus policy provisions → 88 | resources GDD Staff; IRT; Policy Staff → GDS Staff; IRT; Policy Staff |
| 90 | Conduct public comment of changes |  |  |  |  |  |  | resources GDD Staff; IRT → GDS Staff; IRT |
| 91 | Post updated consensus policy |  |  |  |  |  |  | resources GDD Staff → GDS Staff |
| 92 | **Rules for Uniform Domain Name Dispute Resolution Policy (UDRP Rules) [HIGH]** | 2024-11-20 → 2020-08-03 A (-1570d) | 2024-11-20 → 2020-12-04 (-1447d) | 1d → 90d | 0% → 38% | 0d → 1600d |  |  |
| 94 | Review and confirm redlines for final changes | 2020-11-06 → 2020-10-05 (-32d) | 2020-11-19 → 2020-10-16 (-34d) |  |  | 1575d → 1600d | Produce redlines of consensus policy provisions → 93 | resources GDD Staff; IRT; Policy Staff → GDS Staff; IRT; Policy Staff |
| 95 | Conduct public comment of changes | 2020-11-20 → 2020-10-19 (-32d) | 2020-12-31 → 2020-11-27 (-34d) |  |  | 1575d → 1600d |  | resources GDD Staff; IRT → GDS Staff; IRT |
| 96 | Post updated consensus policy | 2021-01-01 → 2020-11-30 (-32d) | 2021-01-07 → 2020-12-04 (-34d) |  |  | 1575d → 1600d |  | resources GDD Staff → GDS Staff |
| 97 | **Uniform Rapid Suspension System Procedure (URS) [HIGH]** | 2022-05-18 → 2021-05-05 A (-378d) | 2022-05-18 → 2021-09-07 (-253d) | 1d → 90d | 0% → 38% | 0d → 1403d |  |  |
| 99 | Review and confirm redlines for final changes | 2020-11-06 → 2021-07-07 (+243d) | 2020-11-19 → 2021-07-20 (+243d) |  |  | 1575d → 1403d | Produce redlines of consensus policy provisions → 98 | resources GDD Staff; IRT; Policy Staff → GDS Staff; IRT; Policy Staff |
| 100 | Conduct public comment of changes | 2020-11-20 → 2021-07-21 (+243d) | 2020-12-31 → 2021-08-31 (+243d) |  |  | 1575d → 1403d |  | resources GDD Staff; IRT → GDS Staff; IRT |

| ID | Task | Start | Finish | Duration | Complete | Total float | Predecessors | Other |
| --- | --- | --- | --- | --- | --- | --- | --- | --- |
| 101 | Post updated consensus policy | 2021-01-01 → 2021-09-01 (+243d) | 2021-01-07 → 2021-09-07 (+243d) |  |  | 1575d → 1403d |  | resources GDD Staff → GDS Staff |
| 102 | **Uniform Rapid Suspension System Rules (URS Rules) [HIGH]** | 2022-05-18 → 2021-05-05 A (-378d) | 2022-05-18 → 2021-09-07 (-253d) | 1d → 90d | 0% → 38% | 0d → 1403d |  |  |
| 107 | **Whois Data Reminder Policy (WDRP) [MEDIUM]** | 2020-08-03 A → 2020-09-04 A (+32d) | 2021-11-24 → 2021-02-22 (-275d) | 343d → 122d | 12% → 37% | 1347d → 1544d |  |  |
| 108 | **Track 1 - Item 1** |  |  |  | 25% → 38% |  |  |  |
| 109 | Produce redlines of consensus policy provisions |  |  |  | 50% → 75% |  |  | resources GDD Staff → GDS Staff |
| 110 | Review and confirm redlines for final changes |  |  |  |  |  |  | resources GDD Staff; IRT; Policy Staff → GDS Staff; IRT; Policy Staff |
| 111 | Conduct public comment of changes |  |  |  |  |  |  | resources GDD Staff; IRT → GDS Staff; IRT |
| 112 | Post updated consensus policy |  |  |  |  |  |  | resources GDD Staff → GDS Staff |
| 113 | **Track 2 - Items 2 through 6** | 2020-08-03 → 2021-02-22 (+203d) | 2021-11-24 → 2021-02-22 (-275d) | 343d → 1d |  |  |  |  |
| 114 | Migrated to Remaining EPDP-P2 Topics Track 2 (Accuracy) | 2020-08-03 → 2021-02-22 (+203d) | 2020-10-23 → 2021-02-22 (+122d) | 60d → 1d |  |  | none → 17 | was named Council to determine if this issue can be coupled with Accuracy or intruct to Develop Policy Status Report; resources GDD Staff; Policy Staff → Policy Staff; Council |
| 115 | **Whois Marketing Restriction Policy [LOW]** |  |  |  | 25% → 38% |  |  |  |
| 116 | Produce redlines of consensus policy provisions |  |  |  | 50% → 75% |  |  | resources GDD Staff → GDS Staff |
| 117 | Review and confirm redlines for final changes |  |  |  |  |  |  | resources GDD Staff; IRT; Policy Staff → GDS Staff; IRT; Policy Staff |
| 118 | Conduct public comment of changes |  |  |  |  |  |  | resources GDD Staff; IRT → GDS Staff; IRT |
| 119 | Post updated consensus policy |  |  |  |  |  |  | resources GDD Staff → GDS Staff |
| 123 | Council to deliberate findings and determine appropriate path | 2020-12-24 → 2021-01-15 (+22d) | 2021-02-24 → 2021-03-18 (+22d) |  |  | 1542d → 1116d | Request Whois IAG to consider terminology updates and if policy changes are required, Staff to review procedure based on experience and develop report → 122 |  |
| 127 | Council to deliberate findings and determine appropriate path | 2021-09-23 → 2021-07-23 (-62d) | 2021-11-24 → 2021-09-23 (-62d) |  |  | none → 1116d | 114 → 126 |  |
| 134 | Council to consider Wave 1.5 and Wave 2 reports and determine next steps |  |  |  |  |  |  | resources GDD Staff; Council; Policy Staff → GDS Staff; Council; Policy Staff |
| 136 | Engage IRT: Privacy & Proxy Services Accreditation Issues |  |  |  |  |  |  | resources GDD Staff; IRT; Policy Staff → GDS Staff; IRT; Policy Staff |
| 138 | Engage IRT: Translation/Transliteration of gTLD Registration Data |  |  |  |  |  |  | resources GDD Staff; IRT; Policy Staff → GDS Staff; IRT; Policy Staff |
| 139 | **RPM - Program Track** |  |  |  | 8% → 15% |  |  |  |
| 140 | **PDP: Review of All Rights Protection Mechanisms in All gTLDs - Phase 1 (URS, TMCH, Sunrise, Claims)** |  |  |  | 31% → 38% | 1222d → 1223d |  |  |
| 141 | Engage Phase 1 working group (started 4 Mar 2016) |  |  |  | 40% → 75% | 567d → 33.75d |  |  |
| 149 | Engage IRT |  |  |  |  | 1222d → 1223d |  | resources IRT; GDD Staff; Policy Staff → IRT; GDS Staff; Policy Staff |
| 151 | Drafting Team to draft new charter (incl. Items 2 through 11 of Rec27 Wave1) |  |  |  |  | 567d → 568d |  | was named Drafting Team to draft new charter |
| 155 | Engage IRT |  |  |  |  | 567d → 568d |  | resources IRT; GDD Staff; Policy Staff → IRT; GDS Staff; Policy Staff |
| 156 | **gTLD - Program Track** |  |  |  | 8% → 11% |  |  |  |
| 157 | **CCWG: New gTLD Auction Proceeds Drafting Team (group completed 31 May 2020)** |  |  |  | 6% → 7% |  |  |  |
| 159 | Board to deliberate and adopt consensus recommendations | 2020-08-31 A |  |  | 0% → 5% |  |  |  |
| 161 | **PDP: New gTLD Subsequent Procedures PDP** |  |  |  | 11% → 13% |  |  |  |
| 162 | Execute New gTLD Subsequent Procedures PDP (started 21 Jan 2016) |  |  |  | 70% → 85% |  |  |  |
| 165 | Execute IRT |  |  |  |  |  |  | resources IRT; GDD Staff; Policy Staff → IRT; GDS Staff; Policy Staff |
| 166 | **Internationalized Domain Names** |  | 2023-04-14 → 2023-05-02 (+18d) | 728d → 740d | 7% → 11% | 985d → 973d |  |  |
| 167 | **IDN Operational Track 1 Working Group** |  |  |  | 33% → 40% |  |  |  |
| 168 | Determine scope of Track 1 working group |  |  |  |  |  |  | resources Contracted Parties; GDD Staff → Contracted Parties; GDS Staff |
| 169 | Engage Operational Track 1 expert group |  |  |  | 10% → 20% |  |  | resources Contracted Parties; GDD Staff → Contracted Parties; GDS Staff |
| 170 | **IDN Policy Track 2 EPDP Working Group** | 2020-10-05 → 2020-10-21 (+16d) | 2023-04-14 → 2023-05-02 (+18d) |  |  |  |  |  |
| 171 | Drafting Team to draft charter | 2020-10-05 → 2020-10-21 (+16d) | 2020-12-25 → 2021-01-12 (+18d) |  |  |  |  |  |
| 172 | Engage Track 2 EPDP working group | 2020-12-28 → 2021-01-13 (+16d) | 2021-12-10 → 2021-12-28 (+18d) |  |  | 985d → 973d |  | resources GDD Staff; Policy Staff; Working Group → GDS Staff; Policy Staff; Working Group |
| 173 | Council to deliberate and adopt working group consensus recommendations | 2021-12-13 → 2021-12-29 (+16d) | 2022-02-04 → 2022-02-22 (+18d) |  |  | 985d → 973d |  |  |
| 174 | Board to deliberate and adopt consensus recommendations | 2022-02-07 → 2022-02-23 (+16d) | 2022-04-29 → 2022-05-17 (+18d) |  |  | 985d → 973d |  |  |
| 175 | Engage IRT | 2022-05-02 → 2022-05-18 (+16d) | 2023-04-14 → 2023-05-02 (+18d) |  |  | 985d → 973d |  | resources GDD Staff; IRT → GDS Staff; IRT |
| 176 | **IDN Track 3 Council Coordination** |  |  |  | 10% → 20% |  |  |  |
| 177 | GNSO Council to coordinate with the CCNSO regarding IDN policy developments |  |  |  | 10% → 20% |  |  |  |
| 178 | **Expiration - Program Track** | 2020-09-04 A → 2020-10-21 (+47d) | 2021-11-24 → 2022-10-04 (+314d) | 319d → 510d | 16% → 0% | 1347d → 0d |  |  |
| 179 | **Expired Domain Deletion Policy (EDDP) / Expired Registration Recovery Policy (ERRP) Review** | 2021-07-01 → 2020-10-21 (-253d) | 2021-11-24 → 2022-10-04 (+314d) | 105d → 510d |  |  |  |  |
| 181 | Develop Policy Status Report (incl. Rec27 Wave1 EDDP Item 2 + ERRP Item3) | 2021-07-01 → 2022-03-30 (+272d) | 2021-09-22 → 2022-08-02 (+314d) | 60d → 90d |  |  | none → 180 | was named Develop Policy Status Report; resources GDD Staff; Policy Staff → GDS Staff; Policy Staff |
| 182 | Council to deliberate findings | 2021-09-23 → 2022-08-03 (+314d) | 2021-11-24 → 2022-10-04 (+314d) |  |  | 1346d → 1123d |  |  |
| 183 | **Transfers - Program Track** |  | 2024-09-24 → 2024-09-10 (-14d) | 1105d → 1095d | 10% → 9% | 608d → 618d |  |  |
| 184 | **Transfer Policy Review** |  | 2024-09-24 → 2024-09-10 (-14d) | 1105d → 1095d | 8% → 9% | 608d → 618d |  |  |
| 186 | Develop Issues Report |  |  |  | 60% → 70% | 608d → 618d |  | was named Issues Report |
| 188 | Council to approve PDP launch | 2021-01-27 → 2021-01-13 (-14d) | 2021-02-09 → 2021-01-26 (-14d) |  |  | 608d → 618d | 186, Staff to include as part of Transfer Review Issue Report and subseqent scoping of effort → 186 |  |
| 189 | Council to approve scope and charter | 2021-02-10 → 2021-01-27 (-14d) | 2021-03-30 → 2021-03-16 (-14d) |  |  | 608d → 618d |  |  |
| 190 | Engage Transfer Policy Review PDP | 2021-03-31 → 2021-03-17 (-14d) | 2023-04-25 → 2023-04-11 (-14d) |  |  | 608d → 618d |  |  |
| 191 | Council to deliberate and adopt working group consensus recommendations | 2023-04-26 → 2023-04-12 (-14d) | 2023-06-20 → 2023-06-06 (-14d) |  |  | 608d → 618d |  |  |
| 192 | Board to deliberate and adopt consensus recommendations | 2023-06-21 → 2023-06-07 (-14d) | 2023-09-12 → 2023-08-29 (-14d) |  |  | 608d → 618d |  |  |
| 193 | Engage IRT | 2023-09-13 → 2023-08-30 (-14d) | 2024-09-24 → 2024-09-10 (-14d) |  |  | 608d → 618d |  | resources IRT; GDD Staff; Policy Staff → IRT; GDS Staff; Policy Staff |
| 201 | Engage IRT |  |  |  |  |  |  | resources GDD Staff; IRT; Policy Staff → GDS Staff; IRT; Policy Staff |
| 204 | Engage IRT |  |  |  |  |  |  | resources GDD Staff; IRT; Policy Staff → GDS Staff; IRT; Policy Staff |
| 206 | Engage IRT |  |  |  |  |  |  | resources GDD Staff; IRT; Policy Staff → GDS Staff; IRT; Policy Staff |
| 207 | **Accountability - Program Track** |  |  |  | 9% → 11% |  |  |  |
| 208 | **Independent Review Process - Implementation Oversight Team** |  |  |  | 20% → 30% |  |  |  |
| 209 | Engage IoT Oversight Team |  |  |  | 20% → 30% |  |  |  |
| 210 | **Cross Community Working Group on Enhancing ICANN Accountability - WS2** |  |  |  | 3% → 5% |  |  |  |
| 211 | Council small team to revew WS2 |  |  |  | 10% → 20% |  |  |  |
| 217 | **Reviews - Program Track** |  |  |  | 5% → 8% |  |  |  |
| 218 | **IANA Naming Function Review** |  | 2021-01-26 → 2021-03-23 (+56d) | 150d → 190d | 20% → 39% | 1563d → 1523d |  |  |
| 220 | GNSO participation on IFRT2 |  | 2021-01-26 → 2021-03-23 (+56d) | 150d → 190d | 20% → 39% | 1563d → 1523d |  |  |
| 242 | **Security, Stability and Resiliency of the DNS #2** |  |  |  | 22% → 44% |  |  |  |
| 243 | GNSO participation on SSR#2 |  |  |  | 30% → 60% |  |  |  |

| ID | Task | Start | Finish | Complete | Other |
| --- | --- | --- | --- | --- | --- |
| 248 | **Operations - Program Track** |  |  | 14% → 17% |  |
| 252 | Review IRT principles and CPIF |  |  |  | resources GDD Staff → GDS Staff |
| 254 | **Participant of Empowered Community** |  |  | 4% → 6% |  |
| 255 | Perform role 2020 |  | 2020-10-21 A | 70% → 100% |  |
| 266 | **GNSO Council** |  |  | 39% → 45% |  |
| 267 | **GNSO Council - Monthly Meetings** |  |  | 17% → 22% |  |
| 271 | GNSO Council Meeting 4 | 2020-10-21 A | 2020-10-21 A | 0% → 100% |  |
| 286 | **GNSO Council - Leadership Meetings** |  |  | 17% → 22% |  |
| 290 | GNSO Council - Leadership Meetings 4 | 2020-10-12 A | 2020-10-13 A | 0% → 100% |  |
| 305 | **GNSO Council - Action Items** |  |  | 17% → 22% |  |
| 309 | GNSO Council - Action Items 4 | 2020-10-12 A | 2020-10-12 A | 0% → 100% |  |
| 328 | **GNSO Standing Selection Committee** |  |  | 50% → 60% |  |
| 329 | SSC fill positions as assigned |  |  | 50% → 60% |  |
| 330 | **Strategic Planning Session** |  |  | 47% → 49% |  |
| 332 | Develop plan, topics, and materials for deliberation | 2020-10-21 A |  | 0% → 5% |  |

## Version 5 (saved 2020-10-28, file GNSO_Council_Program_Management_Tool_20201119.mpp)

Last finish 2027-01-22 → 2026-06-30 (-206d). Complete tasks 31 → 34.

Added:

| ID | Task | Duration | Start | Finish | Predecessors | Constraint | Resources |
| --- | --- | --- | --- | --- | --- | --- | --- |
| 16 | Staff to produce Briefing Document on Accuracy | 100d | 2020-09-28 | 2021-02-12 | 5 |  |  |
| 287 | GNSO Council Meeting | 1d | 2022-01-20 | 2022-01-20 |  | start no earlier than 2022-01-20 | Council; Policy Staff |
| 288 | GNSO Council Meeting | 1d | 2022-02-17 | 2022-02-17 |  | start no earlier than 2022-02-17 | Council; Policy Staff |
| 289 | GNSO Council Meeting | 1d | 2022-03-24 | 2022-03-24 |  | start no earlier than 2022-03-24 | Council; Policy Staff |
| 290 | GNSO Council Meeting | 1d | 2022-04-21 | 2022-04-21 |  | start no earlier than 2022-04-21 | Council; Policy Staff |
| 291 | GNSO Council Meeting | 1d | 2022-05-19 | 2022-05-19 |  | start no earlier than 2022-05-19 | Council; Policy Staff |
| 292 | GNSO Council Meeting | 1d | 2022-06-22 | 2022-06-22 |  | start no earlier than 2022-06-22 | Council; Policy Staff |
| 293 | GNSO Council Meeting | 1d | 2022-07-21 | 2022-07-21 |  | start no earlier than 2022-07-21 | Council; Policy Staff |
| 294 | GNSO Council Meeting | 1d | 2022-08-18 | 2022-08-18 |  | start no earlier than 2022-08-18 | Council; Policy Staff |
| 295 | GNSO Council Meeting | 1d | 2022-09-22 | 2022-09-22 |  | start no earlier than 2022-09-22 | Council; Policy Staff |
| 296 | GNSO Council Meeting | 1d | 2022-10-19 | 2022-10-19 |  | start no earlier than 2022-10-19 | Council; Policy Staff |
| 297 | GNSO Council Meeting | 1d | 2022-11-17 | 2022-11-17 |  | start no earlier than 2022-11-17 | Council; Policy Staff |
| 298 | GNSO Council Meeting | 1d | 2022-12-15 | 2022-12-15 |  | start no earlier than 2022-12-15 | Council; Policy Staff |
| 299 | GNSO Council Meeting | 1d | 2023-01-19 | 2023-01-19 |  | start no earlier than 2023-01-19 | Council; Policy Staff |
| 300 | GNSO Council Meeting | 1d | 2023-02-16 | 2023-02-16 |  | start no earlier than 2023-02-16 | Council; Policy Staff |
| 301 | GNSO Council Meeting | 1d | 2023-03-22 | 2023-03-22 |  | start no earlier than 2023-03-22 | Council; Policy Staff |
| 302 | GNSO Council Meeting | 1d | 2023-04-20 | 2023-04-20 |  | start no earlier than 2023-04-20 | Council; Policy Staff |
| 303 | GNSO Council Meeting | 1d | 2023-05-18 | 2023-05-18 |  | start no earlier than 2023-05-18 | Council; Policy Staff |
| 304 | GNSO Council Meeting | 1d | 2023-06-21 | 2023-06-21 |  | start no earlier than 2023-06-21 | Council; Policy Staff |
| 305 | GNSO Council Meeting | 1d | 2023-07-20 | 2023-07-20 |  | start no earlier than 2023-07-20 | Council; Policy Staff |
| 306 | GNSO Council Meeting | 1d | 2023-08-17 | 2023-08-17 |  | start no earlier than 2023-08-17 | Council; Policy Staff |
| 307 | GNSO Council Meeting | 1d | 2023-09-21 | 2023-09-21 |  | start no earlier than 2023-09-21 | Council; Policy Staff |
| 308 | GNSO Council Meeting | 1d | 2023-10-18 | 2023-10-18 |  | start no earlier than 2023-10-18 | Council; Policy Staff |
| 309 | GNSO Council Meeting | 1d | 2023-11-16 | 2023-11-16 |  | start no earlier than 2023-11-16 | Council; Policy Staff |
| 310 | GNSO Council Meeting | 1d | 2023-12-14 | 2023-12-14 |  | start no earlier than 2023-12-14 | Council; Policy Staff |
| 311 | GNSO Council Meeting | 1d | 2024-01-18 | 2024-01-18 |  | start no earlier than 2024-01-18 | Council; Policy Staff |
| 312 | GNSO Council Meeting | 1d | 2024-02-15 | 2024-02-15 |  | start no earlier than 2024-02-15 | Council; Policy Staff |
| 313 | GNSO Council Meeting | 1d | 2024-03-20 | 2024-03-20 |  | start no earlier than 2024-03-20 | Council; Policy Staff |
| 314 | GNSO Council Meeting | 1d | 2024-04-18 | 2024-04-18 |  | start no earlier than 2024-04-18 | Council; Policy Staff |
| 315 | GNSO Council Meeting | 1d | 2024-05-16 | 2024-05-16 |  | start no earlier than 2024-05-16 | Council; Policy Staff |
| 316 | GNSO Council Meeting | 1d | 2024-06-19 | 2024-06-19 |  | start no earlier than 2024-06-19 | Council; Policy Staff |
| 317 | GNSO Council Meeting | 1d | 2024-07-18 | 2024-07-18 |  | start no earlier than 2024-07-18 | Council; Policy Staff |
| 318 | GNSO Council Meeting | 1d | 2024-08-15 | 2024-08-15 |  | start no earlier than 2024-08-15 | Council; Policy Staff |
| 319 | GNSO Council Meeting | 1d | 2024-09-19 | 2024-09-19 |  | start no earlier than 2024-09-19 | Council; Policy Staff |
| 320 | GNSO Council Meeting | 1d | 2024-10-23 | 2024-10-23 |  | start no earlier than 2024-10-23 | Council; Policy Staff |
| 321 | GNSO Council Meeting | 1d | 2024-11-14 | 2024-11-14 |  | start no earlier than 2024-11-14 | Council; Policy Staff |
| 322 | GNSO Council Meeting | 1d | 2024-12-12 | 2024-12-12 |  | start no earlier than 2024-12-12 | Council; Policy Staff |
| 323 | GNSO Council Meeting | 1d | 2025-01-16 | 2025-01-16 |  | start no earlier than 2025-01-16 | Council; Policy Staff |
| 324 | GNSO Council Meeting | 1d | 2025-02-13 | 2025-02-13 |  | start no earlier than 2025-02-13 | Council; Policy Staff |
| 325 | GNSO Council Meeting | 1d | 2025-03-19 | 2025-03-19 |  | start no earlier than 2025-03-19 | Council; Policy Staff |
| 326 | GNSO Council Meeting | 1d | 2025-04-17 | 2025-04-17 |  | start no earlier than 2025-04-17 | Council; Policy Staff |
| 327 | GNSO Council Meeting | 1d | 2025-05-15 | 2025-05-15 |  | start no earlier than 2025-05-15 | Council; Policy Staff |
| 328 | GNSO Council Meeting | 1d | 2025-06-18 | 2025-06-18 |  | start no earlier than 2025-06-18 | Council; Policy Staff |
| 329 | GNSO Council Meeting | 1d | 2025-07-17 | 2025-07-17 |  | start no earlier than 2025-07-17 | Council; Policy Staff |
| 330 | GNSO Council Meeting | 1d | 2025-08-21 | 2025-08-21 |  | start no earlier than 2025-08-21 | Council; Policy Staff |
| 331 | GNSO Council Meeting | 1d | 2025-09-18 | 2025-09-18 |  | start no earlier than 2025-09-18 | Council; Policy Staff |
| 332 | GNSO Council Meeting | 1d | 2025-10-22 | 2025-10-22 |  | start no earlier than 2025-10-22 | Council; Policy Staff |
| 333 | GNSO Council Meeting | 1d | 2025-11-13 | 2025-11-13 |  | start no earlier than 2025-11-13 | Council; Policy Staff |
| 334 | GNSO Council Meeting | 1d | 2025-12-18 | 2025-12-18 |  | start no earlier than 2025-12-18 | Council; Policy Staff |
| 335 | GNSO Council Meeting | 1d | 2026-01-15 | 2026-01-15 |  | start no earlier than 2026-01-15 | Council; Policy Staff |
| 336 | GNSO Council Meeting | 1d | 2026-02-19 | 2026-02-19 |  | start no earlier than 2026-02-19 | Council; Policy Staff |
| 337 | GNSO Council Meeting | 1d | 2026-03-18 | 2026-03-18 |  | start no earlier than 2026-03-18 | Council; Policy Staff |
| 338 | GNSO Council Meeting | 1d | 2026-04-16 | 2026-04-16 |  | start no earlier than 2026-04-16 | Council; Policy Staff |
| 339 | GNSO Council Meeting | 1d | 2026-05-14 | 2026-05-14 |  | start no earlier than 2026-05-14 | Council; Policy Staff |
| 340 | GNSO Council Meeting | 1d | 2026-06-17 | 2026-06-17 |  | start no earlier than 2026-06-17 | Council; Policy Staff |
| 360 | GNSO Council - Leadership Meetings | 2d | 2022-01-20 | 2022-01-21 |  | start no earlier than 2022-01-20 | Policy Staff; Council Leads |
| 361 | GNSO Council - Leadership Meetings | 2d | 2022-02-17 | 2022-02-18 |  | start no earlier than 2022-02-17 | Policy Staff; Council Leads |
| 362 | GNSO Council - Leadership Meetings | 2d | 2022-03-24 | 2022-03-25 |  | start no earlier than 2022-03-24 | Policy Staff; Council Leads |
| 363 | GNSO Council - Leadership Meetings | 2d | 2022-04-21 | 2022-04-22 |  | start no earlier than 2022-04-21 | Policy Staff; Council Leads |
| 364 | GNSO Council - Leadership Meetings | 2d | 2022-05-19 | 2022-05-20 |  | start no earlier than 2022-05-19 | Policy Staff; Council Leads |
| 365 | GNSO Council - Leadership Meetings | 2d | 2022-06-22 | 2022-06-23 |  | start no earlier than 2022-06-22 | Policy Staff; Council Leads |
| 366 | GNSO Council - Leadership Meetings | 2d | 2022-07-21 | 2022-07-22 |  | start no earlier than 2022-07-21 | Policy Staff; Council Leads |
| 367 | GNSO Council - Leadership Meetings | 2d | 2022-08-18 | 2022-08-19 |  | start no earlier than 2022-08-18 | Policy Staff; Council Leads |
| 368 | GNSO Council - Leadership Meetings | 2d | 2022-09-22 | 2022-09-23 |  | start no earlier than 2022-09-22 | Policy Staff; Council Leads |
| 369 | GNSO Council - Leadership Meetings | 2d | 2022-10-19 | 2022-10-20 |  | start no earlier than 2022-10-19 | Policy Staff; Council Leads |
| 370 | GNSO Council - Leadership Meetings | 2d | 2022-11-17 | 2022-11-18 |  | start no earlier than 2022-11-17 | Policy Staff; Council Leads |
| 371 | GNSO Council - Leadership Meetings | 2d | 2022-12-15 | 2022-12-16 |  | start no earlier than 2022-12-15 | Policy Staff; Council Leads |
| 372 | GNSO Council - Leadership Meetings | 2d | 2023-01-19 | 2023-01-20 |  | start no earlier than 2023-01-19 | Policy Staff; Council Leads |
| 373 | GNSO Council - Leadership Meetings | 2d | 2023-02-16 | 2023-02-17 |  | start no earlier than 2023-02-16 | Policy Staff; Council Leads |
| 374 | GNSO Council - Leadership Meetings | 2d | 2023-03-22 | 2023-03-23 |  | start no earlier than 2023-03-22 | Policy Staff; Council Leads |
| 375 | GNSO Council - Leadership Meetings | 2d | 2023-04-20 | 2023-04-21 |  | start no earlier than 2023-04-20 | Policy Staff; Council Leads |
| 376 | GNSO Council - Leadership Meetings | 2d | 2023-05-18 | 2023-05-19 |  | start no earlier than 2023-05-18 | Policy Staff; Council Leads |
| 377 | GNSO Council - Leadership Meetings | 2d | 2023-06-21 | 2023-06-22 |  | start no earlier than 2023-06-21 | Policy Staff; Council Leads |
| 378 | GNSO Council - Leadership Meetings | 2d | 2023-07-20 | 2023-07-21 |  | start no earlier than 2023-07-20 | Policy Staff; Council Leads |
| 379 | GNSO Council - Leadership Meetings | 2d | 2023-08-17 | 2023-08-18 |  | start no earlier than 2023-08-17 | Policy Staff; Council Leads |
| 380 | GNSO Council - Leadership Meetings | 2d | 2023-09-21 | 2023-09-22 |  | start no earlier than 2023-09-21 | Policy Staff; Council Leads |
| 381 | GNSO Council - Leadership Meetings | 2d | 2023-10-18 | 2023-10-19 |  | start no earlier than 2023-10-18 | Policy Staff; Council Leads |
| 382 | GNSO Council - Leadership Meetings | 2d | 2023-11-16 | 2023-11-17 |  | start no earlier than 2023-11-16 | Policy Staff; Council Leads |
| 383 | GNSO Council - Leadership Meetings | 2d | 2023-12-14 | 2023-12-15 |  | start no earlier than 2023-12-14 | Policy Staff; Council Leads |
| 384 | GNSO Council - Leadership Meetings | 2d | 2024-01-18 | 2024-01-19 |  | start no earlier than 2024-01-18 | Policy Staff; Council Leads |
| 385 | GNSO Council - Leadership Meetings | 2d | 2024-02-15 | 2024-02-16 |  | start no earlier than 2024-02-15 | Policy Staff; Council Leads |
| 386 | GNSO Council - Leadership Meetings | 2d | 2024-03-20 | 2024-03-21 |  | start no earlier than 2024-03-20 | Policy Staff; Council Leads |
| 387 | GNSO Council - Leadership Meetings | 2d | 2024-04-18 | 2024-04-19 |  | start no earlier than 2024-04-18 | Policy Staff; Council Leads |
| 388 | GNSO Council - Leadership Meetings | 2d | 2024-05-16 | 2024-05-17 |  | start no earlier than 2024-05-16 | Policy Staff; Council Leads |
| 389 | GNSO Council - Leadership Meetings | 2d | 2024-06-19 | 2024-06-20 |  | start no earlier than 2024-06-19 | Policy Staff; Council Leads |
| 390 | GNSO Council - Leadership Meetings | 2d | 2024-07-18 | 2024-07-19 |  | start no earlier than 2024-07-18 | Policy Staff; Council Leads |
| 391 | GNSO Council - Leadership Meetings | 2d | 2024-08-15 | 2024-08-16 |  | start no earlier than 2024-08-15 | Policy Staff; Council Leads |
| 392 | GNSO Council - Leadership Meetings | 2d | 2024-09-19 | 2024-09-20 |  | start no earlier than 2024-09-19 | Policy Staff; Council Leads |
| 393 | GNSO Council - Leadership Meetings | 2d | 2024-10-23 | 2024-10-24 |  | start no earlier than 2024-10-23 | Policy Staff; Council Leads |
| 394 | GNSO Council - Leadership Meetings | 2d | 2024-11-14 | 2024-11-15 |  | start no earlier than 2024-11-14 | Policy Staff; Council Leads |
| 395 | GNSO Council - Leadership Meetings | 2d | 2024-12-12 | 2024-12-13 |  | start no earlier than 2024-12-12 | Policy Staff; Council Leads |
| 396 | GNSO Council - Leadership Meetings | 2d | 2025-01-16 | 2025-01-17 |  | start no earlier than 2025-01-16 | Policy Staff; Council Leads |
| 397 | GNSO Council - Leadership Meetings | 2d | 2025-02-13 | 2025-02-14 |  | start no earlier than 2025-02-13 | Policy Staff; Council Leads |
| 398 | GNSO Council - Leadership Meetings | 2d | 2025-03-19 | 2025-03-20 |  | start no earlier than 2025-03-19 | Policy Staff; Council Leads |
| 399 | GNSO Council - Leadership Meetings | 2d | 2025-04-17 | 2025-04-18 |  | start no earlier than 2025-04-17 | Policy Staff; Council Leads |
| 400 | GNSO Council - Leadership Meetings | 2d | 2025-05-15 | 2025-05-16 |  | start no earlier than 2025-05-15 | Policy Staff; Council Leads |
| 401 | GNSO Council - Leadership Meetings | 2d | 2025-06-18 | 2025-06-19 |  | start no earlier than 2025-06-18 | Policy Staff; Council Leads |
| 402 | GNSO Council - Leadership Meetings | 2d | 2025-07-17 | 2025-07-18 |  | start no earlier than 2025-07-17 | Policy Staff; Council Leads |
| 403 | GNSO Council - Leadership Meetings | 2d | 2025-08-21 | 2025-08-22 |  | start no earlier than 2025-08-21 | Policy Staff; Council Leads |
| 404 | GNSO Council - Leadership Meetings | 2d | 2025-09-18 | 2025-09-19 |  | start no earlier than 2025-09-18 | Policy Staff; Council Leads |
| 405 | GNSO Council - Leadership Meetings | 2d | 2025-10-22 | 2025-10-23 |  | start no earlier than 2025-10-22 | Policy Staff; Council Leads |
| 406 | GNSO Council - Leadership Meetings | 2d | 2025-11-13 | 2025-11-14 |  | start no earlier than 2025-11-13 | Policy Staff; Council Leads |
| 407 | GNSO Council - Leadership Meetings | 2d | 2025-12-18 | 2025-12-19 |  | start no earlier than 2025-12-18 | Policy Staff; Council Leads |
| 408 | GNSO Council - Leadership Meetings | 2d | 2026-01-15 | 2026-01-16 |  | start no earlier than 2026-01-15 | Policy Staff; Council Leads |
| 409 | GNSO Council - Leadership Meetings | 2d | 2026-02-19 | 2026-02-20 |  | start no earlier than 2026-02-19 | Policy Staff; Council Leads |
| 410 | GNSO Council - Leadership Meetings | 2d | 2026-03-18 | 2026-03-19 |  | start no earlier than 2026-03-18 | Policy Staff; Council Leads |
| 411 | GNSO Council - Leadership Meetings | 2d | 2026-04-16 | 2026-04-17 |  | start no earlier than 2026-04-16 | Policy Staff; Council Leads |
| 412 | GNSO Council - Leadership Meetings | 2d | 2026-05-14 | 2026-05-15 |  | start no earlier than 2026-05-14 | Policy Staff; Council Leads |
| 413 | GNSO Council - Leadership Meetings | 2d | 2026-06-17 | 2026-06-18 |  | start no earlier than 2026-06-17 | Policy Staff; Council Leads |
| 433 | GNSO Council - Action Items | 1d | 2022-01-20 | 2022-01-20 |  | start no earlier than 2022-01-20 | Council; Policy Staff |
| 434 | GNSO Council - Action Items | 1d | 2022-02-17 | 2022-02-17 |  | start no earlier than 2022-02-17 | Council; Policy Staff |
| 435 | GNSO Council - Action Items | 1d | 2022-03-24 | 2022-03-24 |  | start no earlier than 2022-03-24 | Council; Policy Staff |
| 436 | GNSO Council - Action Items | 1d | 2022-04-21 | 2022-04-21 |  | start no earlier than 2022-04-21 | Council; Policy Staff |
| 437 | GNSO Council - Action Items | 1d | 2022-05-19 | 2022-05-19 |  | start no earlier than 2022-05-19 | Council; Policy Staff |
| 438 | GNSO Council - Action Items | 1d | 2022-06-22 | 2022-06-22 |  | start no earlier than 2022-06-22 | Council; Policy Staff |
| 439 | GNSO Council - Action Items | 1d | 2022-07-21 | 2022-07-21 |  | start no earlier than 2022-07-21 | Council; Policy Staff |
| 440 | GNSO Council - Action Items | 1d | 2022-08-18 | 2022-08-18 |  | start no earlier than 2022-08-18 | Council; Policy Staff |
| 441 | GNSO Council - Action Items | 1d | 2022-09-22 | 2022-09-22 |  | start no earlier than 2022-09-22 | Council; Policy Staff |
| 442 | GNSO Council - Action Items | 1d | 2022-10-19 | 2022-10-19 |  | start no earlier than 2022-10-19 | Council; Policy Staff |
| 443 | GNSO Council - Action Items | 1d | 2022-11-17 | 2022-11-17 |  | start no earlier than 2022-11-17 | Council; Policy Staff |
| 444 | GNSO Council - Action Items | 1d | 2022-12-15 | 2022-12-15 |  | start no earlier than 2022-12-15 | Council; Policy Staff |
| 445 | GNSO Council - Action Items | 1d | 2023-01-19 | 2023-01-19 |  | start no earlier than 2023-01-19 | Council; Policy Staff |
| 446 | GNSO Council - Action Items | 1d | 2023-02-16 | 2023-02-16 |  | start no earlier than 2023-02-16 | Council; Policy Staff |
| 447 | GNSO Council - Action Items | 1d | 2023-03-22 | 2023-03-22 |  | start no earlier than 2023-03-22 | Council; Policy Staff |
| 448 | GNSO Council - Action Items | 1d | 2023-04-20 | 2023-04-20 |  | start no earlier than 2023-04-20 | Council; Policy Staff |
| 449 | GNSO Council - Action Items | 1d | 2023-05-18 | 2023-05-18 |  | start no earlier than 2023-05-18 | Council; Policy Staff |
| 450 | GNSO Council - Action Items | 1d | 2023-06-21 | 2023-06-21 |  | start no earlier than 2023-06-21 | Council; Policy Staff |
| 451 | GNSO Council - Action Items | 1d | 2023-07-20 | 2023-07-20 |  | start no earlier than 2023-07-20 | Council; Policy Staff |
| 452 | GNSO Council - Action Items | 1d | 2023-08-17 | 2023-08-17 |  | start no earlier than 2023-08-17 | Council; Policy Staff |
| 453 | GNSO Council - Action Items | 1d | 2023-09-21 | 2023-09-21 |  | start no earlier than 2023-09-21 | Council; Policy Staff |
| 454 | GNSO Council - Action Items | 1d | 2023-10-18 | 2023-10-18 |  | start no earlier than 2023-10-18 | Council; Policy Staff |
| 455 | GNSO Council - Action Items | 1d | 2023-11-16 | 2023-11-16 |  | start no earlier than 2023-11-16 | Council; Policy Staff |
| 456 | GNSO Council - Action Items | 1d | 2023-12-14 | 2023-12-14 |  | start no earlier than 2023-12-14 | Council; Policy Staff |
| 457 | GNSO Council - Action Items | 1d | 2024-01-18 | 2024-01-18 |  | start no earlier than 2024-01-18 | Council; Policy Staff |
| 458 | GNSO Council - Action Items | 1d | 2024-02-15 | 2024-02-15 |  | start no earlier than 2024-02-15 | Council; Policy Staff |
| 459 | GNSO Council - Action Items | 1d | 2024-03-20 | 2024-03-20 |  | start no earlier than 2024-03-20 | Council; Policy Staff |
| 460 | GNSO Council - Action Items | 1d | 2024-04-18 | 2024-04-18 |  | start no earlier than 2024-04-18 | Council; Policy Staff |
| 461 | GNSO Council - Action Items | 1d | 2024-05-16 | 2024-05-16 |  | start no earlier than 2024-05-16 | Council; Policy Staff |
| 462 | GNSO Council - Action Items | 1d | 2024-06-19 | 2024-06-19 |  | start no earlier than 2024-06-19 | Council; Policy Staff |
| 463 | GNSO Council - Action Items | 1d | 2024-07-18 | 2024-07-18 |  | start no earlier than 2024-07-18 | Council; Policy Staff |
| 464 | GNSO Council - Action Items | 1d | 2024-08-15 | 2024-08-15 |  | start no earlier than 2024-08-15 | Council; Policy Staff |
| 465 | GNSO Council - Action Items | 1d | 2024-09-19 | 2024-09-19 |  | start no earlier than 2024-09-19 | Council; Policy Staff |
| 466 | GNSO Council - Action Items | 1d | 2024-10-23 | 2024-10-23 |  | start no earlier than 2024-10-23 | Council; Policy Staff |
| 467 | GNSO Council - Action Items | 1d | 2024-11-14 | 2024-11-14 |  | start no earlier than 2024-11-14 | Council; Policy Staff |
| 468 | GNSO Council - Action Items | 1d | 2024-12-12 | 2024-12-12 |  | start no earlier than 2024-12-12 | Council; Policy Staff |
| 469 | GNSO Council - Action Items | 1d | 2025-01-16 | 2025-01-16 |  | start no earlier than 2025-01-16 | Council; Policy Staff |
| 470 | GNSO Council - Action Items | 1d | 2025-02-13 | 2025-02-13 |  | start no earlier than 2025-02-13 | Council; Policy Staff |
| 471 | GNSO Council - Action Items | 1d | 2025-03-19 | 2025-03-19 |  | start no earlier than 2025-03-19 | Council; Policy Staff |
| 472 | GNSO Council - Action Items | 1d | 2025-04-17 | 2025-04-17 |  | start no earlier than 2025-04-17 | Council; Policy Staff |
| 473 | GNSO Council - Action Items | 1d | 2025-05-15 | 2025-05-15 |  | start no earlier than 2025-05-15 | Council; Policy Staff |
| 474 | GNSO Council - Action Items | 1d | 2025-06-18 | 2025-06-18 |  | start no earlier than 2025-06-18 | Council; Policy Staff |
| 475 | GNSO Council - Action Items | 1d | 2025-07-17 | 2025-07-17 |  | start no earlier than 2025-07-17 | Council; Policy Staff |
| 476 | GNSO Council - Action Items | 1d | 2025-08-21 | 2025-08-21 |  | start no earlier than 2025-08-21 | Council; Policy Staff |
| 477 | GNSO Council - Action Items | 1d | 2025-09-18 | 2025-09-18 |  | start no earlier than 2025-09-18 | Council; Policy Staff |
| 478 | GNSO Council - Action Items | 1d | 2025-10-22 | 2025-10-22 |  | start no earlier than 2025-10-22 | Council; Policy Staff |
| 479 | GNSO Council - Action Items | 1d | 2025-11-13 | 2025-11-13 |  | start no earlier than 2025-11-13 | Council; Policy Staff |
| 480 | GNSO Council - Action Items | 1d | 2025-12-18 | 2025-12-18 |  | start no earlier than 2025-12-18 | Council; Policy Staff |
| 481 | GNSO Council - Action Items | 1d | 2026-01-15 | 2026-01-15 |  | start no earlier than 2026-01-15 | Council; Policy Staff |
| 482 | GNSO Council - Action Items | 1d | 2026-02-19 | 2026-02-19 |  | start no earlier than 2026-02-19 | Council; Policy Staff |
| 483 | GNSO Council - Action Items | 1d | 2026-03-18 | 2026-03-18 |  | start no earlier than 2026-03-18 | Council; Policy Staff |
| 484 | GNSO Council - Action Items | 1d | 2026-04-16 | 2026-04-16 |  | start no earlier than 2026-04-16 | Council; Policy Staff |
| 485 | GNSO Council - Action Items | 1d | 2026-05-14 | 2026-05-14 |  | start no earlier than 2026-05-14 | Council; Policy Staff |
| 486 | GNSO Council - Action Items | 1d | 2026-06-17 | 2026-06-17 |  | start no earlier than 2026-06-17 | Council; Policy Staff |
| 498 | **ICANN Meeting Planning, Meeting, Respond to GAC Advice** | 1570d | 2020-07-01 A | 2026-06-30 |  |  |  |
| 499 | **ICANN69** | 97d | 2020-07-01 A | 2020-11-12 |  |  |  |
| 500 | Meeting Planning | 75d | 2020-07-01 A | 2020-10-13 A |  |  | Council Leads; Policy Staff |
| 501 | ICANN Meeting | 5d | 2020-10-17 A | 2020-10-22 A | 500 |  | Board; Contracted Parties; Council; Council Leads; EC Admin; EC Rep; Finance Staff; GDS Staff; IRT; Legal Staff; Policy Staff; SSC; Working Group |
| 502 | Respond to GAC Advice | 15d | 2020-10-23 | 2020-11-12 | 501 |  | Council; Policy Staff |
| 503 | **ICANN70** | 99d | 2020-12-01 | 2021-04-15 |  |  |  |
| 504 | Meeting Planning | 75d | 2020-12-01 | 2021-03-15 |  | start no earlier than 2020-12-01 | Council Leads; Policy Staff |
| 505 | ICANN Meeting | 5d | 2021-03-20 | 2021-03-25 | 504 | start no earlier than 2021-03-20 | Board; Contracted Parties; Council; Council Leads; EC Admin; EC Rep; Finance Staff; GDS Staff; IRT; Legal Staff; Policy Staff; SSC; Working Group |
| 506 | Respond to GAC Advice | 15d | 2021-03-26 | 2021-04-15 | 505 |  | Council; Policy Staff |
| 507 | **ICANN71** | 70d | 2021-04-01 | 2021-07-07 |  |  |  |
| 508 | Meeting Planning | 50d | 2021-04-01 | 2021-06-09 |  | start no earlier than 2021-04-01 | Council Leads; Policy Staff |
| 509 | ICANN Meeting | 5d | 2021-06-10 | 2021-06-16 | 508 | start no earlier than 2021-03-20 | Board; Contracted Parties; Council; Council Leads; EC Admin; EC Rep; Finance Staff; GDS Staff; IRT; Legal Staff; Policy Staff; SSC; Working Group |
| 510 | Respond to GAC Advice | 15d | 2021-06-17 | 2021-07-07 | 509 |  | Council; Policy Staff |
| 511 | **ICANN72** | 102d | 2021-07-01 | 2021-11-18 |  |  |  |
| 512 | Meeting Planning | 75d | 2021-07-01 | 2021-10-13 |  | start no earlier than 2021-07-01 | Council Leads; Policy Staff |
| 513 | ICANN Meeting | 5d | 2021-10-23 | 2021-10-28 | 512 | start no earlier than 2021-10-23 | Board; Contracted Parties; Council; Council Leads; EC Admin; EC Rep; Finance Staff; GDS Staff; IRT; Legal Staff; Policy Staff; SSC; Working Group |
| 514 | Respond to GAC Advice | 15d | 2021-10-29 | 2021-11-18 | 513 |  | Council; Policy Staff |
| 515 | **ICANN73** | 95d | 2021-12-01 | 2022-04-12 |  |  |  |
| 516 | Meeting Planning | 75d | 2021-12-01 | 2022-03-15 |  | start no earlier than 2021-12-01 | Council Leads; Policy Staff |
| 517 | ICANN Meeting | 5d | 2022-03-16 | 2022-03-22 | 516 | start no earlier than 2021-06-14 | Board; Contracted Parties; Council; Council Leads; EC Admin; EC Rep; Finance Staff; GDS Staff; IRT; Legal Staff; Policy Staff; SSC; Working Group |
| 518 | Respond to GAC Advice | 15d | 2022-03-23 | 2022-04-12 | 517 |  | Council; Policy Staff |
| 519 | **ICANN74** | 70d | 2022-04-01 | 2022-07-07 |  |  |  |
| 520 | Meeting Planning | 50d | 2022-04-01 | 2022-06-09 |  | start no earlier than 2022-04-01 | Council Leads; Policy Staff |
| 521 | ICANN Meeting | 5d | 2022-06-10 | 2022-06-16 | 520 | start no earlier than 2021-03-20 | Board; Contracted Parties; Council; Council Leads; EC Admin; EC Rep; Finance Staff; GDS Staff; IRT; Legal Staff; Policy Staff; SSC; Working Group |
| 522 | Respond to GAC Advice | 15d | 2022-06-17 | 2022-07-07 | 521 |  | Council; Policy Staff |
| 523 | **ICANN75** | 95d | 2022-06-01 | 2022-10-11 |  |  |  |
| 524 | Meeting Planning | 75d | 2022-06-01 | 2022-09-13 |  | start no earlier than 2022-06-01 | Council Leads; Policy Staff |
| 525 | ICANN Meeting | 5d | 2022-09-14 | 2022-09-20 | 524 | start no earlier than 2021-10-23 | Board; Contracted Parties; Council; Council Leads; EC Admin; EC Rep; Finance Staff; GDS Staff; IRT; Legal Staff; Policy Staff; SSC; Working Group |
| 526 | Respond to GAC Advice | 15d | 2022-09-21 | 2022-10-11 | 525 |  | Council; Policy Staff |
| 527 | **ICANN76** | 95d | 2022-12-01 | 2023-04-11 |  |  |  |
| 528 | Meeting Planning | 75d | 2022-12-01 | 2023-03-15 |  | start no earlier than 2022-12-01 | Council Leads; Policy Staff |
| 529 | ICANN Meeting | 5d | 2023-03-16 | 2023-03-22 | 528 | start no earlier than 2021-06-14 | Board; Contracted Parties; Council; Council Leads; EC Admin; EC Rep; Finance Staff; GDS Staff; IRT; Legal Staff; Policy Staff; SSC; Working Group |
| 530 | Respond to GAC Advice | 15d | 2023-03-23 | 2023-04-11 | 529 |  | Council; Policy Staff |
| 531 | **ICANN77** | 70d | 2023-04-01 | 2023-07-05 |  |  |  |
| 532 | Meeting Planning | 50d | 2023-04-01 | 2023-06-08 |  | start no earlier than 2023-04-01 | Council Leads; Policy Staff |
| 533 | ICANN Meeting | 5d | 2023-06-09 | 2023-06-15 | 532 | start no earlier than 2021-03-20 | Board; Contracted Parties; Council; Council Leads; EC Admin; EC Rep; Finance Staff; GDS Staff; IRT; Legal Staff; Policy Staff; SSC; Working Group |
| 534 | Respond to GAC Advice | 15d | 2023-06-16 | 2023-07-05 | 533 |  | Council; Policy Staff |
| 535 | **ICANN78** | 95d | 2023-07-01 | 2023-11-09 |  |  |  |
| 536 | Meeting Planning | 75d | 2023-07-01 | 2023-10-12 |  | start no earlier than 2023-07-01 | Council Leads; Policy Staff |
| 537 | ICANN Meeting | 5d | 2023-10-13 | 2023-10-19 | 536 | start no earlier than 2021-10-23 | Board; Contracted Parties; Council; Council Leads; EC Admin; EC Rep; Finance Staff; GDS Staff; IRT; Legal Staff; Policy Staff; SSC; Working Group |
| 538 | Respond to GAC Advice | 15d | 2023-10-20 | 2023-11-09 | 537 |  | Council; Policy Staff |
| 539 | **ICANN79** | 95d | 2023-12-01 | 2024-04-11 |  |  |  |
| 540 | Meeting Planning | 75d | 2023-12-01 | 2024-03-14 |  | start no earlier than 2023-12-01 | Council Leads; Policy Staff |
| 541 | ICANN Meeting | 5d | 2024-03-15 | 2024-03-21 | 540 | start no earlier than 2021-06-14 | Board; Contracted Parties; Council; Council Leads; EC Admin; EC Rep; Finance Staff; GDS Staff; IRT; Legal Staff; Policy Staff; SSC; Working Group |
| 542 | Respond to GAC Advice | 15d | 2024-03-22 | 2024-04-11 | 541 |  | Council; Policy Staff |
| 543 | **ICANN80** | 70d | 2024-04-01 | 2024-07-05 |  |  |  |
| 544 | Meeting Planning | 50d | 2024-04-01 | 2024-06-07 |  | start no earlier than 2024-04-01 | Council Leads; Policy Staff |
| 545 | ICANN Meeting | 5d | 2024-06-10 | 2024-06-14 | 544 | start no earlier than 2021-03-20 | Board; Contracted Parties; Council; Council Leads; EC Admin; EC Rep; Finance Staff; GDS Staff; IRT; Legal Staff; Policy Staff; SSC; Working Group |
| 546 | Respond to GAC Advice | 15d | 2024-06-17 | 2024-07-05 | 545 |  | Council; Policy Staff |
| 547 | **ICANN81** | 95d | 2024-07-01 | 2024-11-08 |  |  |  |
| 548 | Meeting Planning | 75d | 2024-07-01 | 2024-10-11 |  | start no earlier than 2024-07-01 | Council Leads; Policy Staff |
| 549 | ICANN Meeting | 5d | 2024-10-14 | 2024-10-18 | 548 | start no earlier than 2021-10-23 | Board; Contracted Parties; Council; Council Leads; EC Admin; EC Rep; Finance Staff; GDS Staff; IRT; Legal Staff; Policy Staff; SSC; Working Group |
| 550 | Respond to GAC Advice | 15d | 2024-10-21 | 2024-11-08 | 549 |  | Council; Policy Staff |
| 551 | **ICANN82** | 95d | 2024-12-01 | 2025-04-10 |  |  |  |
| 552 | Meeting Planning | 75d | 2024-12-01 | 2025-03-13 |  | start no earlier than 2024-12-01 | Council Leads; Policy Staff |
| 553 | ICANN Meeting | 5d | 2025-03-14 | 2025-03-20 | 552 | start no earlier than 2021-06-14 | Board; Contracted Parties; Council; Council Leads; EC Admin; EC Rep; Finance Staff; GDS Staff; IRT; Legal Staff; Policy Staff; SSC; Working Group |
| 554 | Respond to GAC Advice | 15d | 2025-03-21 | 2025-04-10 | 553 |  | Council; Policy Staff |
| 555 | **ICANN83** | 70d | 2025-04-01 | 2025-07-07 |  |  |  |
| 556 | Meeting Planning | 50d | 2025-04-01 | 2025-06-09 |  | start no earlier than 2025-04-01 | Council Leads; Policy Staff |
| 557 | ICANN Meeting | 5d | 2025-06-10 | 2025-06-16 | 556 | start no earlier than 2021-03-20 | Board; Contracted Parties; Council; Council Leads; EC Admin; EC Rep; Finance Staff; GDS Staff; IRT; Legal Staff; Policy Staff; SSC; Working Group |
| 558 | Respond to GAC Advice | 15d | 2025-06-17 | 2025-07-07 | 557 |  | Council; Policy Staff |
| 559 | **ICANN84** | 95d | 2025-07-01 | 2025-11-10 |  |  |  |
| 560 | Meeting Planning | 75d | 2025-07-01 | 2025-10-13 |  | start no earlier than 2025-07-01 | Council Leads; Policy Staff |
| 561 | ICANN Meeting | 5d | 2025-10-14 | 2025-10-20 | 560 | start no earlier than 2021-10-23 | Board; Contracted Parties; Council; Council Leads; EC Admin; EC Rep; Finance Staff; GDS Staff; IRT; Legal Staff; Policy Staff; SSC; Working Group |
| 562 | Respond to GAC Advice | 15d | 2025-10-21 | 2025-11-10 | 561 |  | Council; Policy Staff |
| 563 | **ICANN85** | 95d | 2025-12-01 | 2026-04-10 |  |  |  |
| 564 | Meeting Planning | 75d | 2025-12-01 | 2026-03-13 |  | start no earlier than 2025-12-01 | Council Leads; Policy Staff |
| 565 | ICANN Meeting | 5d | 2026-03-16 | 2026-03-20 | 564 | start no earlier than 2021-06-14 | Board; Contracted Parties; Council; Council Leads; EC Admin; EC Rep; Finance Staff; GDS Staff; IRT; Legal Staff; Policy Staff; SSC; Working Group |
| 566 | Respond to GAC Advice | 15d | 2026-03-23 | 2026-04-10 | 565 |  | Council; Policy Staff |
| 567 | **ICANN86** | 65d | 2026-04-01 | 2026-06-30 |  |  |  |
| 568 | Meeting Planning | 50d | 2026-04-01 | 2026-06-09 |  | start no earlier than 2026-04-01 | Council Leads; Policy Staff |
| 569 | ICANN Meeting | 5d | 2026-06-10 | 2026-06-16 | 568 | start no earlier than 2021-03-20 | Board; Contracted Parties; Council; Council Leads; EC Admin; EC Rep; Finance Staff; GDS Staff; IRT; Legal Staff; Policy Staff; SSC; Working Group |
| 570 | Respond to GAC Advice | 10d | 2026-06-17 | 2026-06-30 | 569 |  | Council; Policy Staff |

Changed:

| ID | Task | Start | Finish | Duration | Complete | Total float | Predecessors | Other |
| --- | --- | --- | --- | --- | --- | --- | --- | --- |
| 1 | **GNSO Program Management Planning** |  | 2027-01-22 → 2026-06-30 (-206d) | 1713d → 1570d | 12% → 11% |  |  |  |
| 2 | **RDDS - Program Track** |  | 2022-12-23 → 2023-05-09 (+137d) | 648d → 748d |  | 1065d → 822d |  |  |
| 3 | **EPDP: Temporary Specification on gTLD Registration Data - Phase 2** |  | 2022-12-02 → 2022-11-30 (-2d) |  |  | 1080d → 937d |  |  |
| 7 | Engage IRT: Temporary Specification on gTLD Registration Data - Phase 2 |  | 2022-12-02 → 2022-11-30 (-2d) |  |  | 1080d → 937d |  |  |
| 8 | **Remaining EPDP-P2 Topics (Legal vs. Natural, Unique Contacts, + Accuracy )** | 2020-09-28 A | 2022-12-23 → 2023-05-09 (+137d) | 585d → 685d | 0% → 1% | 1065d → 822d |  |  |
| 9 | **Remaining EPDP-P2 Topics Track 1 (Legal vs. Natural + Feasability of Unique Contacts)** | 2020-09-28 A | 2022-03-04 → 2022-04-06 (+33d) | 375d → 400d | 0% → 2% | 1275d → 1107d |  |  |
| 10 | Reset EPDP-P2A and elect new Chair | 2020-09-28 A | 2020-11-13 → 2020-12-18 (+35d) | 35d → 60d | 0% → 10% | 1275d → 1107d |  | was named Reset EPDP-P2 and elect new Chair |
| 11 | Engage EPDP-P2A to address remaining topics | 2020-11-16 → 2020-12-21 (+35d) | 2021-02-19 → 2021-03-25 (+34d) |  |  | 1275d → 1107d |  | was named Engage EPDP-P2 to address remaining topics |
| 12 | Council to deliberate and adopt working group consensus recommendations | 2021-02-22 → 2021-03-26 (+32d) | 2021-04-16 → 2021-05-20 (+34d) |  |  | 1275d → 1107d |  |  |
| 13 | Board to deliberate and adopt consensus recommendations | 2021-04-19 → 2021-05-21 (+32d) | 2021-06-25 → 2021-07-29 (+34d) |  |  | 1275d → 1107d |  |  |
| 14 | Engage IRT | 2021-06-28 → 2021-07-30 (+32d) | 2022-03-04 → 2022-04-06 (+33d) |  |  | 1275d → 1107d |  |  |
| 15 | **Remaining EPDP-P2 Topics Track 2 (Accuracy)** |  | 2022-12-23 → 2023-05-09 (+137d) | 585d → 685d |  | 1065d → 822d |  |  |
| 17 | Deliberate scope and decide to request Issues Report | 2020-09-28 → 2021-02-15 (+140d) | 2020-11-27 → 2021-04-15 (+139d) |  |  | 1065d → 822d | 5 → 16 |  |
| 18 | Issues Report | 2020-11-30 → 2021-04-16 (+137d) | 2021-02-19 → 2021-07-08 (+139d) |  |  | 1065d → 822d |  |  |
| 19 | Council to approve PDP launch | 2021-02-22 → 2021-07-09 (+137d) | 2021-03-19 → 2021-08-05 (+139d) |  |  | 1065d → 822d |  |  |
| 20 | Council to approve scope and charter | 2021-03-22 → 2021-08-06 (+137d) | 2021-05-14 → 2021-09-30 (+139d) |  |  | 1065d → 822d |  |  |
| 21 | Engage RDS Accuracy PDP | 2021-05-17 → 2021-10-01 (+137d) | 2021-12-10 → 2022-04-27 (+138d) |  |  | 1065d → 822d |  |  |
| 22 | Council to deliberate and adopt working group consensus recommendations | 2021-12-13 → 2022-04-28 (+136d) | 2022-02-04 → 2022-06-22 (+138d) |  |  | 1065d → 822d |  |  |
| 23 | Board to deliberate and adopt consensus recommendations | 2022-02-07 → 2022-06-23 (+136d) | 2022-04-15 → 2022-08-31 (+138d) |  |  | 1065d → 822d |  |  |
| 24 | Engage IRT | 2022-04-18 → 2022-09-01 (+136d) | 2022-12-23 → 2023-05-09 (+137d) |  |  | 1065d → 822d |  |  |
| 25 | **RDS2 Review Items** |  | 2022-02-07 → 2022-06-23 (+136d) | 403d → 503d |  | 1294d → 1051d |  |  |
| 26 | **RDS2 Review - Recommendation CC.1 (suspension of domain due to incorrect RDS)** |  | 2022-02-07 → 2022-06-23 (+136d) | 403d → 503d |  | 1294d → 1051d |  |  |
| 28 | Determine if CC.1 can be coupled with Remaining EPDP-P2 Topics (Accuracy) | 2021-02-22 → 2021-07-09 (+137d) | 2021-02-22 → 2021-07-09 (+137d) |  |  | 1544d → 1301d |  |  |
| 29 | CC.1 Implemented | 2022-02-07 → 2022-06-23 (+136d) | 2022-02-07 → 2022-06-23 (+136d) |  |  | 1294d → 1051d |  |  |
| 33 | **IRT: Temporary Specification on gTLD Registration Data - Phase 1** |  | 2022-08-02 → 2022-08-01 (-1d) | 545d → 546d |  | 1168d → 1024d |  |  |
| 34 | Engage IRT: Temporary Specification on gTLD Registration Data - Phase 1 |  | 2022-08-02 → 2022-08-01 (-1d) |  |  | 1168d → 1024d |  |  |
| 35 | **EPDP-P1 Rec27 Wave 1 Other Policy Impacts** |  |  | 310d → 311d |  | 1403d → 1259d |  |  |
| 121 | **Revised ICANN Procedure for Handling Whois Conflicts with Privacy Law** |  | 2022-10-13 → 2022-10-11 (-2d) |  | 8% → 10% | 1116d → 973d |  |  |
| 122 | Council small scoping team to determine next steps and Council consideration |  | 2020-10-22 A |  | 75% → 100% |  |  |  |
| 125 | IF required, review WPIAG Charter to determine if it's fit for purpose |  | 2021-04-29 → 2021-04-28 (-1d) |  |  | 1116d → 973d |  |  |
| 126 | **IF required, Council to approve charter and launch WPIAG** | 2021-04-30 → 2021-04-29 (-1d) | 2021-09-23 → 2021-09-22 (-1d) |  |  | 1116d → 973d |  |  |
| 127 | Engage WPIAG | 2021-04-30 → 2021-04-29 (-1d) | 2021-07-22 → 2021-07-21 (-1d) |  |  | 1116d → 973d |  |  |
| 128 | Council to deliberate findings and determine appropriate path | 2021-07-23 → 2021-07-22 (-1d) | 2021-09-23 → 2021-09-22 (-1d) |  |  | 1116d → 973d |  |  |
| 129 | **IF required, Council to approve launch of EPDP** | 2021-09-24 → 2021-09-23 (-1d) | 2022-10-13 → 2022-10-11 (-2d) |  |  | 1116d → 973d |  |  |
| 130 | Engage EPDP: Temporary Specification on gTLD Registration Data - Phase 2 | 2021-09-24 → 2021-09-23 (-1d) | 2022-01-27 → 2022-01-25 (-2d) |  |  | 1116d → 973d |  |  |
| 131 | Council to deliberate and adopt working group consensus recommendations | 2022-01-28 → 2022-01-26 (-2d) | 2022-03-31 → 2022-03-29 (-2d) |  |  | 1116d → 973d |  |  |
| 132 | Board to deliberate and adopt consensus recommendations | 2022-04-01 → 2022-03-30 (-2d) | 2022-06-09 → 2022-06-07 (-2d) |  |  | 1116d → 973d |  |  |
| 133 | Engage IRT: Temporary Specification on gTLD Registration Data - Phase 2 | 2022-06-10 → 2022-06-08 (-2d) | 2022-10-13 → 2022-10-11 (-2d) |  |  | 1116d → 973d |  |  |
| 136 | **IRT: Privacy & Proxy Services Accreditation Issues (on-hold pending EPDP)** |  | 2021-10-08 → 2021-10-07 (-1d) |  |  | 1380d → 1237d |  |  |
| 137 | Engage IRT: Privacy & Proxy Services Accreditation Issues |  | 2021-10-08 → 2021-10-07 (-1d) |  |  | 1380d → 1237d |  |  |
| 138 | **IRT: Translation/Transliteration of gTLD Registration Data (on-hold pending EPDP + RDAP)** |  | 2021-10-08 → 2021-10-07 (-1d) |  |  | 1380d → 1237d |  |  |
| 139 | Engage IRT: Translation/Transliteration of gTLD Registration Data |  | 2021-10-08 → 2021-10-07 (-1d) |  |  | 1380d → 1237d |  |  |
| 140 | **RPM - Program Track** |  | 2024-11-19 → 2024-11-13 (-6d) |  |  | 568d → 425d |  |  |
| 141 | **PDP: Review of All Rights Protection Mechanisms in All gTLDs - Phase 1 (URS, TMCH, Sunrise, Claims)** |  | 2022-05-17 → 2022-05-13 (-4d) |  |  | 1223d → 1080d |  |  |
| 149 | Board to deliberate and adopt consensus recommendations |  | 2021-05-04 → 2021-05-03 (-1d) |  |  | 33.75d → 34.75d |  |  |
| 150 | Engage IRT | 2021-05-05 → 2021-05-04 (-1d) | 2022-05-17 → 2022-05-13 (-4d) |  |  | 1223d → 1080d |  |  |
| 151 | **PDP: Review of All Rights Protection Mechanisms in All gTLDs - Phase 2 (UDRP)** |  | 2024-11-19 → 2024-11-13 (-6d) |  |  | 568d → 425d |  |  |
| 152 | Drafting Team to draft new charter (incl. Items 2 through 11 of Rec27 Wave1) |  | 2021-06-15 → 2021-06-14 (-1d) |  |  | 568d → 425d |  |  |
| 153 | Engage Phase 2 working group | 2021-06-16 → 2021-06-15 (-1d) | 2023-06-20 → 2023-06-15 (-5d) |  |  | 568d → 425d |  |  |
| 154 | Council to deliberate and adopt working group consensus recommendations | 2023-06-21 → 2023-06-16 (-5d) | 2023-08-15 → 2023-08-09 (-6d) |  |  | 568d → 425d |  |  |
| 155 | Board to deliberate and adopt consensus recommendations | 2023-08-16 → 2023-08-10 (-6d) | 2023-11-07 → 2023-11-01 (-6d) |  |  | 568d → 425d |  |  |
| 156 | Engage IRT | 2023-11-08 → 2023-11-02 (-6d) | 2024-11-19 → 2024-11-13 (-6d) |  |  | 568d → 425d |  |  |
| 157 | **gTLD - Program Track** |  | 2023-08-14 → 2023-08-08 (-6d) |  |  | 899d → 756d |  |  |
| 158 | **CCWG: New gTLD Auction Proceeds Drafting Team (group completed 31 May 2020)** |  | 2021-12-17 → 2021-12-15 (-2d) |  |  | 1330d → 1187d |  |  |
| 161 | Implement program |  | 2021-12-17 → 2021-12-15 (-2d) |  |  | 1330d → 1187d |  |  |
| 162 | **PDP: New gTLD Subsequent Procedures PDP** |  | 2023-08-14 → 2023-08-08 (-6d) |  |  | 899d → 756d |  |  |
| 165 | Board to deliberate and adopt consensus recommendations |  | 2021-07-19 → 2021-07-16 (-3d) |  |  | 899d → 756d |  |  |
| 166 | Execute IRT | 2021-07-20 → 2021-07-19 (-1d) | 2023-08-14 → 2023-08-08 (-6d) |  |  | 899d → 756d |  |  |
| 167 | **Internationalized Domain Names** |  | 2023-05-02 → 2023-04-27 (-5d) |  |  | 973d → 830d |  |  |
| 171 | **IDN Policy Track 2 EPDP Working Group** |  | 2023-05-02 → 2023-04-27 (-5d) |  |  |  |  |  |
| 173 | Engage Track 2 EPDP working group |  | 2021-12-28 → 2021-12-24 (-4d) |  |  | 973d → 830d |  |  |
| 174 | Council to deliberate and adopt working group consensus recommendations | 2021-12-29 → 2021-12-27 (-2d) | 2022-02-22 → 2022-02-18 (-4d) |  |  | 973d → 830d |  |  |
| 175 | Board to deliberate and adopt consensus recommendations | 2022-02-23 → 2022-02-21 (-2d) | 2022-05-17 → 2022-05-13 (-4d) |  |  | 973d → 830d |  |  |
| 176 | Engage IRT | 2022-05-18 → 2022-05-16 (-2d) | 2023-05-02 → 2023-04-27 (-5d) |  |  | 973d → 830d |  |  |
| 177 | **IDN Track 3 Council Coordination** |  | 2021-12-07 → 2021-12-03 (-4d) |  |  | 1338d → 1195d |  |  |
| 178 | GNSO Council to coordinate with the CCNSO regarding IDN policy developments |  | 2021-12-07 → 2021-12-03 (-4d) |  |  | 1338d → 1195d |  |  |
| 179 | **Expiration - Program Track** | 2020-10-21 → 2020-11-19 (+29d) | 2022-10-04 → 2022-10-31 (+27d) |  |  |  |  |  |
| 180 | **Expired Domain Deletion Policy (EDDP) / Expired Registration Recovery Policy (ERRP) Review** | 2020-10-21 → 2020-11-19 (+29d) | 2022-10-04 → 2022-10-31 (+27d) |  |  |  |  |  |
| 181 | Council to extend PSR for 18 months or when bandwidth becomes available | 2020-10-21 → 2020-11-19 (+29d) | 2022-03-29 → 2022-04-25 (+27d) |  |  |  |  |  |
| 182 | Develop Policy Status Report (incl. Rec27 Wave1 EDDP Item 2 + ERRP Item3) | 2022-03-30 → 2022-04-26 (+27d) | 2022-08-02 → 2022-08-29 (+27d) |  |  | none → 959d |  |  |

| ID | Task | Start | Finish | Duration | Complete | Total float | Other |
| --- | --- | --- | --- | --- | --- | --- | --- |
| 183 | Council to deliberate findings | 2022-08-03 → 2022-08-30 (+27d) | 2022-10-04 → 2022-10-31 (+27d) |  |  | 1123d → 959d |  |
| 184 | **Transfers - Program Track** |  | 2024-09-10 → 2024-09-04 (-6d) |  |  | 618d → 475d |  |
| 185 | **Transfer Policy Review** |  | 2024-09-10 → 2024-09-04 (-6d) |  |  | 618d → 475d |  |
| 191 | Engage Transfer Policy Review PDP |  | 2023-04-11 → 2023-04-06 (-5d) |  |  | 618d → 475d |  |
| 192 | Council to deliberate and adopt working group consensus recommendations | 2023-04-12 → 2023-04-07 (-5d) | 2023-06-06 → 2023-06-01 (-5d) |  |  | 618d → 475d |  |
| 193 | Board to deliberate and adopt consensus recommendations | 2023-06-07 → 2023-06-02 (-5d) | 2023-08-29 → 2023-08-23 (-6d) |  |  | 618d → 475d |  |
| 194 | Engage IRT | 2023-08-30 → 2023-08-24 (-6d) | 2024-09-10 → 2024-09-04 (-6d) |  |  | 618d → 475d |  |
| 195 | **IGO - Program Track** |  | 2023-05-12 → 2023-05-09 (-3d) |  |  | 965d → 822d |  |
| 196 | **PDP: RPM - IGO Curative Rights Work Track** |  | 2023-05-12 → 2023-05-09 (-3d) |  |  | 965d → 822d |  |
| 199 | Engage IGO-CRPM Work Track Policy Review PDP |  | 2021-12-10 → 2021-12-08 (-2d) |  |  |  |  |
| 200 | Council to deliberate and adopt working group consensus recommendations | 2021-12-13 → 2021-12-09 (-4d) | 2022-02-04 → 2022-02-02 (-2d) |  |  | 965d → 822d |  |
| 201 | Board to deliberate and adopt consensus recommendations | 2022-02-07 → 2022-02-03 (-4d) | 2022-04-29 → 2022-04-27 (-2d) |  |  | 965d → 822d |  |
| 202 | Engage IRT | 2022-05-02 → 2022-04-28 (-4d) | 2023-05-12 → 2023-05-09 (-3d) |  |  | 965d → 822d |  |
| 203 | **PDP: Curative Rights Protections for IGO/INGOs** | 2022-02-07 → 2022-02-03 (-4d) | 2023-05-12 → 2023-05-09 (-3d) |  |  | 965d → 822d |  |
| 204 | Board to deliberate and adopt consensus recommendations | 2022-02-07 → 2022-02-03 (-4d) | 2022-04-29 → 2022-04-27 (-2d) |  |  | 965d → 822d |  |
| 205 | Engage IRT | 2022-05-02 → 2022-04-28 (-4d) | 2023-05-12 → 2023-05-09 (-3d) |  |  | 965d → 822d |  |
| 206 | **PDP: Protection of International Organization Names in All gTLDs** | 2022-05-02 → 2022-04-28 (-4d) | 2023-05-12 → 2023-05-09 (-3d) |  |  | 965d → 822d |  |
| 207 | Engage IRT | 2022-05-02 → 2022-04-28 (-4d) | 2023-05-12 → 2023-05-09 (-3d) |  |  | 965d → 822d |  |
| 208 | **Accountability - Program Track** |  | 2021-12-14 → 2021-12-10 (-4d) |  |  | 1333d → 1190d |  |
| 209 | **Independent Review Process - Implementation Oversight Team** |  | 2021-06-15 → 2021-06-14 (-1d) |  |  | 1463d → 1320d |  |
| 210 | Engage IoT Oversight Team |  | 2021-06-15 → 2021-06-14 (-1d) |  |  | 1463d → 1320d |  |
| 211 | **Cross Community Working Group on Enhancing ICANN Accountability - WS2** |  | 2021-07-20 → 2021-07-19 (-1d) |  |  | 1438d → 1295d |  |
| 213 | Council to determine what is required of the GNSO |  | 2021-07-20 → 2021-07-19 (-1d) |  |  | 1438d → 1295d |  |
| 214 | **Multistakeholder Model Evolution** |  | 2021-12-14 → 2021-12-10 (-4d) |  |  | 1333d → 1190d |  |
| 215 | Council to determine what is required of the GNSO |  | 2021-12-14 → 2021-12-10 (-4d) |  |  | 1333d → 1190d |  |
| 216 | **Geo Regions Review** |  | 2021-12-14 → 2021-12-10 (-4d) |  |  | 1333d → 1190d |  |
| 217 | Council to determine what is required of the GNSO |  | 2021-12-14 → 2021-12-10 (-4d) |  |  | 1333d → 1190d |  |
| 218 | **Reviews - Program Track** |  | 2027-01-22 → 2026-06-26 (-210d) | 1713d → 1568d |  | 0d → 2d |  |
| 219 | **IANA Naming Function Review** |  | 2021-03-23 → 2021-03-22 (-1d) |  |  | 1523d → 1380d |  |
| 221 | GNSO participation on IFRT2 |  | 2021-03-23 → 2021-03-22 (-1d) |  |  | 1523d → 1380d |  |
| 222 | **GNSO Review RT3** |  | 2023-12-25 → 2023-12-20 (-5d) |  |  |  |  |
| 224 | GNSO participation on GNSO3-RT |  | 2022-07-25 → 2022-07-22 (-3d) |  |  | 804d → 660d |  |
| 225 | Council to deliberate and adopt review team consensus recommendations | 2022-07-26 → 2022-07-25 (-1d) | 2022-09-19 → 2022-09-16 (-3d) |  |  | 804d → 660d |  |
| 226 | Board to deliberate and adopt consensus recommendations | 2022-09-20 → 2022-09-19 (-1d) | 2022-12-12 → 2022-12-09 (-3d) |  |  | 804d → 660d |  |
| 227 | Implement GNSO3 Review recommendations | 2022-12-13 → 2022-12-12 (-1d) | 2023-12-25 → 2023-12-20 (-5d) |  |  | 804d → 660d |  |
| 231 | **Registration Directory Service Review RT3** |  | 2025-10-24 → 2025-10-23 (-1d) |  |  |  |  |
| 233 | GNSO participation on RDS3-RT |  | 2025-10-24 → 2025-10-23 (-1d) |  |  | 325d → 178d |  |
| 234 | **Competition, Consumer Trust and Consumer Choice RT2** |  | 2024-02-26 → 2024-02-22 (-4d) |  |  |  |  |
| 236 | GNSO participation on CCT-RT2 |  | 2024-02-26 → 2024-02-22 (-4d) |  |  | 759d → 614d |  |
| 237 | **Accountability and Transparency Review 3** |  | 2021-06-29 → 2021-06-28 (-1d) |  |  | 1453d → 1310d |  |
| 239 | Council to monitor for ATRT3 implementation assignments should the Board adopt ATRT3 recommendations |  | 2021-06-29 → 2021-06-28 (-1d) |  |  | 1453d → 1310d |  |
| 240 | **Accountability and Transparency Review 4** |  | 2026-07-24 → 2026-06-26 (-28d) | 300d → 280d |  |  |  |
| 242 | GNSO participation on ATRT4 |  | 2026-07-24 → 2026-06-26 (-28d) | 270d → 250d |  | 130d → 2d |  |
| 246 | **Security, Stability and Resiliency of the DNS #3** |  | 2027-01-22 → 2026-06-26 (-210d) | 300d → 150d |  |  |  |
| 248 | GNSO participation on SSR3 |  | 2027-01-22 → 2026-06-26 (-210d) | 270d → 120d |  | 0d → 2d |  |
| 249 | **Operations - Program Track** |  | 2025-11-19 → 2026-06-30 (+223d) | 1406d → 1570d | 17% → 12% | 307d → 0d |  |
| 250 | **Policy & Implementation - Recommendations Review** |  |  | 475d → 477d |  |  |  |
| 255 | **Participant of Empowered Community** |  | 2025-11-19 → 2025-11-12 (-7d) |  |  | 307d → 164d |  |
| 258 | Perform role 2021 |  | 2021-10-27 → 2021-10-25 (-2d) |  |  | 307d → 164d |  |
| 259 | Elect new participant | 2021-10-28 → 2021-10-26 (-2d) | 2021-11-17 → 2021-11-15 (-2d) |  |  | 307d → 164d |  |
| 260 | Perform role 2022 | 2021-11-18 → 2021-11-16 (-2d) | 2022-11-02 → 2022-10-31 (-2d) |  |  | 307d → 164d |  |
| 261 | Elect new participant | 2022-11-03 → 2022-11-01 (-2d) | 2022-11-23 → 2022-11-21 (-2d) |  |  | 307d → 164d |  |
| 262 | Perform role 2023 | 2022-11-24 → 2022-11-22 (-2d) | 2023-11-08 → 2023-11-02 (-6d) |  |  | 307d → 164d |  |
| 263 | Elect new participant | 2023-11-09 → 2023-11-03 (-6d) | 2023-11-29 → 2023-11-23 (-6d) |  |  | 307d → 164d |  |
| 264 | Perform role 2024 | 2023-11-30 → 2023-11-24 (-6d) | 2024-11-13 → 2024-11-07 (-6d) |  |  | 307d → 164d |  |
| 265 | Elect new participant | 2024-11-14 → 2024-11-08 (-6d) | 2024-12-04 → 2024-11-28 (-6d) |  |  | 307d → 164d |  |
| 266 | Perform role 2025 | 2024-12-05 → 2024-11-29 (-6d) | 2025-11-19 → 2025-11-12 (-7d) |  |  | 307d → 164d |  |
| 267 | **GNSO Council** |  | 2021-12-22 → 2026-06-30 (+1651d) | 386d → 1570d | 45% → 16% | 1327d → 0d |  |
| 268 | **GNSO Council - Monthly Meetings** |  | 2021-12-16 → 2026-06-17 (+1644d) | 366d → 1545d | 22% → 6% |  |  |
| 269 | GNSO Council Meeting |  |  |  |  |  | was named GNSO Council Meeting 1 |
| 270 | GNSO Council Meeting |  |  |  |  |  | was named GNSO Council Meeting 2 |
| 271 | GNSO Council Meeting |  |  |  |  |  | was named GNSO Council Meeting 3 |
| 272 | GNSO Council Meeting |  |  |  |  |  | was named GNSO Council Meeting 4 |
| 273 | GNSO Council Meeting |  |  |  |  |  | was named GNSO Council Meeting 5 |
| 274 | GNSO Council Meeting |  |  |  |  |  | was named GNSO Council Meeting 6 |
| 275 | GNSO Council Meeting |  |  |  |  |  | was named GNSO Council Meeting 7 |
| 276 | GNSO Council Meeting |  |  |  |  |  | was named GNSO Council Meeting 8 |
| 277 | GNSO Council Meeting | 2021-03-18 → 2021-03-24 (+6d) | 2021-03-18 → 2021-03-24 (+6d) |  |  |  | was named GNSO Council Meeting 9; constraint start no earlier than 2021-03-18 → start no earlier than 2021-03-24 |
| 278 | GNSO Council Meeting | 2021-04-15 → 2021-04-22 (+7d) | 2021-04-15 → 2021-04-22 (+7d) |  |  |  | was named GNSO Council Meeting 10; constraint start no earlier than 2021-04-15 → start no earlier than 2021-04-22 |
| 279 | GNSO Council Meeting |  |  |  |  |  | was named GNSO Council Meeting 11 |

| ID | Task | Start | Finish | Duration | Complete | Total float | Other |
| --- | --- | --- | --- | --- | --- | --- | --- |
| 280 | GNSO Council Meeting | 2021-06-17 → 2021-06-16 (-1d) | 2021-06-17 → 2021-06-16 (-1d) |  |  |  | was named GNSO Council Meeting 12; constraint start no earlier than 2021-06-17 → start no earlier than 2021-06-16 |
| 281 | GNSO Council Meeting | 2021-07-15 → 2021-07-22 (+7d) | 2021-07-15 → 2021-07-22 (+7d) |  |  |  | was named GNSO Council Meeting 13; constraint start no earlier than 2021-07-15 → start no earlier than 2021-07-22 |
| 282 | GNSO Council Meeting |  |  |  |  |  | was named GNSO Council Meeting 14 |
| 283 | GNSO Council Meeting | 2021-09-16 → 2021-09-23 (+7d) | 2021-09-16 → 2021-09-23 (+7d) |  |  |  | was named GNSO Council Meeting 15; constraint start no earlier than 2021-09-16 → start no earlier than 2021-09-23 |
| 284 | GNSO Council Meeting | 2021-10-21 → 2021-10-27 (+6d) | 2021-10-21 → 2021-10-27 (+6d) |  |  |  | was named GNSO Council Meeting 16; constraint start no earlier than 2021-10-21 → start no earlier than 2021-10-27 |
| 285 | GNSO Council Meeting |  |  |  |  |  | was named GNSO Council Meeting 17 |
| 286 | GNSO Council Meeting |  |  |  |  |  | was named GNSO Council Meeting 18 |
| 341 | **GNSO Council - Leadership Meetings** |  | 2021-12-14 → 2026-06-18 (+1647d) | 372d → 1554d | 22% → 6% |  |  |
| 342 | GNSO Council - Leadership Meetings |  |  |  |  |  | was named GNSO Council - Leadership Meetings 1 |
| 343 | GNSO Council - Leadership Meetings |  |  |  |  |  | was named GNSO Council - Leadership Meetings 2 |
| 344 | GNSO Council - Leadership Meetings |  |  |  |  |  | was named GNSO Council - Leadership Meetings 3 |
| 345 | GNSO Council - Leadership Meetings |  |  |  |  |  | was named GNSO Council - Leadership Meetings 4 |
| 346 | GNSO Council - Leadership Meetings |  |  |  |  |  | was named GNSO Council - Leadership Meetings 5 |
| 347 | GNSO Council - Leadership Meetings |  |  |  |  |  | was named GNSO Council - Leadership Meetings 6 |
| 348 | GNSO Council - Leadership Meetings |  |  |  |  |  | was named GNSO Council - Leadership Meetings 7 |
| 349 | GNSO Council - Leadership Meetings |  |  |  |  |  | was named GNSO Council - Leadership Meetings 8 |
| 350 | GNSO Council - Leadership Meetings |  |  |  |  |  | was named GNSO Council - Leadership Meetings 9 |
| 351 | GNSO Council - Leadership Meetings |  |  |  |  |  | was named GNSO Council - Leadership Meetings 10 |
| 352 | GNSO Council - Leadership Meetings |  |  |  |  |  | was named GNSO Council - Leadership Meetings 11 |
| 353 | GNSO Council - Leadership Meetings |  |  |  |  |  | was named GNSO Council - Leadership Meetings 12 |
| 354 | GNSO Council - Leadership Meetings |  |  |  |  |  | was named GNSO Council - Leadership Meetings 13 |
| 355 | GNSO Council - Leadership Meetings |  |  |  |  |  | was named GNSO Council - Leadership Meetings 14 |
| 356 | GNSO Council - Leadership Meetings |  |  |  |  |  | was named GNSO Council - Leadership Meetings 15 |
| 357 | GNSO Council - Leadership Meetings |  |  |  |  |  | was named GNSO Council - Leadership Meetings 16 |
| 358 | GNSO Council - Leadership Meetings |  |  |  |  |  | was named GNSO Council - Leadership Meetings 17 |
| 359 | GNSO Council - Leadership Meetings |  |  |  |  |  | was named GNSO Council - Leadership Meetings 18 |
| 414 | **GNSO Council - Action Items** |  | 2021-12-13 → 2026-06-17 (+1647d) | 371d → 1553d | 22% → 6% |  |  |
| 415 | GNSO Council - Action Items |  |  |  |  |  | was named GNSO Council - Action Items 1 |
| 416 | GNSO Council - Action Items |  |  |  |  |  | was named GNSO Council - Action Items 2 |
| 417 | GNSO Council - Action Items |  |  |  |  |  | was named GNSO Council - Action Items 3 |
| 418 | GNSO Council - Action Items |  |  |  |  |  | was named GNSO Council - Action Items 4 |
| 419 | GNSO Council - Action Items |  |  |  |  |  | was named GNSO Council - Action Items 5 |
| 420 | GNSO Council - Action Items |  |  |  |  |  | was named GNSO Council - Action Items 6 |
| 421 | GNSO Council - Action Items |  |  |  |  |  | was named GNSO Council - Action Items 7 |
| 422 | GNSO Council - Action Items |  |  |  |  |  | was named GNSO Council - Action Items 8 |
| 423 | GNSO Council - Action Items |  |  |  |  |  | was named GNSO Council - Action Items 9 |
| 424 | GNSO Council - Action Items |  |  |  |  |  | was named GNSO Council - Action Items 10 |
| 425 | GNSO Council - Action Items |  |  |  |  |  | was named GNSO Council - Action Items 11 |
| 426 | GNSO Council - Action Items |  |  |  |  |  | was named GNSO Council - Action Items 12 |
| 427 | GNSO Council - Action Items |  |  |  |  |  | was named GNSO Council - Action Items 13 |
| 428 | GNSO Council - Action Items |  |  |  |  |  | was named GNSO Council - Action Items 14 |
| 429 | GNSO Council - Action Items |  |  |  |  |  | was named GNSO Council - Action Items 15 |
| 430 | GNSO Council - Action Items |  |  |  |  |  | was named GNSO Council - Action Items 16 |
| 431 | GNSO Council - Action Items |  |  |  |  |  | was named GNSO Council - Action Items 17 |
| 432 | GNSO Council - Action Items |  |  |  |  |  | was named GNSO Council - Action Items 18 |
| 487 | **GNSO Standing Committee on Budget and Operations** |  | 2021-03-26 → 2021-03-25 (-1d) |  |  |  |  |
| 490 | Complete draft of comments for Council consideration and submit |  | 2021-03-26 → 2021-03-25 (-1d) |  |  | 1520d → 1377d |  |
| 491 | **GNSO Standing Selection Committee** |  | 2021-12-22 → 2021-12-21 (-1d) | 386d → 387d |  |  |  |
| 492 | SSC fill positions as assigned |  | 2021-12-22 → 2021-12-21 (-1d) |  |  |  |  |

## Version 6 (saved 2020-11-26, file GNSO_Council_Program_Management_Tool_20201217.mpp)

Last finish stays 2026-06-30. Complete tasks 34 → 61.

Added:

| ID | Task | Duration | Start | Finish | Predecessors | Constraint | Resources |
| --- | --- | --- | --- | --- | --- | --- | --- |
| 17 | Council to form Accuracy Scoping Team | 60d | 2021-03-26 | 2021-06-17 | 16 |  | Council; Policy Staff |
| 136 | Council to consider Wave 1.5 report and determine next steps | 90d | 2020-12-17 | 2021-04-20 |  |  | GDS Staff; Council; Policy Staff |
| 490 | **2020-2021** | 75d | 2020-11-02 A | 2021-02-12 |  |  |  |
| 494 | **2021-2022** | 75d | 2021-11-01 | 2022-02-11 |  |  |  |
| 495 | Refresh roster and confirm Chair | 15d | 2021-11-01 | 2021-11-19 |  |  | Policy Staff; Council |
| 496 | Evaluate fiscal year budget and planning documents | 50d | 2021-11-22 | 2022-01-28 | 495 |  | Council; Policy Staff |
| 497 | Complete draft of comments for Council consideration and submit | 10d | 2022-01-31 | 2022-02-11 | 496 |  | Council; Policy Staff |
| 498 | **2022-2023** | 75d | 2022-11-01 | 2023-02-13 |  |  |  |
| 499 | Refresh roster and confirm Chair | 15d | 2022-11-01 | 2022-11-21 |  |  | Policy Staff; Council |
| 500 | Evaluate fiscal year budget and planning documents | 50d | 2022-11-22 | 2023-01-30 | 499 |  | Council; Policy Staff |
| 501 | Complete draft of comments for Council consideration and submit | 10d | 2023-01-31 | 2023-02-13 | 500 |  | Council; Policy Staff |
| 502 | **2023-2024** | 75d | 2023-11-01 | 2024-02-13 |  |  |  |
| 503 | Refresh roster and confirm Chair | 15d | 2023-11-01 | 2023-11-21 |  |  | Policy Staff; Council |
| 504 | Evaluate fiscal year budget and planning documents | 50d | 2023-11-22 | 2024-01-30 | 503 |  | Council; Policy Staff |
| 505 | Complete draft of comments for Council consideration and submit | 10d | 2024-01-31 | 2024-02-13 | 504 |  | Council; Policy Staff |
| 506 | **2024-2025** | 75d | 2024-11-01 | 2025-02-12 |  |  |  |
| 507 | Refresh roster and confirm Chair | 15d | 2024-11-01 | 2024-11-21 |  |  | Policy Staff; Council |
| 508 | Evaluate fiscal year budget and planning documents | 50d | 2024-11-22 | 2025-01-29 | 507 |  | Council; Policy Staff |
| 509 | Complete draft of comments for Council consideration and submit | 10d | 2025-01-30 | 2025-02-12 | 508 |  | Council; Policy Staff |
| 513 | **2020-2021** | 52d | 2020-10-01 A | 2020-12-11 |  |  |  |
| 518 | **2021-2022** | 92d | 2021-10-01 | 2022-02-04 |  |  |  |
| 519 | Establish and manage travel arrangements | 75d | 2021-10-01 | 2022-01-12 |  |  | Council Leads; Policy Staff |
| 520 | Develop plan, topics, and materials for deliberation | 65d | 2021-10-01 | 2021-12-29 |  |  | Council Leads; Policy Staff |
| 521 | Conduct planning session | 5d | 2022-01-10 | 2022-01-14 | 520 | start no earlier than 2022-01-10 | Council; Policy Staff |
| 522 | Develop post planning session report | 15d | 2022-01-17 | 2022-02-04 | 521 |  | Council Leads; Policy Staff |
| 523 | **2022-2023** | 90d | 2022-10-01 | 2023-02-03 |  |  |  |
| 524 | Establish and manage travel arrangements | 75d | 2022-10-01 | 2023-01-12 |  |  | Council Leads; Policy Staff |
| 525 | Develop plan, topics, and materials for deliberation | 65d | 2022-10-01 | 2022-12-29 |  |  | Council Leads; Policy Staff |
| 526 | Conduct planning session | 5d | 2023-01-09 | 2023-01-13 | 525 | start no earlier than 2023-01-09 | Council; Policy Staff |
| 527 | Develop post planning session report | 15d | 2023-01-16 | 2023-02-03 | 526 |  | Council Leads; Policy Staff |
| 528 | **2023-2024** | 95d | 2023-10-01 | 2024-02-09 |  |  |  |
| 529 | Establish and manage travel arrangements | 75d | 2023-10-01 | 2024-01-11 |  |  | Council Leads; Policy Staff |
| 530 | Develop plan, topics, and materials for deliberation | 65d | 2023-10-01 | 2023-12-28 |  |  | Council Leads; Policy Staff |
| 531 | Conduct planning session | 5d | 2024-01-15 | 2024-01-19 | 530 | start no earlier than 2024-01-15 | Council; Policy Staff |
| 532 | Develop post planning session report | 15d | 2024-01-22 | 2024-02-09 | 531 |  | Council Leads; Policy Staff |
| 533 | **2024-2025** | 95d | 2024-10-01 | 2025-02-07 |  |  |  |
| 534 | Establish and manage travel arrangements | 75d | 2024-10-01 | 2025-01-10 |  |  | Council Leads; Policy Staff |
| 535 | Develop plan, topics, and materials for deliberation | 65d | 2024-10-01 | 2024-12-27 |  |  | Council Leads; Policy Staff |
| 536 | Conduct planning session | 5d | 2025-01-13 | 2025-01-17 | 535 | start no earlier than 2025-01-13 | Council; Policy Staff |
| 537 | Develop post planning session report | 15d | 2025-01-20 | 2025-02-07 | 536 |  | Council Leads; Policy Staff |

Changed:

| ID | Task | Start | Finish | Duration | Complete | Total float | Predecessors | Other |
| --- | --- | --- | --- | --- | --- | --- | --- | --- |
| 1 | **GNSO Program Management Planning** |  |  |  | 11% → 12% |  |  |  |
| 2 | **RDDS - Program Track** |  | 2023-05-09 → 2023-08-21 (+104d) | 748d → 823d | 16% → 19% | 822d → 747d |  |  |
| 3 | **EPDP: Temporary Specification on gTLD Registration Data - Phase 2** |  | 2022-11-30 → 2023-04-18 (+139d) | 633d → 733d | 10% → 9% | 937d → 837d |  |  |
| 6 | Board to deliberate and adopt consensus recommendations |  | 2020-12-04 → 2021-04-22 (+139d) | 50d → 150d |  | 937d → 837d |  |  |
| 7 | Engage IRT: Temporary Specification on gTLD Registration Data - Phase 2 | 2020-12-07 → 2021-04-23 (+137d) | 2022-11-30 → 2023-04-18 (+139d) |  |  | 937d → 837d |  |  |
| 8 | **Remaining EPDP-P2 Topics (Legal vs. Natural, Unique Contacts, + Accuracy )** |  | 2023-05-09 → 2023-08-21 (+104d) | 685d → 760d | 1% → 5% | 822d → 747d |  |  |
| 9 | **Remaining EPDP-P2 Topics Track 1 (Legal vs. Natural + Feasability of Unique Contacts)** |  | 2022-04-06 → 2022-07-18 (+103d) | 400d → 473d | 2% → 13% | 1107d → 1034d |  |  |
| 10 | Reset EPDP-P2A and elect new Chair |  | 2020-12-18 → 2020-12-16 A (-2d) | 60d → 58d | 10% → 100% | 1107d → none |  |  |
| 11 | Engage EPDP-P2A to address remaining topics | 2020-12-21 → 2020-12-17 A (-4d) | 2021-03-25 → 2021-06-29 (+96d) | 70d → 140d | 0% → 3% | 1107d → 1034d |  |  |
| 12 | Council to deliberate and adopt working group consensus recommendations | 2021-03-26 → 2021-06-30 (+96d) | 2021-05-20 → 2021-08-31 (+103d) | 40d → 45d |  | 1107d → 1034d |  |  |
| 13 | Board to deliberate and adopt consensus recommendations | 2021-05-21 → 2021-09-01 (+103d) | 2021-07-29 → 2021-11-08 (+102d) |  |  | 1107d → 1034d |  |  |
| 14 | Engage IRT | 2021-07-30 → 2021-11-09 (+102d) | 2022-04-06 → 2022-07-18 (+103d) |  |  | 1107d → 1034d |  |  |
| 15 | **Remaining EPDP-P2 Topics Track 2 (Accuracy)** |  | 2023-05-09 → 2023-08-21 (+104d) | 685d → 760d |  | 822d → 747d |  |  |
| 16 | Staff to produce Briefing Document on Accuracy |  | 2021-02-12 → 2021-03-25 (+41d) | 100d → 130d |  | 822d → 747d |  | resources none → GDS Staff |
| 18 | Deliberate scope and decide to request Issues Report | 2021-02-15 → 2021-06-18 (+123d) | 2021-04-15 → 2021-07-29 (+105d) | 45d → 30d |  | 822d → 747d | 16 → 16, 17 |  |
| 19 | Issues Report | 2021-04-16 → 2021-07-30 (+105d) | 2021-07-08 → 2021-10-21 (+105d) |  |  | 822d → 747d |  |  |
| 20 | Council to approve PDP launch | 2021-07-09 → 2021-10-22 (+105d) | 2021-08-05 → 2021-11-17 (+104d) |  |  | 822d → 747d |  |  |
| 21 | Council to approve scope and charter | 2021-08-06 → 2021-11-18 (+104d) | 2021-09-30 → 2022-01-12 (+104d) |  |  | 822d → 747d |  |  |
| 22 | Engage RDS Accuracy PDP | 2021-10-01 → 2022-01-13 (+104d) | 2022-04-27 → 2022-08-10 (+105d) |  |  | 822d → 747d |  |  |
| 23 | Council to deliberate and adopt working group consensus recommendations | 2022-04-28 → 2022-08-11 (+105d) | 2022-06-22 → 2022-10-05 (+105d) |  |  | 822d → 747d |  |  |
| 24 | Board to deliberate and adopt consensus recommendations | 2022-06-23 → 2022-10-06 (+105d) | 2022-08-31 → 2022-12-14 (+105d) |  |  | 822d → 747d |  |  |
| 25 | Engage IRT | 2022-09-01 → 2022-12-15 (+105d) | 2023-05-09 → 2023-08-21 (+104d) |  |  | 822d → 747d |  |  |
| 26 | **RDS2 Review Items** |  | 2022-06-23 → 2022-10-06 (+105d) | 503d → 578d |  | 1051d → 976d |  |  |
| 27 | **RDS2 Review - Recommendation CC.1 (suspension of domain due to incorrect RDS)** |  | 2022-06-23 → 2022-10-06 (+105d) | 503d → 578d |  | 1051d → 976d |  |  |
| 29 | Determine if CC.1 can be coupled with Remaining EPDP-P2 Topics (Accuracy) | 2021-07-09 → 2021-10-22 (+105d) | 2021-07-09 → 2021-10-22 (+105d) |  |  | 1301d → 1226d |  |  |
| 30 | CC.1 Implemented | 2022-06-23 → 2022-10-06 (+105d) | 2022-06-23 → 2022-10-06 (+105d) |  |  | 1051d → 976d |  |  |
| 34 | **IRT: Temporary Specification on gTLD Registration Data - Phase 1** |  |  |  | 32% → 37% |  |  |  |
| 35 | Engage IRT: Temporary Specification on gTLD Registration Data - Phase 1 |  |  |  | 40% → 55% |  |  |  |
| 36 | **EPDP-P1 Rec27 Wave 1 Other Policy Impacts** |  | 2021-09-07 → 2021-10-22 (+45d) | 311d → 344d | 29% → 31% | 1259d → 1226d |  |  |
| 39 | **Additional Whois Information Policy (AWIP) [LOW]** |  | 2021-01-07 → 2021-02-04 (+28d) | 90d → 110d | 38% → 41% | 1433d → 1413d |  |  |
| 40 | Produce redlines of consensus policy provisions (assumes step 2 accomplished here) |  | 2020-11-05 A |  | 75% → 100% |  |  |  |
| 41 | Review and confirm redlines for final changes |  | 2020-11-19 → 2020-12-17 (+28d) | 10d → 30d |  | 1433d → 1413d |  |  |
| 42 | Conduct public comment of changes | 2020-11-20 → 2020-12-18 (+28d) | 2020-12-31 → 2021-01-28 (+28d) |  |  | 1433d → 1413d |  |  |
| 43 | Post updated consensus policy | 2021-01-01 → 2021-01-29 (+28d) | 2021-01-07 → 2021-02-04 (+28d) |  |  | 1433d → 1413d |  |  |
| 44 | **Expired Domain Deletion Policy (EDDP) [MEDIUM]** |  | 2021-01-07 → 2021-02-18 (+42d) | 90d → 120d |  | 1433d → 1403d |  |  |
| 45 | Produce redlines of consensus policy provisions |  | 2020-11-05 A |  | 75% → 100% |  |  |  |
| 46 | Review and confirm redlines for final changes |  | 2020-11-19 → 2020-12-31 (+42d) | 10d → 40d |  | 1433d → 1403d |  |  |
| 47 | Conduct public comment of changes | 2020-11-20 → 2021-01-01 (+42d) | 2020-12-31 → 2021-02-11 (+42d) |  |  | 1433d → 1403d |  |  |
| 48 | Post updated consensus policy | 2021-01-01 → 2021-02-12 (+42d) | 2021-01-07 → 2021-02-18 (+42d) |  |  | 1433d → 1403d |  |  |
| 49 | **Expired Registration Recovery Policy (ERRP) [LOW]** |  | 2021-01-07 → 2021-02-18 (+42d) | 90d → 120d |  | 1433d → 1403d |  |  |
| 50 | Produce redlines of consensus policy provisions |  | 2020-11-05 A |  | 75% → 100% |  |  |  |
| 51 | Review and confirm redlines for final changes |  | 2020-11-19 → 2020-12-31 (+42d) | 10d → 40d |  | 1433d → 1403d |  |  |
| 52 | Conduct public comment of changes | 2020-11-20 → 2021-01-01 (+42d) | 2020-12-31 → 2021-02-11 (+42d) |  |  | 1433d → 1403d |  |  |
| 53 | Post updated consensus policy | 2021-01-01 → 2021-02-12 (+42d) | 2021-01-07 → 2021-02-18 (+42d) |  |  | 1433d → 1403d |  |  |
| 64 | **Restored Names Accuracy Policy (RNAP) [LOW]** |  | 2021-02-22 → 2021-10-22 (+242d) | 122d → 297d |  | 1401d → 1226d |  |  |
| 65 | **Track 1 - Item 1** |  | 2021-01-07 → 2021-02-18 (+42d) | 90d → 120d |  | 1433d → 1403d |  |  |
| 66 | Produce redlines of consensus policy provisions |  | 2020-11-05 A |  | 75% → 100% |  |  |  |
| 67 | Review and confirm redlines for final changes |  | 2020-11-19 → 2020-12-31 (+42d) | 10d → 40d |  | 1433d → 1403d |  |  |
| 68 | Conduct public comment of changes | 2020-11-20 → 2021-01-01 (+42d) | 2020-12-31 → 2021-02-11 (+42d) |  |  | 1433d → 1403d |  |  |
| 69 | Post updated consensus policy | 2021-01-01 → 2021-02-12 (+42d) | 2021-01-07 → 2021-02-18 (+42d) |  |  | 1433d → 1403d |  |  |
| 70 | **Track 2 - Item 2** | 2021-02-22 → 2021-10-22 (+242d) | 2021-02-22 → 2021-10-22 (+242d) |  |  |  |  |  |
| 71 | Migrated to Remaining EPDP-P2 Topics Track 2 (Accuracy) | 2021-02-22 → 2021-10-22 (+242d) | 2021-02-22 → 2021-10-22 (+242d) |  |  |  |  |  |
| 72 | **Revised ICANN Procedure for Handling Whois Conflicts with Privacy Law [LOW]** |  | 2021-01-07 → 2021-02-18 (+42d) | 90d → 120d |  | 1433d → 1403d |  |  |
| 73 | **Track 1 - Items 1 to 3** |  | 2021-01-07 → 2021-02-18 (+42d) | 90d → 120d |  | 1433d → 1403d |  |  |
| 74 | Produce redlines of consensus policy provisions |  | 2020-11-05 A |  | 75% → 100% |  |  |  |
| 75 | Review and confirm redlines for final changes |  | 2020-11-19 → 2020-12-31 (+42d) | 10d → 40d |  | 1433d → 1403d |  |  |
| 76 | Conduct public comment of changes | 2020-11-20 → 2021-01-01 (+42d) | 2020-12-31 → 2021-02-11 (+42d) |  |  | 1433d → 1403d |  |  |
| 77 | Post updated consensus policy | 2021-01-01 → 2021-02-12 (+42d) | 2021-01-07 → 2021-02-18 (+42d) |  |  | 1433d → 1403d |  |  |
| 84 | **Transfer Policy [HIGH]** |  | 2021-01-07 → 2021-02-18 (+42d) | 90d → 120d |  | 1433d → 1403d |  |  |
| 85 | Produce redlines of consensus policy provisions (Items 1,2,3 & 6) |  | 2020-11-05 A |  | 75% → 100% |  |  |  |
| 86 | Review and confirm redlines for final changes |  | 2020-11-19 → 2020-12-31 (+42d) | 10d → 40d |  | 1433d → 1403d |  |  |
| 87 | Conduct public comment of changes | 2020-11-20 → 2021-01-01 (+42d) | 2020-12-31 → 2021-02-11 (+42d) |  |  | 1433d → 1403d |  |  |
| 88 | Post updated consensus policy | 2021-01-01 → 2021-02-12 (+42d) | 2021-01-07 → 2021-02-18 (+42d) |  |  | 1433d → 1403d |  |  |
| 89 | **Transfer Dispute Resolution Policy (TDRP) [HIGH]** |  | 2021-01-07 → 2021-02-18 (+42d) | 90d → 120d |  | 1433d → 1403d |  |  |
| 90 | Produce redlines of consensus policy provisions |  | 2020-11-05 A |  | 75% → 100% |  |  |  |
| 91 | Review and confirm redlines for final changes |  | 2020-11-19 → 2020-12-31 (+42d) | 10d → 40d |  | 1433d → 1403d |  |  |
| 92 | Conduct public comment of changes | 2020-11-20 → 2021-01-01 (+42d) | 2020-12-31 → 2021-02-11 (+42d) |  |  | 1433d → 1403d |  |  |
| 93 | Post updated consensus policy | 2021-01-01 → 2021-02-12 (+42d) | 2021-01-07 → 2021-02-18 (+42d) |  |  | 1433d → 1403d |  |  |
| 94 | **Rules for Uniform Domain Name Dispute Resolution Policy (UDRP Rules) [HIGH]** |  | 2020-12-04 → 2021-01-15 (+42d) | 90d → 120d |  | 1457d → 1427d |  |  |
| 95 | Produce redlines of consensus policy provisions (Item 1) |  | 2020-10-02 A |  | 75% → 100% | 1457d → none |  |  |

| ID | Task | Start | Finish | Duration | Complete | Total float | Other |
| --- | --- | --- | --- | --- | --- | --- | --- |
| 96 | Review and confirm redlines for final changes |  | 2020-10-16 → 2020-11-27 (+42d) | 10d → 40d |  | 1457d → 1427d |  |
| 97 | Conduct public comment of changes | 2020-10-19 → 2020-11-30 (+42d) | 2020-11-27 → 2021-01-08 (+42d) |  |  | 1457d → 1427d |  |
| 98 | Post updated consensus policy | 2020-11-30 → 2021-01-11 (+42d) | 2020-12-04 → 2021-01-15 (+42d) |  |  | 1457d → 1427d |  |
| 99 | **Uniform Rapid Suspension System Procedure (URS) [HIGH]** |  | 2021-09-07 → 2021-10-19 (+42d) | 90d → 120d |  | 1259d → 1229d |  |
| 100 | Produce redlines of consensus policy provisions (Items 1,2 & 8) |  | 2021-07-06 A |  | 75% → 100% | 1259d → none |  |
| 101 | Review and confirm redlines for final changes |  | 2021-07-20 → 2021-08-31 (+42d) | 10d → 40d |  | 1259d → 1229d |  |
| 102 | Conduct public comment of changes | 2021-07-21 → 2021-09-01 (+42d) | 2021-08-31 → 2021-10-12 (+42d) |  |  | 1259d → 1229d |  |
| 103 | Post updated consensus policy | 2021-09-01 → 2021-10-13 (+42d) | 2021-09-07 → 2021-10-19 (+42d) |  |  | 1259d → 1229d |  |
| 104 | **Uniform Rapid Suspension System Rules (URS Rules) [HIGH]** |  | 2021-09-07 → 2021-10-19 (+42d) | 90d → 120d |  | 1259d → 1229d |  |
| 105 | Produce redlines of consensus policy provisions (Items 1&3) |  | 2021-07-06 A |  | 75% → 100% | 1259d → none |  |
| 106 | Review and confirm redlines for final changes |  | 2021-07-20 → 2021-08-31 (+42d) | 10d → 40d |  | 1259d → 1229d |  |
| 107 | Conduct public comment of changes | 2021-07-21 → 2021-09-01 (+42d) | 2021-08-31 → 2021-10-12 (+42d) |  |  | 1259d → 1229d |  |
| 108 | Post updated consensus policy | 2021-09-01 → 2021-10-13 (+42d) | 2021-09-07 → 2021-10-19 (+42d) |  |  | 1259d → 1229d |  |
| 109 | **Whois Data Reminder Policy (WDRP) [MEDIUM]** |  | 2021-02-22 → 2021-10-22 (+242d) | 122d → 297d |  | 1401d → 1226d |  |
| 110 | **Track 1 - Item 1** |  | 2021-01-07 → 2021-02-18 (+42d) | 90d → 120d |  | 1433d → 1403d |  |
| 111 | Produce redlines of consensus policy provisions |  | 2020-11-05 A |  | 75% → 100% |  |  |
| 112 | Review and confirm redlines for final changes |  | 2020-11-19 → 2020-12-31 (+42d) | 10d → 40d |  | 1433d → 1403d |  |
| 113 | Conduct public comment of changes | 2020-11-20 → 2021-01-01 (+42d) | 2020-12-31 → 2021-02-11 (+42d) |  |  | 1433d → 1403d |  |
| 114 | Post updated consensus policy | 2021-01-01 → 2021-02-12 (+42d) | 2021-01-07 → 2021-02-18 (+42d) |  |  | 1433d → 1403d |  |
| 115 | **Track 2 - Items 2 through 6** | 2021-02-22 → 2021-10-22 (+242d) | 2021-02-22 → 2021-10-22 (+242d) |  |  |  |  |
| 116 | Migrated to Remaining EPDP-P2 Topics Track 2 (Accuracy) | 2021-02-22 → 2021-10-22 (+242d) | 2021-02-22 → 2021-10-22 (+242d) |  |  |  |  |
| 117 | **Whois Marketing Restriction Policy [LOW]** |  | 2021-01-07 → 2021-02-18 (+42d) | 90d → 120d |  | 1433d → 1403d |  |
| 118 | Produce redlines of consensus policy provisions |  | 2020-11-05 A |  | 75% → 100% |  |  |
| 119 | Review and confirm redlines for final changes |  | 2020-11-19 → 2020-12-31 (+42d) | 10d → 40d |  | 1433d → 1403d |  |
| 120 | Conduct public comment of changes | 2020-11-20 → 2021-01-01 (+42d) | 2020-12-31 → 2021-02-11 (+42d) |  |  | 1433d → 1403d |  |
| 121 | Post updated consensus policy | 2021-01-01 → 2021-02-12 (+42d) | 2021-01-07 → 2021-02-18 (+42d) |  |  | 1433d → 1403d |  |
| 122 | **Revised ICANN Procedure for Handling Whois Conflicts with Privacy Law** |  | 2022-10-11 → 2022-11-22 (+42d) | 575d → 605d |  | 973d → 943d |  |
| 124 | Request ICANN org to develop revised proposal for invoking Procedure |  | 2021-01-14 → 2021-02-25 (+42d) | 60d → 90d |  | 973d → 943d |  |
| 125 | Council to deliberate findings and determine appropriate path | 2021-01-15 → 2021-02-26 (+42d) | 2021-03-18 → 2021-04-28 (+41d) |  |  | 973d → 943d |  |
| 126 | IF required, review WPIAG Charter to determine if it's fit for purpose | 2021-03-19 → 2021-04-29 (+41d) | 2021-04-28 → 2021-06-09 (+42d) |  |  | 973d → 943d |  |
| 127 | **IF required, Council to approve charter and launch WPIAG** | 2021-04-29 → 2021-06-10 (+42d) | 2021-09-22 → 2021-11-02 (+41d) |  |  | 973d → 943d |  |
| 128 | Engage WPIAG | 2021-04-29 → 2021-06-10 (+42d) | 2021-07-21 → 2021-09-01 (+42d) |  |  | 973d → 943d |  |
| 129 | Council to deliberate findings and determine appropriate path | 2021-07-22 → 2021-09-02 (+42d) | 2021-09-22 → 2021-11-02 (+41d) |  |  | 973d → 943d |  |
| 130 | **IF required, Council to approve launch of EPDP** | 2021-09-23 → 2021-11-03 (+41d) | 2022-10-11 → 2022-11-22 (+42d) |  |  | 973d → 943d |  |
| 131 | Engage EPDP: Temporary Specification on gTLD Registration Data - Phase 2 | 2021-09-23 → 2021-11-03 (+41d) | 2022-01-25 → 2022-03-08 (+42d) |  |  | 973d → 943d |  |
| 132 | Council to deliberate and adopt working group consensus recommendations | 2022-01-26 → 2022-03-09 (+42d) | 2022-03-29 → 2022-05-10 (+42d) |  |  | 973d → 943d |  |
| 133 | Board to deliberate and adopt consensus recommendations | 2022-03-30 → 2022-05-11 (+42d) | 2022-06-07 → 2022-07-19 (+42d) |  |  | 973d → 943d |  |
| 134 | Engage IRT: Temporary Specification on gTLD Registration Data - Phase 2 | 2022-06-08 → 2022-07-20 (+42d) | 2022-10-11 → 2022-11-22 (+42d) |  |  | 973d → 943d |  |
| 135 | **EPDP-P1 Rec27 Wave 1.5 & Wave 2 Other Policy Impacts (pending delivery)** | 2020-09-30 → 2020-12-17 (+78d) | 2021-02-02 → 2021-08-03 (+182d) | 90d → 165d |  |  |  |
| 137 | Council to consider Wave Wave 2 reports and determine next steps | 2020-09-30 → 2021-03-31 (+182d) | 2021-02-02 → 2021-08-03 (+182d) |  |  |  | was named Council to consider Wave 1.5 and Wave 2 reports and determine next steps |
| 138 | **IRT: Privacy & Proxy Services Accreditation Issues (on-hold pending EPDP)** | 2020-09-28 → 2021-01-22 (+116d) | 2021-10-07 → 2022-02-01 (+117d) |  |  | 1237d → 1153d |  |
| 139 | Engage IRT: Privacy & Proxy Services Accreditation Issues | 2020-09-28 → 2021-01-22 (+116d) | 2021-10-07 → 2022-02-01 (+117d) |  |  | 1237d → 1153d | constraint none → start no earlier than 2021-01-22 |
| 140 | **IRT: Translation/Transliteration of gTLD Registration Data (on-hold pending EPDP + RDAP)** | 2020-09-28 → 2021-01-22 (+116d) | 2021-10-07 → 2022-02-01 (+117d) |  |  | 1237d → 1153d |  |
| 141 | Engage IRT: Translation/Transliteration of gTLD Registration Data | 2020-09-28 → 2021-01-22 (+116d) | 2021-10-07 → 2022-02-01 (+117d) |  |  | 1237d → 1153d | constraint none → start no earlier than 2021-01-22 |
| 142 | **RPM - Program Track** |  |  |  | 15% → 17% |  |  |
| 143 | **PDP: Review of All Rights Protection Mechanisms in All gTLDs - Phase 1 (URS, TMCH, Sunrise, Claims)** |  |  |  | 38% → 43% |  |  |
| 144 | Engage Phase 1 working group (started 4 Mar 2016) |  | 2020-12-15 A |  | 75% → 100% | 34.75d → none |  |
| 160 | **CCWG: New gTLD Auction Proceeds Drafting Team (group completed 31 May 2020)** |  | 2021-12-15 → 2022-01-26 (+42d) | 360d → 390d | 7% → 6% | 1187d → 1157d |  |
| 162 | Board to deliberate and adopt consensus recommendations |  | 2021-01-01 → 2021-02-12 (+42d) | 90d → 120d | 5% → 4% | 1187d → 1157d |  |
| 163 | Implement program | 2021-01-04 → 2021-02-15 (+42d) | 2021-12-15 → 2022-01-26 (+42d) |  |  | 1187d → 1157d |  |
| 169 | **Internationalized Domain Names** |  | 2023-04-27 → 2023-06-08 (+42d) | 740d → 770d |  | 830d → 800d |  |
| 170 | **IDN Operational Track 1 Working Group** |  | 2021-01-15 → 2021-04-08 (+83d) | 120d → 180d | 40% → 27% | 1427d → 1367d |  |
| 172 | Engage Operational Track 1 expert group |  | 2021-01-15 → 2021-04-08 (+83d) | 90d → 150d | 20% → 12% | 1427d → 1367d |  |
| 173 | **IDN Policy Track 2 EPDP Working Group** |  | 2023-04-27 → 2023-06-08 (+42d) | 660d → 690d |  |  |  |
| 174 | Drafting Team to draft charter |  | 2021-01-12 → 2021-02-23 (+42d) | 60d → 90d |  |  |  |
| 175 | Engage Track 2 EPDP working group | 2021-01-13 → 2021-02-24 (+42d) | 2021-12-24 → 2022-02-04 (+42d) |  |  | 830d → 800d |  |
| 176 | Council to deliberate and adopt working group consensus recommendations | 2021-12-27 → 2022-02-07 (+42d) | 2022-02-18 → 2022-04-01 (+42d) |  |  | 830d → 800d |  |
| 177 | Board to deliberate and adopt consensus recommendations | 2022-02-21 → 2022-04-04 (+42d) | 2022-05-13 → 2022-06-24 (+42d) |  |  | 830d → 800d |  |
| 178 | Engage IRT | 2022-05-16 → 2022-06-27 (+42d) | 2023-04-27 → 2023-06-08 (+42d) |  |  | 830d → 800d |  |
| 179 | **IDN Track 3 Council Coordination** |  |  |  | 20% → 25% |  |  |
| 180 | GNSO Council to coordinate with the CCNSO regarding IDN policy developments |  |  |  | 20% → 25% |  |  |
| 181 | **Expiration - Program Track** | 2020-11-19 → 2020-10-01 A (-49d) | 2022-10-31 → 2023-03-28 (+148d) | 510d → 651d | 0% → 23% | 0d → 853d |  |
| 182 | **Expired Domain Deletion Policy (EDDP) / Expired Registration Recovery Policy (ERRP) Review** | 2020-11-19 → 2020-10-01 A (-49d) | 2022-10-31 → 2023-03-28 (+148d) | 510d → 651d | 0% → 23% | 0d → 853d |  |
| 183 | Council to extend PSR for 18 months or when bandwidth becomes available | 2020-11-19 → 2020-10-01 A (-49d) | 2022-04-25 → 2020-11-25 A (-516d) | 375d → 40d | 0% → 100% |  |  |
| 184 | Develop Policy Status Report (incl. Rec27 Wave1 EDDP Item 2 + ERRP Item3) | 2022-04-26 → 2022-09-21 (+148d) | 2022-08-29 → 2023-01-24 (+148d) |  |  | 959d → 853d | constraint none → start no earlier than 2022-09-21 |
| 185 | Council to deliberate findings | 2022-08-30 → 2023-01-25 (+148d) | 2022-10-31 → 2023-03-28 (+148d) |  |  | 959d → 853d |  |
| 186 | **Transfers - Program Track** |  | 2024-09-04 → 2024-10-16 (+42d) | 1095d → 1125d | 9% → 12% | 475d → 445d |  |
| 187 | **Transfer Policy Review** |  | 2024-09-04 → 2024-10-16 (+42d) | 1095d → 1125d | 9% → 12% | 475d → 445d |  |
| 188 | **Transfer Issue Report** |  | 2021-01-13 → 2021-02-23 (+41d) | 141d → 170d | 70% → 80% | 474d → 445d |  |
| 189 | Develop Issues Report |  | 2021-01-12 → 2021-02-23 (+42d) | 140d → 170d | 70% → 80% | 475d → 445d |  |

| ID | Task | Start | Finish | Duration | Complete | Total float |
| --- | --- | --- | --- | --- | --- | --- |
| 191 | Council to approve PDP launch | 2021-01-13 → 2021-02-24 (+42d) | 2021-01-26 → 2021-03-09 (+42d) |  |  | 475d → 445d |
| 192 | Council to approve scope and charter | 2021-01-27 → 2021-03-10 (+42d) | 2021-03-16 → 2021-04-26 (+41d) |  |  | 475d → 445d |
| 193 | Engage Transfer Policy Review PDP | 2021-03-17 → 2021-04-27 (+41d) | 2023-04-06 → 2023-05-18 (+42d) |  |  | 475d → 445d |
| 194 | Council to deliberate and adopt working group consensus recommendations | 2023-04-07 → 2023-05-19 (+42d) | 2023-06-01 → 2023-07-12 (+41d) |  |  | 475d → 445d |
| 195 | Board to deliberate and adopt consensus recommendations | 2023-06-02 → 2023-07-13 (+41d) | 2023-08-23 → 2023-10-04 (+42d) |  |  | 475d → 445d |
| 196 | Engage IRT | 2023-08-24 → 2023-10-05 (+42d) | 2024-09-04 → 2024-10-16 (+42d) |  |  | 475d → 445d |
| 197 | **IGO - Program Track** |  | 2023-05-09 → 2023-06-13 (+35d) | 748d → 773d |  | 822d → 797d |
| 198 | **PDP: RPM - IGO Curative Rights Work Track** |  | 2023-05-09 → 2023-06-13 (+35d) | 748d → 773d |  | 822d → 797d |
| 201 | Engage IGO-CRPM Work Track Policy Review PDP | 2020-11-30 → 2021-01-04 (+35d) | 2021-12-08 → 2022-01-12 (+35d) |  |  |  |
| 202 | Council to deliberate and adopt working group consensus recommendations | 2021-12-09 → 2022-01-13 (+35d) | 2022-02-02 → 2022-03-09 (+35d) |  |  | 822d → 797d |
| 203 | Board to deliberate and adopt consensus recommendations | 2022-02-03 → 2022-03-10 (+35d) | 2022-04-27 → 2022-06-01 (+35d) |  |  | 822d → 797d |
| 204 | Engage IRT | 2022-04-28 → 2022-06-02 (+35d) | 2023-05-09 → 2023-06-13 (+35d) |  |  | 822d → 797d |
| 205 | **PDP: Curative Rights Protections for IGO/INGOs** | 2022-02-03 → 2022-03-10 (+35d) | 2023-05-09 → 2023-06-13 (+35d) |  |  | 822d → 797d |
| 206 | Board to deliberate and adopt consensus recommendations | 2022-02-03 → 2022-03-10 (+35d) | 2022-04-27 → 2022-06-01 (+35d) |  |  | 822d → 797d |
| 207 | Engage IRT | 2022-04-28 → 2022-06-02 (+35d) | 2023-05-09 → 2023-06-13 (+35d) |  |  | 822d → 797d |
| 208 | **PDP: Protection of International Organization Names in All gTLDs** | 2022-04-28 → 2022-06-02 (+35d) | 2023-05-09 → 2023-06-13 (+35d) |  |  | 822d → 797d |
| 209 | Engage IRT | 2022-04-28 → 2022-06-02 (+35d) | 2023-05-09 → 2023-06-13 (+35d) |  |  | 822d → 797d |
| 210 | **Accountability - Program Track** |  |  |  | 11% → 15% |  |
| 211 | **Independent Review Process - Implementation Oversight Team** |  | 2021-06-14 → 2020-11-17 A (-209d) | 250d → 100d | 30% → 100% | 1320d → none |
| 212 | Engage IoT Oversight Team |  | 2021-06-14 → 2020-11-17 A (-209d) | 250d → 100d | 30% → 100% | 1320d → none |
| 213 | **Cross Community Working Group on Enhancing ICANN Accountability - WS2** |  | 2021-07-19 → 2021-10-29 (+102d) | 275d → 350d | 5% → 9% | 1295d → 1220d |
| 214 | Council small team to revew WS2 |  | 2020-10-13 → 2021-01-26 (+105d) | 75d → 150d |  |  |
| 215 | Council to determine what is required of the GNSO | 2020-10-14 → 2021-01-27 (+105d) | 2021-07-19 → 2021-10-29 (+102d) |  |  | 1295d → 1220d |
| 220 | **Reviews - Program Track** |  |  |  | 8% → 9% |  |
| 245 | **Security, Stability and Resiliency of the DNS #2** |  |  |  | 44% → 51% |  |
| 246 | GNSO participation on SSR#2 |  |  |  | 60% → 70% |  |
| 251 | **Operations - Program Track** |  |  |  | 12% → 9% |  |
| 253 | Council to decide to extend review beyond 5 years from Final Report |  | 2020-10-30 → 2020-12-18 (+49d) | 20d → 55d |  |  |
| 257 | **Participant of Empowered Community** |  |  |  | 6% → 7% |  |
| 259 | Elect new participant | 2020-10-22 A | 2020-11-11 A |  | 0% → 100% | 164d → none |
| 269 | **GNSO Council** |  |  |  | 16% → 10% |  |
| 270 | **GNSO Council - Monthly Meetings** |  |  |  | 6% → 8% |  |
| 275 | GNSO Council Meeting | 2020-11-19 A | 2020-11-19 A |  | 0% → 100% |  |
| 276 | GNSO Council Meeting | 2020-12-17 A | 2020-12-17 A |  | 0% → 100% |  |
| 343 | **GNSO Council - Leadership Meetings** |  |  |  | 6% → 8% |  |
| 348 | GNSO Council - Leadership Meetings | 2020-11-09 A | 2020-11-10 A |  | 0% → 100% |  |
| 349 | GNSO Council - Leadership Meetings | 2020-12-14 A | 2020-12-15 A |  | 0% → 100% |  |
| 416 | **GNSO Council - Action Items** |  |  |  | 6% → 8% |  |
| 421 | GNSO Council - Action Items | 2020-11-09 A | 2020-11-09 A |  | 0% → 100% |  |
| 422 | GNSO Council - Action Items | 2020-12-14 A | 2020-12-14 A |  | 0% → 100% |  |
| 489 | **GNSO Standing Committee on Budget and Operations** | 2020-11-02 A | 2021-03-25 → 2025-02-12 (+1420d) | 105d → 1123d | 0% → 6% | 0d → 359d |
| 491 | Refresh roster and confirm Chair | 2020-11-02 A | 2020-11-20 A |  | 0% → 100% |  |
| 492 | Evaluate fiscal year budget and planning documents | 2020-11-23 A | 2021-03-05 → 2021-01-29 (-35d) | 75d → 50d | 0% → 15% | 1377d → 1407d |
| 493 | Complete draft of comments for Council consideration and submit | 2021-03-08 → 2021-02-01 (-35d) | 2021-03-25 → 2021-02-12 (-41d) | 15d → 10d |  | 1377d → 1407d |
| 510 | **GNSO Standing Selection Committee** |  | 2021-12-21 → 2025-06-18 (+1275d) | 387d → 1301d | 60% → 18% |  |
| 511 | SSC fill positions as assigned |  | 2021-12-21 → 2025-06-18 (+1275d) | 386d → 1300d | 60% → 18% |  |
| 512 | **Strategic Planning Session** |  | 2021-02-16 → 2025-02-07 (+1452d) | 99d → 1142d | 49% → 7% | 1405d → 362d |
| 514 | Establish and manage travel arrangements |  | 2021-01-13 A → 2020-10-01 A (-104d) | 75d → 1d |  |  |
| 515 | Develop plan, topics, and materials for deliberation | 2020-10-21 A → 2020-10-01 A (-20d) | 2021-01-19 → 2020-11-11 A (-69d) | 65d → 30d | 5% → 100% |  |
| 516 | Conduct planning session | 2021-01-20 → 2020-11-02 A (-79d) | 2021-01-26 → 2020-11-23 A (-64d) | 5d → 13d | 0% → 100% | 1405d → none |
| 517 | Develop post planning session report | 2021-01-27 → 2020-11-23 A (-65d) | 2021-02-16 → 2020-12-11 (-67d) |  | 0% → 20% | 1405d → 1452d |
| 538 | **ICANN Meeting Planning, Meeting, Respond to GAC Advice** |  |  |  | 5% → 6% |  |
| 539 | **ICANN69** |  | 2020-11-12 A |  | 84% → 100% | 1473d → none |
| 542 | Respond to GAC Advice | 2020-10-23 A | 2020-11-12 A |  | 0% → 100% | 1473d → none |

## Version 7 (saved 2021-01-09, file GNSO_Council_Program_Management_Tool_20210121.mpp)

Last finish stays 2026-06-30. Complete tasks 61 → 66.

Changed:

| ID | Task | Start | Finish | Duration | Complete | Total float |
| --- | --- | --- | --- | --- | --- | --- |
| 1 | **GNSO Program Management Planning** |  |  |  | 12% → 16% |  |
| 2 | **RDDS - Program Track** |  |  |  | 19% → 20% |  |
| 3 | **EPDP: Temporary Specification on gTLD Registration Data - Phase 2** |  |  |  | 9% → 10% |  |
| 6 | Board to deliberate and adopt consensus recommendations | 2020-09-28 A |  |  | 0% → 5% |  |
| 8 | **Remaining EPDP-P2 Topics (Legal vs. Natural, Unique Contacts, + Accuracy )** |  |  |  | 5% → 7% |  |
| 9 | **Remaining EPDP-P2 Topics Track 1 (Legal vs. Natural + Feasability of Unique Contacts)** |  |  |  | 13% → 15% |  |
| 11 | Engage EPDP-P2A to address remaining topics |  |  |  | 3% → 9% |  |
| 15 | **Remaining EPDP-P2 Topics Track 2 (Accuracy)** | 2020-09-28 A |  |  | 0% → 3% |  |
| 16 | Staff to produce Briefing Document on Accuracy | 2020-09-28 A |  |  | 0% → 15% |  |
| 122 | **Revised ICANN Procedure for Handling Whois Conflicts with Privacy Law** |  | 2022-11-22 → 2023-01-03 (+42d) | 605d → 635d | 10% → 16% | 943d → 913d |
| 124 | Request ICANN org to develop revised proposal for invoking Procedure | 2020-10-23 A | 2021-02-25 → 2021-04-07 (+41d) | 90d → 120d | 0% → 35% | 943d → 913d |
| 125 | Council to deliberate findings and determine appropriate path | 2021-02-26 → 2021-04-08 (+41d) | 2021-04-28 → 2021-06-09 (+42d) |  |  | 943d → 913d |
| 126 | IF required, review WPIAG Charter to determine if it's fit for purpose | 2021-04-29 → 2021-06-10 (+42d) | 2021-06-09 → 2021-07-21 (+42d) |  |  | 943d → 913d |
| 127 | **IF required, Council to approve charter and launch WPIAG** | 2021-06-10 → 2021-07-22 (+42d) | 2021-11-02 → 2021-12-14 (+42d) |  |  | 943d → 913d |
| 128 | Engage WPIAG | 2021-06-10 → 2021-07-22 (+42d) | 2021-09-01 → 2021-10-13 (+42d) |  |  | 943d → 913d |
| 129 | Council to deliberate findings and determine appropriate path | 2021-09-02 → 2021-10-14 (+42d) | 2021-11-02 → 2021-12-14 (+42d) |  |  | 943d → 913d |
| 130 | **IF required, Council to approve launch of EPDP** | 2021-11-03 → 2021-12-15 (+42d) | 2022-11-22 → 2023-01-03 (+42d) |  |  | 943d → 913d |
| 131 | Engage EPDP: Temporary Specification on gTLD Registration Data - Phase 2 | 2021-11-03 → 2021-12-15 (+42d) | 2022-03-08 → 2022-04-19 (+42d) |  |  | 943d → 913d |
| 132 | Council to deliberate and adopt working group consensus recommendations | 2022-03-09 → 2022-04-20 (+42d) | 2022-05-10 → 2022-06-21 (+42d) |  |  | 943d → 913d |
| 133 | Board to deliberate and adopt consensus recommendations | 2022-05-11 → 2022-06-22 (+42d) | 2022-07-19 → 2022-08-30 (+42d) |  |  | 943d → 913d |
| 134 | Engage IRT: Temporary Specification on gTLD Registration Data - Phase 2 | 2022-07-20 → 2022-08-31 (+42d) | 2022-11-22 → 2023-01-03 (+42d) |  |  | 943d → 913d |
| 142 | **RPM - Program Track** |  | 2024-11-13 → 2024-12-24 (+41d) | 1145d → 1175d | 17% → 18% | 425d → 395d |
| 143 | **PDP: Review of All Rights Protection Mechanisms in All gTLDs - Phase 1 (URS, TMCH, Sunrise, Claims)** |  |  |  | 43% → 46% |  |
| 150 | Council to deliberate and adopt working group consensus recommendations | 2020-12-16 A |  |  | 0% → 50% | 425d → 395d |
| 153 | **PDP: Review of All Rights Protection Mechanisms in All gTLDs - Phase 2 (UDRP)** |  | 2024-11-13 → 2024-12-24 (+41d) | 985d → 1015d |  | 425d → 395d |
| 154 | Drafting Team to draft new charter (incl. Items 2 through 11 of Rec27 Wave1) |  | 2021-06-14 → 2021-07-26 (+42d) | 90d → 120d |  | 425d → 395d |
| 155 | Engage Phase 2 working group | 2021-06-15 → 2021-07-27 (+42d) | 2023-06-15 → 2023-07-26 (+41d) |  |  | 425d → 395d |
| 156 | Council to deliberate and adopt working group consensus recommendations | 2023-06-16 → 2023-07-27 (+41d) | 2023-08-09 → 2023-09-20 (+42d) |  |  | 425d → 395d |
| 157 | Board to deliberate and adopt consensus recommendations | 2023-08-10 → 2023-09-21 (+42d) | 2023-11-01 → 2023-12-13 (+42d) |  |  | 425d → 395d |
| 158 | Engage IRT | 2023-11-02 → 2023-12-14 (+42d) | 2024-11-13 → 2024-12-24 (+41d) |  |  | 425d → 395d |
| 159 | **gTLD - Program Track** |  | 2023-08-08 → 2023-08-09 (+1d) | 814d → 815d | 11% → 14% | 756d → 755d |
| 169 | **Internationalized Domain Names** |  | 2023-06-08 → 2023-08-09 (+62d) | 770d → 815d | 11% → 18% | 800d → 755d |
| 170 | **IDN Operational Track 1 Working Group** |  | 2021-04-08 → 2021-08-26 (+140d) | 180d → 280d | 27% → 29% | 1367d → 1267d |
| 172 | Engage Operational Track 1 expert group |  | 2021-04-08 → 2021-08-26 (+140d) | 150d → 250d | 12% → 20% | 1367d → 1267d |
| 173 | **IDN Policy Track 2 EPDP Working Group** | 2020-10-21 A | 2023-06-08 → 2023-08-09 (+62d) | 690d → 735d | 0% → 5% | 0d → 755d |
| 174 | Drafting Team to draft charter | 2020-10-21 A | 2021-02-23 → 2021-04-26 (+62d) | 90d → 135d | 0% → 25% |  |
| 175 | Engage Track 2 EPDP working group | 2021-02-24 → 2021-04-27 (+62d) | 2022-02-04 → 2022-04-08 (+63d) |  |  | 800d → 755d |
| 176 | Council to deliberate and adopt working group consensus recommendations | 2022-02-07 → 2022-04-11 (+63d) | 2022-04-01 → 2022-06-03 (+63d) |  |  | 800d → 755d |
| 177 | Board to deliberate and adopt consensus recommendations | 2022-04-04 → 2022-06-06 (+63d) | 2022-06-24 → 2022-08-26 (+63d) |  |  | 800d → 755d |
| 178 | Engage IRT | 2022-06-27 → 2022-08-29 (+63d) | 2023-06-08 → 2023-08-09 (+62d) |  |  | 800d → 755d |
| 179 | **IDN Track 3 Council Coordination** |  |  |  | 25% → 35% |  |
| 180 | GNSO Council to coordinate with the CCNSO regarding IDN policy developments |  |  |  | 25% → 35% |  |
| 186 | **Transfers - Program Track** |  |  |  | 12% → 15% |  |
| 187 | **Transfer Policy Review** |  |  |  | 12% → 15% |  |
| 188 | **Transfer Issue Report** |  | 2021-02-23 A |  | 80% → 100% | 445d → none |
| 189 | Develop Issues Report |  | 2021-02-23 A |  | 80% → 100% | 445d → none |
| 197 | **IGO - Program Track** |  |  |  | 0% → 1% |  |
| 198 | **PDP: RPM - IGO Curative Rights Work Track** |  |  |  | 0% → 1% |  |
| 201 | Engage IGO-CRPM Work Track Policy Review PDP | 2021-01-04 A |  |  | 0% → 3% |  |
| 210 | **Accountability - Program Track** |  | 2021-12-10 → 2022-01-07 (+28d) | 380d → 400d | 15% → 43% | 1190d → 1170d |
| 213 | **Cross Community Working Group on Enhancing ICANN Accountability - WS2** |  | 2021-10-29 → 2022-01-07 (+70d) | 350d → 400d | 9% → 35% | 1220d → 1170d |
| 214 | Council small team to revew WS2 |  | 2021-01-26 → 2021-04-05 (+69d) | 150d → 200d | 20% → 70% |  |
| 215 | Council to determine what is required of the GNSO | 2021-01-27 → 2021-04-06 (+69d) | 2021-10-29 → 2022-01-07 (+70d) |  |  | 1220d → 1170d |
| 216 | **Multistakeholder Model Evolution** |  |  |  | 10% → 40% |  |
| 217 | Council to determine what is required of the GNSO |  |  |  | 10% → 40% |  |
| 218 | **Geo Regions Review** |  |  |  | 5% → 40% |  |
| 219 | Council to determine what is required of the GNSO |  |  |  | 5% → 40% |  |
| 220 | **Reviews - Program Track** |  |  |  | 9% → 16% |  |
| 221 | **IANA Naming Function Review** |  |  |  | 39% → 75% |  |
| 223 | GNSO participation on IFRT2 |  |  |  | 39% → 75% |  |
| 239 | **Accountability and Transparency Review 3** |  | 2021-06-28 → 2021-10-04 (+98d) | 260d → 330d | 22% → 44% | 1310d → 1240d |
| 241 | Council to monitor for ATRT3 implementation assignments should the Board adopt ATRT3 recommendations |  | 2021-06-28 → 2021-10-04 (+98d) | 260d → 330d | 15% → 40% | 1310d → 1240d |
| 245 | **Security, Stability and Resiliency of the DNS #2** |  | 2021-02-23 → 2021-04-12 (+48d) | 170d → 205d | 51% → 62% | 1400d → 1365d |
| 246 | GNSO participation on SSR#2 |  | 2020-12-22 → 2021-02-09 (+49d) | 125d → 160d | 70% → 80% | 1400d → 1365d |
| 247 | Council to consider SSR#2 Results | 2020-12-23 → 2021-02-10 (+49d) | 2021-02-23 → 2021-04-12 (+48d) |  |  | 1400d → 1365d |
| 251 | **Operations - Program Track** |  |  |  | 9% → 10% |  |
| 252 | **Policy & Implementation - Recommendations Review** | 2020-10-05 A |  |  | 0% → 23% | 0d → 1025d |
| 253 | Council to decide to extend review beyond 5 years from Final Report | 2020-10-05 A | 2020-12-18 → 2021-02-19 (+63d) | 55d → 100d | 0% → 70% |  |
| 257 | **Participant of Empowered Community** |  |  |  | 7% → 9% |  |
| 260 | Perform role 2021 | 2020-11-12 A |  |  | 0% → 15% |  |

| ID | Task | Start | Finish | Duration | Complete | Total float |
| --- | --- | --- | --- | --- | --- | --- |
| 269 | **GNSO Council** |  |  |  | 10% → 9% |  |
| 270 | **GNSO Council - Monthly Meetings** |  |  |  | 8% → 10% |  |
| 277 | GNSO Council Meeting | 2021-01-21 A | 2021-01-21 A |  | 0% → 100% |  |
| 343 | **GNSO Council - Leadership Meetings** |  |  |  | 8% → 10% |  |
| 350 | GNSO Council - Leadership Meetings | 2021-01-11 A | 2021-01-12 A |  | 0% → 100% |  |
| 416 | **GNSO Council - Action Items** |  |  |  | 8% → 10% |  |
| 423 | GNSO Council - Action Items | 2021-01-11 A | 2021-01-11 A |  | 0% → 100% |  |
| 489 | **GNSO Standing Committee on Budget and Operations** |  |  |  | 6% → 13% |  |
| 490 | **2020-2021** |  | 2021-02-12 → 2021-02-15 (+3d) | 75d → 76d | 30% → 66% | 1407d → 1406d |
| 492 | Evaluate fiscal year budget and planning documents |  |  |  | 15% → 70% | 1407d → 1406d |
| 493 | Complete draft of comments for Council consideration and submit |  | 2021-02-12 → 2021-02-15 (+3d) | 10d → 11d |  | 1407d → 1406d |
| 510 | **GNSO Standing Selection Committee** |  |  |  | 18% → 12% |  |
| 511 | SSC fill positions as assigned |  |  |  | 18% → 12% |  |
| 512 | **Strategic Planning Session** |  |  |  | 7% → 8% |  |
| 513 | **2020-2021** |  | 2020-12-11 A |  | 80% → 100% | 1452d → none |
| 517 | Develop post planning session report |  | 2020-12-11 A |  | 20% → 100% | 1452d → none |

## Version 8 (saved 2021-02-04, file GNSO_Council_Program_Management_Tool_20210218.mpp)

Last finish stays 2026-06-30. Complete tasks 66 → 75.

Changed:

| ID | Task | Start | Finish | Duration | Complete | Total float | Other |
| --- | --- | --- | --- | --- | --- | --- | --- |
| 1 | **GNSO Program Management Planning** |  |  |  | 16% → 17% |  |  |
| 2 | **RDDS - Program Track** |  |  |  | 20% → 21% |  |  |
| 3 | **EPDP: Temporary Specification on gTLD Registration Data - Phase 2** |  |  |  | 10% → 11% |  |  |
| 6 | Board to deliberate and adopt consensus recommendations |  |  |  | 5% → 10% |  |  |
| 8 | **Remaining EPDP-P2 Topics (Legal vs. Natural, Unique Contacts, + Accuracy )** |  |  |  | 7% → 12% |  |  |
| 9 | **Remaining EPDP-P2 Topics Track 1 (Legal vs. Natural + Feasability of Unique Contacts)** |  | 2022-07-18 → 2022-09-12 (+56d) | 473d → 513d | 15% → 18% | 1034d → 994d |  |
| 11 | Engage EPDP-P2A to address remaining topics |  | 2021-06-29 → 2021-08-24 (+56d) | 140d → 180d | 9% → 19% | 1034d → 994d |  |
| 12 | Council to deliberate and adopt working group consensus recommendations | 2021-06-30 → 2021-08-25 (+56d) | 2021-08-31 → 2021-10-25 (+55d) |  |  | 1034d → 994d |  |
| 13 | Board to deliberate and adopt consensus recommendations | 2021-09-01 → 2021-10-26 (+55d) | 2021-11-08 → 2022-01-03 (+56d) |  |  | 1034d → 994d |  |
| 14 | Engage IRT | 2021-11-09 → 2022-01-04 (+56d) | 2022-07-18 → 2022-09-12 (+56d) |  |  | 1034d → 994d |  |
| 15 | **Remaining EPDP-P2 Topics Track 2 (Accuracy)** |  |  |  | 3% → 9% |  |  |
| 16 | Staff to produce Briefing Document on Accuracy |  |  |  | 15% → 50% |  |  |
| 135 | **EPDP-P1 Rec27 Wave 1.5 & Wave 2 Other Policy Impacts (pending delivery)** |  | 2021-08-03 → 2021-10-01 (+59d) | 165d → 208d |  |  |  |
| 136 | Council to consider Wave 1.5 report and determine next steps |  | 2021-04-20 → 2021-06-01 (+42d) | 90d → 120d |  |  |  |
| 137 | Council to consider Wave Wave 2 reports and determine next steps | 2021-03-31 → 2021-05-31 (+61d) | 2021-08-03 → 2021-10-01 (+59d) |  |  |  |  |
| 138 | **IRT: Privacy & Proxy Services Accreditation Issues (on-hold pending EPDP)** | 2021-01-22 → 2021-03-25 (+62d) | 2022-02-01 → 2022-04-05 (+63d) |  |  | 1153d → 1108d |  |
| 139 | Engage IRT: Privacy & Proxy Services Accreditation Issues | 2021-01-22 → 2021-03-25 (+62d) | 2022-02-01 → 2022-04-05 (+63d) |  |  | 1153d → 1108d | constraint start no earlier than 2021-01-22 → start no earlier than 2021-03-25 |
| 140 | **IRT: Translation/Transliteration of gTLD Registration Data (on-hold pending EPDP + RDAP)** | 2021-01-22 → 2021-03-25 (+62d) | 2022-02-01 → 2022-04-05 (+63d) |  |  | 1153d → 1108d |  |
| 141 | Engage IRT: Translation/Transliteration of gTLD Registration Data | 2021-01-22 → 2021-03-25 (+62d) | 2022-02-01 → 2022-04-05 (+63d) |  |  | 1153d → 1108d | constraint start no earlier than 2021-01-22 → start no earlier than 2021-03-25 |
| 142 | **RPM - Program Track** |  | 2024-12-24 → 2025-02-04 (+42d) | 1175d → 1205d | 18% → 19% | 395d → 365d |  |
| 143 | **PDP: Review of All Rights Protection Mechanisms in All gTLDs - Phase 1 (URS, TMCH, Sunrise, Claims)** |  |  |  | 46% → 49% |  |  |
| 150 | Council to deliberate and adopt working group consensus recommendations |  | 2021-02-09 A |  | 50% → 100% | 395d → none |  |
| 153 | **PDP: Review of All Rights Protection Mechanisms in All gTLDs - Phase 2 (UDRP)** |  | 2024-12-24 → 2025-02-04 (+42d) | 1015d → 1045d |  | 395d → 365d |  |
| 154 | Drafting Team to draft new charter (incl. Items 2 through 11 of Rec27 Wave1) |  | 2021-07-26 → 2021-09-06 (+42d) | 120d → 150d |  | 395d → 365d |  |
| 155 | Engage Phase 2 working group | 2021-07-27 → 2021-09-07 (+42d) | 2023-07-26 → 2023-09-06 (+42d) |  |  | 395d → 365d |  |
| 156 | Council to deliberate and adopt working group consensus recommendations | 2023-07-27 → 2023-09-07 (+42d) | 2023-09-20 → 2023-11-01 (+42d) |  |  | 395d → 365d |  |
| 157 | Board to deliberate and adopt consensus recommendations | 2023-09-21 → 2023-11-02 (+42d) | 2023-12-13 → 2024-01-24 (+42d) |  |  | 395d → 365d |  |
| 158 | Engage IRT | 2023-12-14 → 2024-01-25 (+42d) | 2024-12-24 → 2025-02-04 (+42d) |  |  | 395d → 365d |  |
| 159 | **gTLD - Program Track** |  | 2023-08-09 → 2023-08-21 (+12d) | 815d → 823d | 14% → 15% | 755d → 747d |  |
| 160 | **CCWG: New gTLD Auction Proceeds Drafting Team (group completed 31 May 2020)** |  | 2022-01-26 → 2022-05-18 (+112d) | 390d → 470d | 6% → 5% | 1157d → 1077d |  |
| 162 | Board to deliberate and adopt consensus recommendations |  | 2021-02-12 → 2021-06-03 (+111d) | 120d → 200d | 4% → 2% | 1157d → 1077d |  |
| 163 | Implement program | 2021-02-15 → 2021-06-04 (+109d) | 2022-01-26 → 2022-05-18 (+112d) |  |  | 1157d → 1077d |  |
| 164 | **PDP: New gTLD Subsequent Procedures PDP** |  | 2023-08-08 → 2023-08-21 (+13d) | 814d → 823d | 13% → 17% | 756d → 747d |  |
| 165 | Execute New gTLD Subsequent Procedures PDP (started 21 Jan 2016) |  | 2020-12-21 → 2021-01-15 A (+25d) | 124d → 143d | 85% → 100% | 756d → none |  |
| 166 | Council to deliberate and adopt working group recommendations | 2020-12-22 → 2021-01-18 (+27d) | 2021-03-15 → 2021-03-25 (+10d) | 60d → 50d |  | 756d → 747d |  |
| 167 | Board to deliberate and adopt consensus recommendations | 2021-03-16 → 2021-03-26 (+10d) | 2021-07-16 → 2021-07-29 (+13d) |  |  | 756d → 747d |  |
| 168 | Execute IRT | 2021-07-19 → 2021-07-30 (+11d) | 2023-08-08 → 2023-08-21 (+13d) |  |  | 756d → 747d |  |
| 210 | **Accountability - Program Track** |  | 2022-01-07 → 2024-04-24 (+838d) | 400d → 1000d | 43% → 28% | 1170d → 570d |  |
| 213 | **Cross Community Working Group on Enhancing ICANN Accountability - WS2** |  | 2022-01-07 → 2022-03-04 (+56d) | 400d → 440d | 35% → 32% | 1170d → 1130d |  |
| 214 | Council small team to revew WS2 |  | 2021-04-05 → 2021-05-31 (+56d) | 200d → 240d | 70% → 58% |  |  |
| 215 | Council to determine what is required of the GNSO | 2021-04-06 → 2021-06-01 (+56d) | 2022-01-07 → 2022-03-04 (+56d) |  |  | 1170d → 1130d |  |
| 216 | **Multistakeholder Model Evolution** |  | 2021-12-10 → 2024-04-24 (+866d) | 380d → 1000d | 40% → 15% | 1190d → 570d |  |
| 217 | Council to determine what is required of the GNSO |  | 2021-12-10 → 2024-04-24 (+866d) | 380d → 1000d | 40% → 15% | 1190d → 570d |  |
| 220 | **Reviews - Program Track** |  |  |  | 16% → 19% |  |  |
| 221 | **IANA Naming Function Review** |  | 2021-03-22 A |  | 75% → 100% | 1380d → none |  |
| 223 | GNSO participation on IFRT2 |  | 2021-03-22 A |  | 75% → 100% | 1380d → none |  |
| 245 | **Security, Stability and Resiliency of the DNS #2** |  |  |  | 62% → 78% |  |  |
| 246 | GNSO participation on SSR#2 |  | 2021-02-09 A |  | 80% → 100% | 1365d → none |  |
| 251 | **Operations - Program Track** |  |  |  | 10% → 13% |  |  |
| 252 | **Policy & Implementation - Recommendations Review** |  |  |  | 23% → 20% |  |  |
| 253 | Council to decide to extend review beyond 5 years from Final Report |  | 2021-02-19 → 2021-04-15 (+55d) | 100d → 140d | 70% → 50% |  |  |
| 257 | **Participant of Empowered Community** |  |  |  | 9% → 11% |  |  |
| 260 | Perform role 2021 |  |  |  | 15% → 25% |  |  |
| 269 | **GNSO Council** |  |  |  | 9% → 14% |  |  |
| 270 | **GNSO Council - Monthly Meetings** |  |  |  | 10% → 11% |  |  |
| 278 | GNSO Council Meeting | 2021-02-18 A | 2021-02-18 A |  | 0% → 100% |  |  |
| 343 | **GNSO Council - Leadership Meetings** |  |  |  | 10% → 11% |  |  |
| 351 | GNSO Council - Leadership Meetings | 2021-02-08 A | 2021-02-09 A |  | 0% → 100% |  |  |
| 416 | **GNSO Council - Action Items** |  |  |  | 10% → 11% |  |  |
| 424 | GNSO Council - Action Items | 2021-02-08 A | 2021-02-08 A |  | 0% → 100% |  |  |
| 489 | **GNSO Standing Committee on Budget and Operations** |  |  |  | 13% → 20% |  |  |
| 490 | **2020-2021** |  | 2021-02-15 A |  | 66% → 100% | 1406d → none |  |
| 492 | Evaluate fiscal year budget and planning documents |  | 2021-01-29 A |  | 70% → 100% | 1406d → none |  |
| 493 | Complete draft of comments for Council consideration and submit | 2021-02-01 A | 2021-02-15 A |  | 0% → 100% | 1406d → none |  |
| 510 | **GNSO Standing Selection Committee** |  |  |  | 12% → 20% |  |  |
| 511 | SSC fill positions as assigned |  |  |  | 12% → 20% |  |  |
| 538 | **ICANN Meeting Planning, Meeting, Respond to GAC Advice** |  |  |  | 6% → 9% |  |  |
| 543 | **ICANN70** | 2020-12-01 A |  |  | 0% → 51% |  |  |
| 544 | Meeting Planning | 2020-12-01 A |  |  | 0% → 65% |  |  |

## Version 9 (saved 2021-03-14, file GNSO_Council_Program_Management_Tool_20210324.mpp)

Last finish stays 2026-06-30. Complete tasks 75 → 83.

Changed:

| ID | Task | Start | Finish | Duration | Complete | Total float | Predecessors | Other |
| --- | --- | --- | --- | --- | --- | --- | --- | --- |
| 1 | **GNSO Program Management Planning** |  |  |  | 17% → 20% |  |  |  |
| 2 | **RDDS - Program Track** |  | 2023-08-21 → 2023-09-18 (+28d) | 823d → 843d | 21% → 23% | 747d → 727d |  |  |
| 3 | **EPDP: Temporary Specification on gTLD Registration Data - Phase 2** |  | 2023-04-18 → 2023-09-18 (+153d) | 733d → 843d | 11% → 21% | 837d → 727d |  |  |
| 6 | Board to deliberate and adopt consensus recommendations |  | 2021-04-22 → 2021-09-23 (+154d) | 150d → 260d | 10% → 45% | 837d → 727d |  |  |
| 7 | Engage IRT: Temporary Specification on gTLD Registration Data - Phase 2 | 2021-04-23 → 2021-09-24 (+154d) | 2023-04-18 → 2023-09-18 (+153d) |  |  | 837d → 727d |  |  |
| 8 | **Remaining EPDP-P2 Topics (Legal vs. Natural, Unique Contacts, + Accuracy )** |  |  |  | 12% → 20% |  |  |  |
| 9 | **Remaining EPDP-P2 Topics Track 1 (Legal vs. Natural + Feasability of Unique Contacts)** |  |  |  | 18% → 23% |  |  |  |
| 11 | Engage EPDP-P2A to address remaining topics |  |  |  | 19% → 34% |  |  |  |
| 15 | **Remaining EPDP-P2 Topics Track 2 (Accuracy)** |  |  |  | 9% → 17% |  |  |  |
| 16 | Staff to produce Briefing Document on Accuracy |  | 2021-03-25 A |  | 50% → 100% | 747d → none |  |  |
| 34 | **IRT: Temporary Specification on gTLD Registration Data - Phase 1** |  |  |  | 37% → 32% |  |  |  |
| 35 | Engage IRT: Temporary Specification on gTLD Registration Data - Phase 1 |  |  |  | 55% → 35% |  |  |  |
| 122 | **Revised ICANN Procedure for Handling Whois Conflicts with Privacy Law** |  | 2023-01-03 → 2023-02-28 (+56d) | 635d → 675d | 16% → 22% | 913d → 873d |  |  |
| 124 | Request ICANN org to develop revised proposal for invoking Procedure |  | 2021-04-07 → 2021-06-02 (+56d) | 120d → 160d | 35% → 55% | 913d → 873d |  |  |
| 125 | Council to deliberate findings and determine appropriate path | 2021-04-08 → 2021-06-03 (+56d) | 2021-06-09 → 2021-08-04 (+56d) |  |  | 913d → 873d |  |  |
| 126 | IF required, review WPIAG Charter to determine if it's fit for purpose | 2021-06-10 → 2021-08-05 (+56d) | 2021-07-21 → 2021-09-15 (+56d) |  |  | 913d → 873d |  |  |
| 127 | **IF required, Council to approve charter and launch WPIAG** | 2021-07-22 → 2021-09-16 (+56d) | 2021-12-14 → 2022-02-08 (+56d) |  |  | 913d → 873d |  |  |
| 128 | Engage WPIAG | 2021-07-22 → 2021-09-16 (+56d) | 2021-10-13 → 2021-12-07 (+55d) |  |  | 913d → 873d |  |  |
| 129 | Council to deliberate findings and determine appropriate path | 2021-10-14 → 2021-12-08 (+55d) | 2021-12-14 → 2022-02-08 (+56d) |  |  | 913d → 873d |  |  |
| 130 | **IF required, Council to approve launch of EPDP** | 2021-12-15 → 2022-02-09 (+56d) | 2023-01-03 → 2023-02-28 (+56d) |  |  | 913d → 873d |  |  |
| 131 | Engage EPDP: Temporary Specification on gTLD Registration Data - Phase 2 | 2021-12-15 → 2022-02-09 (+56d) | 2022-04-19 → 2022-06-14 (+56d) |  |  | 913d → 873d |  |  |
| 132 | Council to deliberate and adopt working group consensus recommendations | 2022-04-20 → 2022-06-15 (+56d) | 2022-06-21 → 2022-08-16 (+56d) |  |  | 913d → 873d |  |  |
| 133 | Board to deliberate and adopt consensus recommendations | 2022-06-22 → 2022-08-17 (+56d) | 2022-08-30 → 2022-10-25 (+56d) |  |  | 913d → 873d |  |  |
| 134 | Engage IRT: Temporary Specification on gTLD Registration Data - Phase 2 | 2022-08-31 → 2022-10-26 (+56d) | 2023-01-03 → 2023-02-28 (+56d) |  |  | 913d → 873d |  |  |
| 135 | **EPDP-P1 Rec27 Wave 1.5 & Wave 2 Other Policy Impacts** | 2020-12-17 → 2021-03-01 A (+74d) |  | 208d → 156d | 0% → 6% |  |  | was named EPDP-P1 Rec27 Wave 1.5 & Wave 2 Other Policy Impacts (pending delivery) |
| 136 | Council to consider Wave 1.5 report and determine next steps | 2020-12-17 → 2021-03-01 A (+74d) | 2021-06-01 → 2021-05-20 (-12d) | 120d → 60d | 0% → 16% |  |  |  |
| 138 | **IRT: Privacy & Proxy Services Accreditation Issues (on-hold pending EPDP)** | 2021-03-25 → 2021-05-21 (+57d) | 2022-04-05 → 2022-06-01 (+57d) |  |  | 1108d → 1067d |  |  |
| 139 | Engage IRT: Privacy & Proxy Services Accreditation Issues | 2021-03-25 → 2021-05-21 (+57d) | 2022-04-05 → 2022-06-01 (+57d) |  |  | 1108d → 1067d | 5 → 136 |  |
| 140 | **IRT: Translation/Transliteration of gTLD Registration Data (on-hold pending EPDP + RDAP)** | 2021-03-25 → 2021-05-21 (+57d) | 2022-04-05 → 2022-06-01 (+57d) |  |  | 1108d → 1067d |  |  |
| 141 | Engage IRT: Translation/Transliteration of gTLD Registration Data | 2021-03-25 → 2021-05-21 (+57d) | 2022-04-05 → 2022-06-01 (+57d) |  |  | 1108d → 1067d | 5 → 136 |  |
| 142 | **RPM - Program Track** |  |  |  | 19% → 20% |  |  |  |
| 143 | **PDP: Review of All Rights Protection Mechanisms in All gTLDs - Phase 1 (URS, TMCH, Sunrise, Claims)** |  | 2022-05-13 → 2022-06-24 (+42d) | 490d → 520d | 49% → 47% | 1080d → 1050d |  |  |
| 151 | Board to deliberate and adopt consensus recommendations |  | 2021-05-03 → 2021-06-14 (+42d) | 60d → 90d |  | 1080d → 1050d |  |  |
| 152 | Engage IRT | 2021-05-04 → 2021-06-15 (+42d) | 2022-05-13 → 2022-06-24 (+42d) |  |  | 1080d → 1050d |  |  |
| 153 | **PDP: Review of All Rights Protection Mechanisms in All gTLDs - Phase 2 (UDRP)** | 2021-02-10 A |  |  | 0% → 2% |  |  |  |
| 154 | Drafting Team to draft new charter (incl. Items 2 through 11 of Rec27 Wave1) | 2021-02-10 A |  |  | 0% → 15% |  |  |  |
| 159 | **gTLD - Program Track** |  | 2023-08-21 → 2023-08-09 (-12d) | 823d → 815d | 15% → 22% | 747d → 755d |  |  |
| 160 | **CCWG: New gTLD Auction Proceeds Drafting Team (group completed 31 May 2020)** |  |  |  | 5% → 34% |  |  |  |
| 162 | Board to deliberate and adopt consensus recommendations |  |  |  | 2% → 70% |  |  |  |
| 164 | **PDP: New gTLD Subsequent Procedures PDP** |  | 2023-08-21 → 2023-07-17 (-35d) | 823d → 798d | 17% → 21% | 747d → 772d |  |  |
| 166 | Council to deliberate and adopt working group recommendations | 2021-01-18 A | 2021-03-25 → 2021-02-19 A (-34d) | 50d → 25d | 0% → 100% | 747d → none |  |  |
| 167 | Board to deliberate and adopt consensus recommendations | 2021-03-26 → 2021-02-22 (-32d) | 2021-07-29 → 2021-06-24 (-35d) |  |  | 747d → 772d |  |  |
| 168 | Execute IRT | 2021-07-30 → 2021-06-25 (-35d) | 2023-08-21 → 2023-07-17 (-35d) |  |  | 747d → 772d |  |  |
| 186 | **Transfers - Program Track** |  | 2024-10-16 → 2024-09-20 (-26d) | 1125d → 1107d | 15% → 17% | 445d → 463d |  |  |
| 187 | **Transfer Policy Review** |  | 2024-10-16 → 2024-09-20 (-26d) | 1125d → 1107d | 15% → 17% | 445d → 463d |  |  |
| 188 | **Transfer Issue Report** |  | 2021-02-23 A → 2021-02-04 A (-19d) | 170d → 157d |  |  |  |  |
| 189 | Develop Issues Report |  | 2021-02-23 A → 2021-02-04 A (-19d) | 170d → 157d |  |  |  |  |
| 191 | Council to approve PDP launch | 2021-02-24 → 2021-02-05 A (-19d) | 2021-03-09 → 2021-02-18 A (-19d) |  | 0% → 100% | 445d → none |  |  |
| 192 | Council to approve scope and charter | 2021-03-10 → 2021-02-19 A (-19d) | 2021-04-26 → 2021-03-31 (-26d) | 35d → 30d | 0% → 50% | 445d → 463d |  |  |
| 193 | Engage Transfer Policy Review PDP | 2021-04-27 → 2021-04-01 (-26d) | 2023-05-18 → 2023-04-24 (-24d) |  |  | 445d → 463d |  |  |
| 194 | Council to deliberate and adopt working group consensus recommendations | 2023-05-19 → 2023-04-25 (-24d) | 2023-07-12 → 2023-06-19 (-23d) |  |  | 445d → 463d |  |  |
| 195 | Board to deliberate and adopt consensus recommendations | 2023-07-13 → 2023-06-20 (-23d) | 2023-10-04 → 2023-09-08 (-26d) |  |  | 445d → 463d |  |  |
| 196 | Engage IRT | 2023-10-05 → 2023-09-11 (-24d) | 2024-10-16 → 2024-09-20 (-26d) |  |  | 445d → 463d |  |  |
| 197 | **IGO - Program Track** |  | 2023-06-13 → 2023-04-18 (-56d) | 773d → 733d | 1% → 5% | 797d → 837d |  |  |
| 198 | **PDP: RPM - IGO Curative Rights Work Track** |  | 2023-06-13 → 2023-04-18 (-56d) | 773d → 733d | 1% → 11% | 797d → 837d |  |  |
| 201 | Engage IGO-CRPM Work Track Policy Review PDP |  | 2022-01-12 → 2021-11-17 (-56d) | 270d → 230d | 3% → 28% |  |  |  |
| 202 | Council to deliberate and adopt working group consensus recommendations | 2022-01-13 → 2021-11-18 (-56d) | 2022-03-09 → 2022-01-12 (-56d) |  |  | 797d → 837d |  |  |
| 203 | Board to deliberate and adopt consensus recommendations | 2022-03-10 → 2022-01-13 (-56d) | 2022-06-01 → 2022-04-06 (-56d) |  |  | 797d → 837d |  |  |
| 204 | Engage IRT | 2022-06-02 → 2022-04-07 (-56d) | 2023-06-13 → 2023-04-18 (-56d) |  |  | 797d → 837d |  |  |
| 205 | **PDP: Curative Rights Protections for IGO/INGOs** | 2022-03-10 → 2022-01-13 (-56d) | 2023-06-13 → 2023-04-18 (-56d) |  |  | 797d → 837d |  |  |
| 206 | Board to deliberate and adopt consensus recommendations | 2022-03-10 → 2022-01-13 (-56d) | 2022-06-01 → 2022-04-06 (-56d) |  |  | 797d → 837d |  |  |
| 207 | Engage IRT | 2022-06-02 → 2022-04-07 (-56d) | 2023-06-13 → 2023-04-18 (-56d) |  |  | 797d → 837d |  |  |
| 208 | **PDP: Protection of International Organization Names in All gTLDs** | 2022-06-02 → 2022-04-07 (-56d) | 2023-06-13 → 2023-04-18 (-56d) |  |  | 797d → 837d |  |  |
| 209 | Engage IRT | 2022-06-02 → 2022-04-07 (-56d) | 2023-06-13 → 2023-04-18 (-56d) |  |  | 797d → 837d |  |  |
| 210 | **Accountability - Program Track** |  |  |  | 28% → 32% |  |  |  |
| 213 | **Cross Community Working Group on Enhancing ICANN Accountability - WS2** |  |  |  | 32% → 41% |  |  |  |
| 214 | Council small team to revew WS2 |  |  |  | 58% → 75% |  |  |  |
| 216 | **Multistakeholder Model Evolution** |  |  |  | 15% → 18% |  |  |  |
| 217 | Council to determine what is required of the GNSO |  |  |  | 15% → 18% |  |  |  |
| 220 | **Reviews - Program Track** |  |  |  | 19% → 23% |  |  |  |

| ID | Task | Start | Finish | Complete | Total float |
| --- | --- | --- | --- | --- | --- |
| 239 | **Accountability and Transparency Review 3** |  |  | 44% → 63% |  |
| 241 | Council to monitor for ATRT3 implementation assignments should the Board adopt ATRT3 recommendations |  |  | 40% → 60% |  |
| 245 | **Security, Stability and Resiliency of the DNS #2** |  |  | 78% → 89% |  |
| 247 | Council to consider SSR#2 Results | 2021-02-10 A |  | 0% → 50% |  |
| 257 | **Participant of Empowered Community** |  |  | 11% → 13% |  |
| 260 | Perform role 2021 |  |  | 25% → 35% |  |
| 269 | **GNSO Council** |  |  | 14% → 13% |  |
| 270 | **GNSO Council - Monthly Meetings** |  |  | 11% → 13% |  |
| 279 | GNSO Council Meeting | 2021-03-24 A | 2021-03-24 A | 0% → 100% |  |
| 343 | **GNSO Council - Leadership Meetings** |  |  | 11% → 13% |  |
| 352 | GNSO Council - Leadership Meetings | 2021-03-08 A | 2021-03-09 A | 0% → 100% |  |
| 416 | **GNSO Council - Action Items** |  |  | 11% → 13% |  |
| 425 | GNSO Council - Action Items | 2021-03-08 A | 2021-03-08 A | 0% → 100% |  |
| 510 | **GNSO Standing Selection Committee** |  |  | 20% → 14% |  |
| 511 | SSC fill positions as assigned |  |  | 20% → 14% |  |
| 538 | **ICANN Meeting Planning, Meeting, Respond to GAC Advice** |  |  | 9% → 11% |  |
| 543 | **ICANN70** |  |  | 51% → 84% |  |
| 544 | Meeting Planning |  | 2021-03-15 A | 65% → 100% | 1366d → none |
| 545 | ICANN Meeting | 2021-03-20 A | 2021-03-25 A | 0% → 100% | 1362d → none |

## Version 10 (saved 2021-04-12, file GNSO_Council_Program_Management_Tool_20210422.mpp)

Last finish stays 2026-06-30. Complete tasks 83 → 89.

Added:

| ID | Task | Duration | Start | Finish | Predecessors |
| --- | --- | --- | --- | --- | --- |
| 6 | Operation Design Phase | 270d | 2020-09-28 A | 2021-10-07 | 5 |

Changed:

| ID | Task | Start | Finish | Duration | Complete | Total float | Predecessors |
| --- | --- | --- | --- | --- | --- | --- | --- |
| 1 | **GNSO Program Management Planning** |  |  |  | 20% → 24% |  |  |
| 2 | **RDDS - Program Track** |  | 2023-09-18 → 2023-12-18 (+91d) | 843d → 908d | 23% → 36% | 727d → 662d |  |
| 3 | **EPDP: Temporary Specification on gTLD Registration Data - Phase 2** |  | 2023-09-18 → 2023-12-18 (+91d) | 843d → 908d | 21% → 8% | 727d → 662d |  |
| 7 | Board to deliberate and adopt consensus recommendations | 2020-09-28 A → 2021-10-08 (+375d) | 2021-09-23 → 2021-12-22 (+90d) | 260d → 55d | 45% → 0% | 727d → 662d | 5 → 6 |
| 8 | Engage IRT: Temporary Specification on gTLD Registration Data - Phase 2 | 2021-09-24 → 2021-12-23 (+90d) | 2023-09-18 → 2023-12-18 (+91d) |  |  | 727d → 662d |  |
| 9 | **Remaining EPDP-P2 Topics (Legal vs. Natural, Unique Contacts, + Accuracy )** |  |  |  | 20% → 22% |  |  |
| 10 | **Remaining EPDP-P2 Topics Track 1 (Legal vs. Natural + Feasability of Unique Contacts)** |  |  |  | 23% → 28% |  |  |
| 12 | Engage EPDP-P2A to address remaining topics |  |  |  | 34% → 49% |  |  |
| 35 | **IRT: Temporary Specification on gTLD Registration Data - Phase 1** |  |  |  | 32% → 50% |  |  |
| 37 | **EPDP-P1 Rec27 Wave 1 Other Policy Impacts** |  | 2021-10-22 → 2022-01-04 (+74d) | 344d → 397d | 31% → 52% | 1226d → 1173d |  |
| 40 | **Additional Whois Information Policy (AWIP) [LOW]** |  | 2021-02-04 → 2021-09-29 (+237d) | 110d → 280d | 41% → 55% | 1413d → 1243d |  |
| 42 | Review and confirm redlines for final changes | 2020-11-06 A | 2020-12-17 → 2021-08-11 (+237d) | 30d → 200d | 0% → 55% | 1413d → 1243d |  |
| 43 | Conduct public comment of changes | 2020-12-18 → 2021-08-12 (+237d) | 2021-01-28 → 2021-09-22 (+237d) |  |  | 1413d → 1243d |  |
| 44 | Post updated consensus policy | 2021-01-29 → 2021-09-23 (+237d) | 2021-02-04 → 2021-09-29 (+237d) |  |  | 1413d → 1243d |  |
| 45 | **Expired Domain Deletion Policy (EDDP) [MEDIUM]** |  | 2021-02-18 → 2021-09-29 (+223d) | 120d → 280d | 38% → 55% | 1403d → 1243d |  |
| 47 | Review and confirm redlines for final changes | 2020-11-06 A | 2020-12-31 → 2021-08-11 (+223d) | 40d → 200d | 0% → 55% | 1403d → 1243d |  |
| 48 | Conduct public comment of changes | 2021-01-01 → 2021-08-12 (+223d) | 2021-02-11 → 2021-09-22 (+223d) |  |  | 1403d → 1243d |  |
| 49 | Post updated consensus policy | 2021-02-12 → 2021-09-23 (+223d) | 2021-02-18 → 2021-09-29 (+223d) |  |  | 1403d → 1243d |  |
| 50 | **Expired Registration Recovery Policy (ERRP) [LOW]** |  | 2021-02-18 → 2021-09-29 (+223d) | 120d → 280d | 38% → 55% | 1403d → 1243d |  |
| 52 | Review and confirm redlines for final changes | 2020-11-06 A | 2020-12-31 → 2021-08-11 (+223d) | 40d → 200d | 0% → 55% | 1403d → 1243d |  |
| 53 | Conduct public comment of changes | 2021-01-01 → 2021-08-12 (+223d) | 2021-02-11 → 2021-09-22 (+223d) |  |  | 1403d → 1243d |  |
| 54 | Post updated consensus policy | 2021-02-12 → 2021-09-23 (+223d) | 2021-02-18 → 2021-09-29 (+223d) |  |  | 1403d → 1243d |  |
| 57 | **Registry Registration Data Directory Services Consistent Labeling and Display Policy (CL&D) [HIGH]** | 2020-08-03 → 2020-09-04 A (+32d) | 2020-12-04 → 2021-11-16 (+347d) | 90d → 315d | 0% → 38% | 0d → 1208d |  |
| 58 | Council to determine next steps based on EPDP-P1-IRT + Rec27 findings | 2020-09-04 A | 2020-11-26 → 2021-02-18 A (+84d) | 60d → 120d | 0% → 100% |  |  |
| 59 | Produce redlines of consensus policy provisions | 2020-08-03 → 2021-02-19 (+200d) | 2020-10-02 → 2021-09-15 (+348d) | 45d → 150d |  |  | none → 58 |
| 60 | Review and confirm redlines for final changes | 2020-10-05 → 2021-09-16 (+346d) | 2020-10-16 → 2021-09-29 (+348d) |  |  | 1457d → 1208d |  |
| 61 | Conduct public comment of changes | 2020-10-19 → 2021-09-30 (+346d) | 2020-11-27 → 2021-11-09 (+347d) |  |  | 1457d → 1208d |  |
| 62 | Post updated consensus policy | 2020-11-30 → 2021-11-10 (+345d) | 2020-12-04 → 2021-11-16 (+347d) |  |  | 1457d → 1208d |  |
| 65 | **Restored Names Accuracy Policy (RNAP) [LOW]** |  |  |  | 37% → 55% |  |  |
| 66 | **Track 1 - Item 1** |  | 2021-02-18 → 2021-09-29 (+223d) | 120d → 280d | 38% → 55% | 1403d → 1243d |  |
| 68 | Review and confirm redlines for final changes | 2020-11-06 A | 2020-12-31 → 2021-08-11 (+223d) | 40d → 200d | 0% → 55% | 1403d → 1243d |  |
| 69 | Conduct public comment of changes | 2021-01-01 → 2021-08-12 (+223d) | 2021-02-11 → 2021-09-22 (+223d) |  |  | 1403d → 1243d |  |
| 70 | Post updated consensus policy | 2021-02-12 → 2021-09-23 (+223d) | 2021-02-18 → 2021-09-29 (+223d) |  |  | 1403d → 1243d |  |
| 73 | **Revised ICANN Procedure for Handling Whois Conflicts with Privacy Law [LOW]** |  | 2021-02-18 → 2021-09-29 (+223d) | 120d → 280d | 38% → 55% | 1403d → 1243d |  |
| 74 | **Track 1 - Items 1 to 3** |  | 2021-02-18 → 2021-09-29 (+223d) | 120d → 280d | 38% → 55% | 1403d → 1243d |  |
| 76 | Review and confirm redlines for final changes | 2020-11-06 A | 2020-12-31 → 2021-08-11 (+223d) | 40d → 200d | 0% → 55% | 1403d → 1243d |  |
| 77 | Conduct public comment of changes | 2021-01-01 → 2021-08-12 (+223d) | 2021-02-11 → 2021-09-22 (+223d) |  |  | 1403d → 1243d |  |
| 78 | Post updated consensus policy | 2021-02-12 → 2021-09-23 (+223d) | 2021-02-18 → 2021-09-29 (+223d) |  |  | 1403d → 1243d |  |
| 79 | **Thick Whois Transition Policy for .COM, .NET, .JOBS [HIGH]** | 2020-09-04 A | 2021-01-07 → 2022-01-04 (+362d) | 90d → 350d | 0% → 34% | 0d → 1173d |  |
| 80 | Council to determine next steps based on EPDP-P1-IRT + Rec27 findings | 2020-09-04 A | 2020-11-26 → 2021-02-18 A (+84d) | 60d → 120d | 0% → 100% |  |  |
| 81 | Produce redlines of consensus policy provisions | 2020-09-04 → 2021-02-19 (+168d) | 2020-11-05 → 2021-04-21 (+167d) |  |  |  | none → 80 |
| 82 | Review and confirm redlines for final changes | 2020-11-06 → 2021-04-22 (+167d) | 2020-11-19 → 2021-11-16 (+362d) | 10d → 150d |  | 1433d → 1173d |  |
| 83 | Conduct public comment of changes | 2020-11-20 → 2021-11-17 (+362d) | 2020-12-31 → 2021-12-28 (+362d) |  |  | 1433d → 1173d |  |
| 84 | Post updated consensus policy | 2021-01-01 → 2021-12-29 (+362d) | 2021-01-07 → 2022-01-04 (+362d) |  |  | 1433d → 1173d |  |
| 85 | **Transfer Policy [HIGH]** |  | 2021-02-18 → 2021-09-29 (+223d) | 120d → 280d | 38% → 55% | 1403d → 1243d |  |
| 87 | Review and confirm redlines for final changes | 2020-11-06 A | 2020-12-31 → 2021-08-11 (+223d) | 40d → 200d | 0% → 55% | 1403d → 1243d |  |
| 88 | Conduct public comment of changes | 2021-01-01 → 2021-08-12 (+223d) | 2021-02-11 → 2021-09-22 (+223d) |  |  | 1403d → 1243d |  |
| 89 | Post updated consensus policy | 2021-02-12 → 2021-09-23 (+223d) | 2021-02-18 → 2021-09-29 (+223d) |  |  | 1403d → 1243d |  |
| 90 | **Transfer Dispute Resolution Policy (TDRP) [HIGH]** |  | 2021-02-18 → 2021-09-29 (+223d) | 120d → 280d | 38% → 55% | 1403d → 1243d |  |
| 92 | Review and confirm redlines for final changes | 2020-11-06 A | 2020-12-31 → 2021-08-11 (+223d) | 40d → 200d | 0% → 55% | 1403d → 1243d |  |
| 93 | Conduct public comment of changes | 2021-01-01 → 2021-08-12 (+223d) | 2021-02-11 → 2021-09-22 (+223d) |  |  | 1403d → 1243d |  |
| 94 | Post updated consensus policy | 2021-02-12 → 2021-09-23 (+223d) | 2021-02-18 → 2021-09-29 (+223d) |  |  | 1403d → 1243d |  |
| 95 | **Rules for Uniform Domain Name Dispute Resolution Policy (UDRP Rules) [HIGH]** |  | 2021-01-15 → 2021-11-03 (+292d) | 120d → 330d | 38% → 55% | 1427d → 1217d |  |
| 97 | Review and confirm redlines for final changes | 2020-10-05 A | 2020-11-27 → 2021-09-16 (+293d) | 40d → 250d | 0% → 55% | 1427d → 1217d |  |
| 98 | Conduct public comment of changes | 2020-11-30 → 2021-09-17 (+291d) | 2021-01-08 → 2021-10-27 (+292d) |  |  | 1427d → 1217d |  |
| 99 | Post updated consensus policy | 2021-01-11 → 2021-10-28 (+290d) | 2021-01-15 → 2021-11-03 (+292d) |  |  | 1427d → 1217d |  |
| 100 | **Uniform Rapid Suspension System Procedure (URS) [HIGH]** | 2021-05-05 A → 2020-08-03 A (-275d) | 2021-10-19 → 2021-11-03 (+15d) | 120d → 330d | 38% → 55% | 1229d → 1217d |  |
| 101 | Produce redlines of consensus policy provisions (Items 1,2 & 8) | 2021-05-05 A → 2020-08-03 A (-275d) | 2021-07-06 A → 2020-10-02 A (-277d) |  |  |  | 152 → none |
| 102 | Review and confirm redlines for final changes | 2021-07-07 → 2020-10-05 A (-275d) | 2021-08-31 → 2021-09-16 (+16d) | 40d → 250d | 0% → 55% | 1229d → 1217d |  |
| 103 | Conduct public comment of changes | 2021-09-01 → 2021-09-17 (+16d) | 2021-10-12 → 2021-10-27 (+15d) |  |  | 1229d → 1217d |  |
| 104 | Post updated consensus policy | 2021-10-13 → 2021-10-28 (+15d) | 2021-10-19 → 2021-11-03 (+15d) |  |  | 1229d → 1217d |  |
| 105 | **Uniform Rapid Suspension System Rules (URS Rules) [HIGH]** | 2021-05-05 A → 2020-08-03 A (-275d) | 2021-10-19 → 2021-11-03 (+15d) | 120d → 330d | 38% → 55% | 1229d → 1217d |  |
| 106 | Produce redlines of consensus policy provisions (Items 1&3) | 2021-05-05 A → 2020-08-03 A (-275d) | 2021-07-06 A → 2020-10-02 A (-277d) |  |  |  | 152 → none |
| 107 | Review and confirm redlines for final changes | 2021-07-07 → 2020-10-05 A (-275d) | 2021-08-31 → 2021-09-16 (+16d) | 40d → 250d | 0% → 55% | 1229d → 1217d |  |
| 108 | Conduct public comment of changes | 2021-09-01 → 2021-09-17 (+16d) | 2021-10-12 → 2021-10-27 (+15d) |  |  | 1229d → 1217d |  |
| 109 | Post updated consensus policy | 2021-10-13 → 2021-10-28 (+15d) | 2021-10-19 → 2021-11-03 (+15d) |  |  | 1229d → 1217d |  |
| 110 | **Whois Data Reminder Policy (WDRP) [MEDIUM]** |  |  |  | 37% → 55% |  |  |
| 111 | **Track 1 - Item 1** |  | 2021-02-18 → 2021-09-29 (+223d) | 120d → 280d | 38% → 55% | 1403d → 1243d |  |
| 113 | Review and confirm redlines for final changes | 2020-11-06 A | 2020-12-31 → 2021-08-11 (+223d) | 40d → 200d | 0% → 55% | 1403d → 1243d |  |
| 114 | Conduct public comment of changes | 2021-01-01 → 2021-08-12 (+223d) | 2021-02-11 → 2021-09-22 (+223d) |  |  | 1403d → 1243d |  |

| ID | Task | Start | Finish | Duration | Complete | Total float |
| --- | --- | --- | --- | --- | --- | --- |
| 115 | Post updated consensus policy | 2021-02-12 → 2021-09-23 (+223d) | 2021-02-18 → 2021-09-29 (+223d) |  |  | 1403d → 1243d |
| 118 | **Whois Marketing Restriction Policy [LOW]** |  | 2021-02-18 → 2021-09-29 (+223d) | 120d → 280d | 38% → 55% | 1403d → 1243d |
| 120 | Review and confirm redlines for final changes | 2020-11-06 A | 2020-12-31 → 2021-08-11 (+223d) | 40d → 200d | 0% → 55% | 1403d → 1243d |
| 121 | Conduct public comment of changes | 2021-01-01 → 2021-08-12 (+223d) | 2021-02-11 → 2021-09-22 (+223d) |  |  | 1403d → 1243d |
| 122 | Post updated consensus policy | 2021-02-12 → 2021-09-23 (+223d) | 2021-02-18 → 2021-09-29 (+223d) |  |  | 1403d → 1243d |
| 123 | **Revised ICANN Procedure for Handling Whois Conflicts with Privacy Law** |  | 2023-02-28 → 2023-04-24 (+55d) | 675d → 715d | 22% → 25% | 873d → 833d |
| 125 | Request ICANN org to develop revised proposal for invoking Procedure |  | 2021-06-02 → 2021-07-28 (+56d) | 160d → 200d | 55% → 60% | 873d → 833d |
| 126 | Council to deliberate findings and determine appropriate path | 2021-06-03 → 2021-07-29 (+56d) | 2021-08-04 → 2021-09-29 (+56d) |  |  | 873d → 833d |
| 127 | IF required, review WPIAG Charter to determine if it's fit for purpose | 2021-08-05 → 2021-09-30 (+56d) | 2021-09-15 → 2021-11-09 (+55d) |  |  | 873d → 833d |
| 128 | **IF required, Council to approve charter and launch WPIAG** | 2021-09-16 → 2021-11-10 (+55d) | 2022-02-08 → 2022-04-05 (+56d) |  |  | 873d → 833d |
| 129 | Engage WPIAG | 2021-09-16 → 2021-11-10 (+55d) | 2021-12-07 → 2022-02-01 (+56d) |  |  | 873d → 833d |
| 130 | Council to deliberate findings and determine appropriate path | 2021-12-08 → 2022-02-02 (+56d) | 2022-02-08 → 2022-04-05 (+56d) |  |  | 873d → 833d |
| 131 | **IF required, Council to approve launch of EPDP** | 2022-02-09 → 2022-04-06 (+56d) | 2023-02-28 → 2023-04-24 (+55d) |  |  | 873d → 833d |
| 132 | Engage EPDP: Temporary Specification on gTLD Registration Data - Phase 2 | 2022-02-09 → 2022-04-06 (+56d) | 2022-06-14 → 2022-08-09 (+56d) |  |  | 873d → 833d |
| 133 | Council to deliberate and adopt working group consensus recommendations | 2022-06-15 → 2022-08-10 (+56d) | 2022-08-16 → 2022-10-11 (+56d) |  |  | 873d → 833d |
| 134 | Board to deliberate and adopt consensus recommendations | 2022-08-17 → 2022-10-12 (+56d) | 2022-10-25 → 2022-12-20 (+56d) |  |  | 873d → 833d |
| 135 | Engage IRT: Temporary Specification on gTLD Registration Data - Phase 2 | 2022-10-26 → 2022-12-21 (+56d) | 2023-02-28 → 2023-04-24 (+55d) |  |  | 873d → 833d |
| 136 | **EPDP-P1 Rec27 Wave 1.5 & Wave 2 Other Policy Impacts** |  |  |  | 6% → 20% |  |
| 137 | Council to consider Wave 1.5 report and determine next steps |  |  |  | 16% → 50% |  |
| 143 | **RPM - Program Track** |  |  |  | 20% → 19% |  |
| 154 | **PDP: Review of All Rights Protection Mechanisms in All gTLDs - Phase 2 (UDRP)** |  |  |  | 2% → 1% |  |
| 155 | Drafting Team to draft new charter (incl. Items 2 through 11 of Rec27 Wave1) |  |  |  | 15% → 5% |  |
| 160 | **gTLD - Program Track** |  | 2023-08-09 → 2023-09-13 (+35d) | 815d → 840d | 22% → 26% | 755d → 730d |
| 161 | **CCWG: New gTLD Auction Proceeds Drafting Team (group completed 31 May 2020)** |  | 2022-05-18 → 2022-10-05 (+140d) | 470d → 570d | 34% → 30% | 1077d → 977d |
| 163 | Board to deliberate and adopt consensus recommendations |  | 2021-06-03 → 2021-10-21 (+140d) | 200d → 300d | 70% → 50% | 1077d → 977d |
| 164 | Implement program | 2021-06-04 → 2021-10-22 (+140d) | 2022-05-18 → 2022-10-05 (+140d) |  |  | 1077d → 977d |
| 165 | **PDP: New gTLD Subsequent Procedures PDP** |  | 2023-07-17 → 2023-08-28 (+42d) | 798d → 828d | 21% → 20% | 772d → 742d |
| 168 | Board to deliberate and adopt consensus recommendations |  | 2021-06-24 → 2021-08-05 (+42d) | 90d → 120d |  | 772d → 742d |
| 169 | Execute IRT | 2021-06-25 → 2021-08-06 (+42d) | 2023-07-17 → 2023-08-28 (+42d) |  |  | 772d → 742d |
| 170 | **Internationalized Domain Names** |  | 2023-08-09 → 2023-09-13 (+35d) | 815d → 840d | 18% → 29% | 755d → 730d |
| 174 | **IDN Policy Track 2 EPDP Working Group** |  | 2023-08-09 → 2023-09-13 (+35d) | 735d → 760d | 5% → 16% | 755d → 730d |
| 175 | Drafting Team to draft charter |  | 2021-04-26 → 2021-05-31 (+35d) | 135d → 160d | 25% → 75% |  |
| 176 | Engage Track 2 EPDP working group | 2021-04-27 → 2021-06-01 (+35d) | 2022-04-08 → 2022-05-13 (+35d) |  |  | 755d → 730d |
| 177 | Council to deliberate and adopt working group consensus recommendations | 2022-04-11 → 2022-05-16 (+35d) | 2022-06-03 → 2022-07-08 (+35d) |  |  | 755d → 730d |
| 178 | Board to deliberate and adopt consensus recommendations | 2022-06-06 → 2022-07-11 (+35d) | 2022-08-26 → 2022-09-30 (+35d) |  |  | 755d → 730d |
| 179 | Engage IRT | 2022-08-29 → 2022-10-03 (+35d) | 2023-08-09 → 2023-09-13 (+35d) |  |  | 755d → 730d |
| 180 | **IDN Track 3 Council Coordination** |  |  |  | 35% → 55% |  |
| 181 | GNSO Council to coordinate with the CCNSO regarding IDN policy developments |  |  |  | 35% → 55% |  |
| 187 | **Transfers - Program Track** |  |  |  | 17% → 19% |  |
| 188 | **Transfer Policy Review** |  |  |  | 17% → 19% |  |
| 193 | Council to approve scope and charter |  | 2021-03-31 A |  | 50% → 100% | 463d → none |
| 194 | Engage Transfer Policy Review PDP | 2021-04-01 A |  |  | 0% → 2% |  |
| 198 | **IGO - Program Track** |  |  |  | 5% → 6% |  |
| 199 | **PDP: RPM - IGO Curative Rights Work Track** |  |  |  | 11% → 12% |  |
| 202 | Engage IGO-CRPM Work Track Policy Review PDP |  |  |  | 28% → 30% |  |
| 211 | **Accountability - Program Track** |  |  |  | 32% → 25% |  |
| 214 | **Cross Community Working Group on Enhancing ICANN Accountability - WS2** |  | 2022-03-04 → 2022-04-15 (+42d) | 440d → 470d | 41% → 38% | 1130d → 1100d |
| 215 | Council small team to revew WS2 |  | 2021-05-31 → 2021-07-12 (+42d) | 240d → 270d | 75% → 67% |  |
| 216 | Council to determine what is required of the GNSO | 2021-06-01 → 2021-07-13 (+42d) | 2022-03-04 → 2022-04-15 (+42d) |  |  | 1130d → 1100d |
| 217 | **Multistakeholder Model Evolution** |  |  |  | 18% → 20% |  |
| 218 | Council to determine what is required of the GNSO |  |  |  | 18% → 20% |  |
| 219 | **Geo Regions Review** | 2020-07-01 A → 2020-07-01 |  |  | 40% → 0% |  |
| 220 | Council to determine what is required of the GNSO | 2020-07-01 A → 2020-07-01 |  |  | 40% → 0% |  |
| 221 | **Reviews - Program Track** |  |  |  | 23% → 21% |  |
| 240 | **Accountability and Transparency Review 3** |  | 2021-10-04 → 2022-05-27 (+235d) | 330d → 500d | 63% → 42% | 1240d → 1070d |
| 242 | Council to monitor for ATRT3 implementation assignments should the Board adopt ATRT3 recommendations |  | 2021-10-04 → 2022-05-27 (+235d) | 330d → 500d | 60% → 40% | 1240d → 1070d |
| 246 | **Security, Stability and Resiliency of the DNS #2** |  | 2021-04-12 → 2021-09-06 (+147d) | 205d → 310d | 89% → 64% | 1365d → 1260d |
| 248 | Council to consider SSR#2 Results |  | 2021-04-12 → 2021-09-06 (+147d) | 45d → 150d | 50% → 25% | 1365d → 1260d |
| 253 | **Policy & Implementation - Recommendations Review** | 2020-10-05 A → 2020-10-05 |  |  | 20% → 0% | 1025d → 0d |
| 254 | Council to decide to extend review beyond 5 years from Final Report | 2020-10-05 A → 2020-10-05 | 2021-04-15 → 2021-08-05 (+112d) | 140d → 220d | 50% → 0% |  |
| 258 | **Participant of Empowered Community** |  |  |  | 13% → 15% |  |
| 261 | Perform role 2021 |  |  |  | 35% → 45% |  |
| 271 | **GNSO Council - Monthly Meetings** |  |  |  | 13% → 14% |  |
| 281 | GNSO Council Meeting | 2021-04-22 A | 2021-04-22 A |  | 0% → 100% |  |
| 344 | **GNSO Council - Leadership Meetings** |  |  |  | 13% → 14% |  |
| 354 | GNSO Council - Leadership Meetings | 2021-04-12 A | 2021-04-13 A |  | 0% → 100% |  |
| 417 | **GNSO Council - Action Items** |  |  |  | 13% → 14% |  |
| 427 | GNSO Council - Action Items | 2021-04-12 A | 2021-04-12 A |  | 0% → 100% |  |
| 511 | **GNSO Standing Selection Committee** |  |  |  | 14% → 16% |  |
| 512 | SSC fill positions as assigned |  |  |  | 14% → 16% |  |

| ID | Task | Start | Complete |
| --- | --- | --- | --- |
| 539 | **ICANN Meeting Planning, Meeting, Respond to GAC Advice** |  | 11% → 12% |
| 544 | **ICANN70** |  | 84% → 92% |
| 547 | Respond to GAC Advice | 2021-03-26 A | 0% → 50% |
| 548 | **ICANN71** | 2021-04-01 A | 0% → 4% |
| 549 | Meeting Planning | 2021-04-01 A | 0% → 5% |
